# NGAO Design v7

How a schedule from MS Project changed from version to version. A marks actual dates.

## Version 1 (saved 2009-06-25, file NGAO_Design_B2C_Replan_v8_tracked_May09.mpp)

| ID | WBS | Task | Duration | Start | Finish | Predecessors | Complete | Total float | Constraint |
| --- | --- | --- | --- | --- | --- | --- | --- | --- | --- |
| 1 | 1 | **NGAO Design** | 1210d? | 2005-10-03 A | 2010-05-21 |  | 4% | 0d |  |
| 2 |  | Proposal | 195d? | 2005-10-03 | 2006-06-30 |  |  | 1015d | finish no earlier than 2006-06-30 |
| 3 |  | System Design | 413d? | 2006-10-02 | 2008-04-30 |  |  | 537d | finish no earlier than 2008-04-30 |
| 4 | 1.3 | **Preliminary Design** | 537d? | 2008-05-01 A | 2010-05-21 |  | 4% | 0d |  |
| 5 |  | PD Part I (May/08 through Apr/09) | 261d? | 2008-05-01 A | 2009-04-30 A |  | 100% |  | finish no earlier than 2009-04-30 |
| 6 | 1.3.2 | **PD Phase Management** | 276d? | 2009-05-01 A | 2010-05-21 |  | 7% | 0d |  |
| 7 | 1.3.2.1 | **Planning** | 231d? | 2009-05-01 A | 2010-03-19 |  | 21% | 45d |  |
| 8 | 1.3.2.1.1 | **Replans (PD phase)** | 30d? | 2009-05-04 A | 2009-06-12 |  | 75% | 245d |  |
| 9 |  | B2C Replan | 30d? | 2009-05-04 A | 2009-06-12 |  | 75% | 245d | start no earlier than 2009-05-04 |
| 10 | 1.3.2.1.2 | **WMKO FY Plans** | 21d? | 2009-05-01 A | 2009-05-29 A |  | 100% |  |  |
| 11 |  | Support WMKO FY10 Planning | 21d? | 2009-05-01 A | 2009-05-29 A |  | 100% |  | start no earlier than 2009-05-01 |
| 12 | 1.3.2.1.3 | **Systems Engineering Management Plan** | 178d? | 2009-07-15 | 2010-03-19 |  |  | 45d |  |
| 13 | 1.3.2.1.3.1 | **Project Plan** | 70d? | 2009-12-07 | 2010-03-12 |  |  | 50d |  |
| 14 |  | PBS, WBS & Task Definition | 25d? | 2009-12-07 | 2010-01-08 |  |  | 95d | finish no earlier than 2010-01-08 |
| 15 |  | Cost Estimation | 40d? | 2010-01-04 | 2010-02-26 |  |  | 60d | start no earlier than 2010-01-04 |
| 16 |  | Full Schedule (MS Project Plan) | 30d? | 2010-02-01 | 2010-03-12 |  |  | 50d | finish no earlier than 2010-03-12 |
| 17 | 1.3.2.1.3.2 | **Detailed Design Phase Plan** | 102d? | 2009-07-15 | 2009-12-03 |  |  | 121d |  |
| 18 |  | Detailed Design Plan v1 (TSIP proposal) | 18d? | 2009-07-15 | 2009-08-07 |  |  | 205d | start no earlier than 2009-07-15 |
| 19 |  | Detailed Design Plan Final Version | 19d? | 2009-11-09 | 2009-12-03 |  |  | 121d | start no earlier than 2009-11-09 |
| 20 |  | SEMP Document | 25d? | 2010-02-15 | 2010-03-19 |  |  | 44d | finish no earlier than 2010-03-19 |
| 21 | 1.3.2.2 | **Project Management & Meetings** | 261d? | 2009-05-01 A | 2010-04-30 |  | 8% | 15d |  |
| 22 | 1.3.2.2.1 | **Senior Management Committee** | 261d? | 2009-05-01 A | 2010-04-30 |  | 10% | 15d |  |
| 23 |  | Senior Management Activities | 261d? | 2009-05-01 A | 2010-04-30 |  | 10% | 15d | finish no earlier than 2010-04-30 |
| 24 |  | Senior Management Telecons | 261d? | 2009-05-01 A | 2010-04-30 |  | 10% | 15d | finish no earlier than 2010-04-30 |
| 25 | 1.3.2.2.2 | **Team Meetings** | 238d? | 2009-05-01 A | 2010-03-30 |  | 10% | 38d |  |
| 26 |  | Meeting Participation | 238d? | 2009-05-01 A | 2010-03-30 |  | 10% | 38d | start no earlier than 2009-05-01 |
| 27 | 1.3.2.2.3 | **NSAT Meetings/Telecons** | 232d | 2009-06-11 | 2010-04-30 |  |  | 15d |  |
| 28 |  | NSAT Meeting #1 | 0d | 2009-06-11 | 2009-06-11 |  |  | 247d | start no earlier than 2009-06-11 |
| 29 |  | NSAT Meetings/Telecons | 224d | 2009-06-23 | 2010-04-30 |  |  | 15d | finish no earlier than 2010-04-30 |
| 30 | 1.3.2.3 | **Tracking & Reporting** | 261d? | 2009-05-01 A | 2010-04-30 |  | 9% | 15d |  |
| 31 | 1.3.2.3.1 | **Monthly Status Reports** | 261d? | 2009-05-01 A | 2010-04-30 |  | 10% | 15d |  |
| 32 |  | Monthly Team Status Reports | 238.5d? | 2009-05-01 A | 2010-03-31 |  | 10% | 37.5d | start no earlier than 2009-05-01 |
| 33 |  | Monthly Project Reports (TSIP, Directors) | 261d? | 2009-05-01 A | 2010-04-30 |  | 10% | 15d | start no earlier than 2009-05-01 |
| 34 |  | TSIP Project Report Telecons | 261d? | 2009-05-01 A | 2010-04-30 |  | 10% | 15d | start no earlier than 2009-05-01 |
| 35 | 1.3.2.3.2 | **SSC Meetings** | 207.88d? | 2009-07-08 | 2010-04-23 |  |  | 20.12d |  |
| 36 |  | SSC Meeting (Keck) | 1.12d | 2009-07-08 | 2009-07-09 |  |  | 226.88d | start no earlier than 2009-07-08 |
| 37 |  | SSC Meeting (Caltech) | 1.12d | 2009-11-03 | 2009-11-04 |  |  | 142.88d | start no earlier than 2009-11-03 |
| 38 |  | SSC Meeting (Keck) | 1.88d? | 2010-02-24 | 2010-02-25 |  |  | 61.12d | start no earlier than 2010-02-24 |
| 39 |  | SSC Meeting (Caltech) | 1.88d? | 2010-04-22 | 2010-04-23 |  |  | 20.12d | start no earlier than 2010-04-22 |
| 40 | 1.3.2.3.3 | **Other Presentations** | 111d? | 2009-05-01 | 2009-10-02 |  |  | 165d |  |
| 41 |  | Keck Science Meeting 09 | 3d | 2009-09-17 | 2009-09-21 |  |  | 174d | start no earlier than 2009-09-17 |
| 42 |  | Other | 111d? | 2009-05-01 | 2009-10-02 |  |  | 165d | start no earlier than 2009-05-01 |
| 43 | 1.3.2.4 | **Proposals** | 216d? | 2009-05-01 A | 2010-02-26 |  | 1% | 60d |  |
| 44 |  | Advancement Support | 216d? | 2009-05-01 | 2010-02-26 |  |  | 60d | start no earlier than 2009-05-01 |
| 45 |  | MRI-R2 Proposals | 72d? | 2009-05-01 A | 2009-08-10 |  | 8% | 0d | finish no earlier than 2009-08-10 |
| 46 |  | TSIP Proposal | 77d? | 2009-06-01 | 2009-09-15 |  |  | 178d | start no earlier than 2009-06-01 |
| 47 |  | ATI Proposal(s) | 55d? | 2009-09-15 | 2009-11-30 |  |  | 124d | start no earlier than 2009-09-15 |
| 48 |  | MRI 2010 Proposal | 44d? | 2009-12-01 | 2010-01-29 |  |  | 80d | finish no earlier than 2010-01-29 |
| 49 | 1.3.2.5 | **Programmatic Risk Assessment & Mitigation** | 174d? | 2009-05-01 A | 2009-12-30 |  | 1% | 102d |  |
| 50 | 1.3.2.5.1 | **Risk Assessment** | 4.5d? | 2009-06-24 | 2009-06-30 |  |  | 233d |  |
| 51 |  | Programmatic Risk Assessment | 4.5d? | 2009-06-24 | 2009-06-30 |  |  | 233d | finish no earlier than 2009-06-30 |
| 52 | 1.3.2.5.2 | **Risk Mitigation** | 174d? | 2009-05-01 A | 2009-12-30 |  | 1% | 102d |  |
| 53 |  | Science Instruments | 174d? | 2009-05-01 A | 2009-12-30 |  | 2% | 102d | finish no earlier than 2009-12-30 |
| 54 |  | Funding | 174d? | 2009-05-01 | 2009-12-30 |  |  | 102d | finish no earlier than 2009-12-30 |
| 55 | 1.3.2.6 | **Preliminary Design Review** | 235d? | 2009-06-29 | 2010-05-21 |  |  | 0d |  |
| 56 |  | Define Success Criteria for all Reviews | 9d? | 2009-06-29 | 2009-07-09 |  |  | 226d | start no earlier than 2009-06-29 |
| 57 |  | Review Setup (Date, Participants, Charter) | 5d? | 2009-11-06 | 2009-11-12 |  |  | 136d | start no earlier than 2009-11-06 |
| 58 |  | Preliminary Design Report | 12d? | 2010-03-12 | 2010-03-29 |  |  | 38d | start no earlier than 2010-03-12 |
| 59 |  | Review Package Distributed | 1d? | 2010-04-02 | 2010-04-02 | 58, 20, 227 |  | 35d | start no earlier than 2010-04-02 |
| 60 |  | Reviewer Comments Received | 0d | 2010-04-16 | 2010-04-16 |  |  | 26d | start no earlier than 2010-04-16 |
| 61 |  | Reviewer Comments Addressed | 5d? | 2010-04-19 | 2010-04-23 |  |  | 20d | start no earlier than 2010-04-19 |
| 62 |  | PDR Presentation Preparation | 13d? | 2010-04-05 | 2010-04-21 |  |  | 22d | start no earlier than 2010-04-05 |
| 63 |  | Preliminary Design Review | 2d? | 2010-04-28 | 2010-04-29 |  |  | 16d | finish no earlier than 2010-04-29 |
| 64 |  | Reviewer Report Received | 0d | 2010-05-14 | 2010-05-14 |  |  | 6d | start no earlier than 2010-05-14 |
| 65 |  | Response to Reviewer Report | 5d? | 2010-05-17 | 2010-05-21 |  |  | 0d | start no earlier than 2010-05-17 |
| 66 | 1.3.2.7 | **Project Support** | 261d? | 2009-05-01 A | 2010-04-30 |  | 10% | 15d |  |
| 67 |  | Administrative/Contract Support | 261d? | 2009-05-01 A | 2010-04-30 |  | 10% | 15d | finish no earlier than 2010-04-30 |
| 68 |  | Shared Infrastructure | 215d? | 2009-05-04 A | 2010-02-26 |  | 10% | 60d | finish no earlier than 2010-02-26 |
| 69 | 1.3.3 | **Systems Engineering** | 261d? | 2009-05-01 A | 2010-04-30 |  | 2% | 15d |  |
| 70 | 1.3.3.1 | **Science Case Requirements** | 261d? | 2009-05-01 | 2010-04-30 |  |  | 15d |  |

| ID | WBS | Task | Duration | Start | Finish | Predecessors | Complete | Total float | Constraint |
| --- | --- | --- | --- | --- | --- | --- | --- | --- | --- |
| 71 | 1.3.3.1.1 | **Science Case Requirements** | 238d? | 2009-05-01 | 2010-03-30 |  |  | 38d |  |
| 72 | 1.3.3.1.1.1 | **Science Simulations** | 238d? | 2009-05-01 | 2010-03-30 |  |  | 38d |  |
| 73 |  | High-z Galaxies | 227d? | 2009-05-01 | 2010-03-15 |  |  | 49d | start no earlier than 2009-05-01 |
| 74 |  | BH Measurements in Nearby AGN | 207d? | 2009-05-01 | 2010-02-15 |  |  | 69d | start no earlier than 2009-05-01 |
| 75 |  | Galactic Center | 186d? | 2009-05-01 | 2010-01-15 |  |  | 90d | finish no earlier than 2010-01-15 |
| 76 |  | Extrasolar Planets | 110d? | 2009-06-22 | 2009-11-20 |  |  | 130d | start no earlier than 2009-06-22 |
| 77 |  | Asteroids | 86d? | 2009-07-06 | 2009-11-02 |  |  | 144d | start no earlier than 2009-07-06 |
| 78 |  | Resolved Stellar Populations | 30d? | 2010-01-05 | 2010-02-15 |  |  | 69d | start no earlier than 2010-01-05 |
| 79 |  | Debris Disks and QSO Host Galaxies | 32d? | 2009-11-02 | 2009-12-15 |  |  | 113d | start no earlier than 2009-11-02 |
| 80 |  | Other Science Write-ups | 61d? | 2010-01-05 | 2010-03-30 |  |  | 38d | start no earlier than 2010-01-05 |
| 81 | 1.3.3.1.1.2 | **Extend SCRD Discussion of Science Drivers** | 39d? | 2010-01-05 | 2010-02-26 |  |  | 60d |  |
| 82 |  | Nearby AGNs | 39d? | 2010-01-05 | 2010-02-26 |  |  | 60d | start no earlier than 2010-01-05 |
| 83 |  | Gravitational Lensing | 35d? | 2010-01-11 | 2010-02-26 |  |  | 60d | start no earlier than 2010-01-11 |
| 84 |  | Backup Science | 20d? | 2010-02-01 | 2010-02-26 |  |  | 60d | start no earlier than 2010-02-01 |
| 85 |  | Science Requirements Summary Matrix | 22d? | 2010-02-15 | 2010-03-16 |  |  | 48d | start no earlier than 2010-02-15 |
| 86 |  | Review Science Requirements in Requirements Database | 43d? | 2009-05-18 | 2009-07-15 |  |  | 222d | start no earlier than 2009-05-18 |
| 87 |  | SEMP Input | 75d? | 2009-12-07 | 2010-03-19 |  |  | 45d | start no earlier than 2009-12-07 |
| 88 | 1.3.3.1.2 | **Science Observing Planning & Execution** | 43d? | 2009-05-01 | 2009-06-30 |  |  | 233d |  |
| 89 |  | Develop Observing Scenarios for all Key Science Drivers | 43d? | 2009-05-01 | 2009-06-30 |  |  | 233d | start no earlier than 2009-05-01 |
| 90 | 1.3.3.1.3 | **Science Performance Input** | 216d? | 2009-05-01 | 2010-02-26 |  |  | 60d |  |
| 91 |  | Define Specific Science Driver Parameters for Performance Budgets | 110d? | 2009-06-22 | 2009-11-20 |  |  | 130d | start no earlier than 2009-06-22 |
| 92 |  | Input to User Interfaces, Planning & Observing Tools | 39d? | 2010-01-05 | 2010-02-26 |  |  | 60d | finish no earlier than 2010-02-26 |
| 93 |  | Input to Preliminary Operations Concept Document | 216d? | 2009-05-01 | 2010-02-26 |  |  | 60d | start no earlier than 2009-05-01 |
| 94 | 1.3.3.1.4 | **Science Competitiveness** | 231d? | 2009-05-01 | 2010-03-19 |  |  | 45d |  |
| 95 |  | Update List of Science Goals for Other Facilities | 231d? | 2009-05-01 | 2010-03-19 |  |  | 45d | start no earlier than 2009-05-01 |
| 96 |  | Evaluate NGAO Potential to Compliment Other Facilities | 231d? | 2009-05-01 | 2010-03-19 |  |  | 45d | start no earlier than 2009-05-01 |
| 97 | 1.3.3.1.5 | **User Community Liaison** | 261d? | 2009-05-01 | 2010-04-30 |  |  | 15d |  |
| 98 | 1.3.3.1.5.1 | **SSC & Keck Science Meeting** | 238d? | 2009-05-01 | 2010-03-30 |  |  | 38d |  |
| 99 |  | Prepare & Give Presentations | 238d? | 2009-05-01 | 2010-03-30 |  |  | 38d | start no earlier than 2009-05-01 |
| 100 |  | Obtain & Document Feedback | 238d? | 2009-05-01 | 2010-03-30 |  |  | 38d | start no earlier than 2009-05-01 |
| 101 |  | Proposal Writing | 238d? | 2009-05-01 | 2010-03-30 |  |  | 38d | start no earlier than 2009-05-01 |
| 102 |  | Progress Reporting | 261d? | 2009-05-01 | 2010-04-30 |  |  | 15d | start no earlier than 2009-05-01 |
| 103 | 1.3.3.1.6 | **Science Advisory Team Meetings** | 261d? | 2009-05-01 | 2010-04-30 |  |  | 15d |  |
| 104 |  | Prepare Minutes, Presentations & KAONs | 261d? | 2009-05-01 | 2010-04-30 |  |  | 15d | start no earlier than 2009-05-01 |
| 105 |  | Evaluate Science Impact of Proposed Changes | 216d? | 2009-05-01 | 2010-02-26 |  |  | 60d | start no earlier than 2009-05-01 |
| 106 |  | Science Postdoc Research Time | 261d? | 2009-05-01 | 2010-04-30 |  |  | 15d | finish no earlier than 2010-04-30 |
| 107 | 1.3.3.2 | **Requirements** | 239d? | 2009-05-01 A | 2010-03-31 |  | 11% | 37d |  |
| 108 | 1.3.3.2.1 | **Operations Concept Document (OCD)** | 166d? | 2009-05-01 A | 2009-12-18 |  | 13% | 110d |  |
| 109 |  | OOCD Release 1 | 31d? | 2009-05-01 A | 2009-06-12 |  | 35% | 245d | start no earlier than 2009-05-01 |
| 110 |  | OOCD Release 2 | 55d? | 2009-10-05 | 2009-12-18 |  |  | 110d | start no earlier than 2009-10-05 |
| 111 | 1.3.3.2.2 | **System Requirements (SRD)** | 161d? | 2009-05-01 | 2009-12-11 |  |  | 115d |  |
| 112 |  | SRD PD Release 1 | 50d? | 2009-05-01 | 2009-07-09 |  |  | 226d | start no earlier than 2009-05-01 |
| 113 |  | SRD PD Release 2 | 25d? | 2009-11-09 | 2009-12-11 |  |  | 115d | start no earlier than 2009-11-09 |
| 114 | 1.3.3.2.3 | **Functional Requirements (FRD)** | 239d? | 2009-05-01 A | 2010-03-31 |  | 23% | 37d |  |
| 115 |  | FRD PD Release 1 | 50d? | 2009-05-01 A | 2009-07-09 |  | 43% | 226d | start no earlier than 2009-05-01 |
| 116 |  | FRD PD Release 2 | 20d? | 2010-02-01 | 2010-02-26 |  |  | 60d | finish no earlier than 2010-02-26 |
| 117 |  | Compliance Matrix | 23d? | 2010-03-01 | 2010-03-31 |  |  | 37d | finish no earlier than 2010-03-31 |
| 118 |  | Software Standards (Define & Document) | 25d? | 2009-05-01 | 2009-06-04 |  |  | 251d | start no earlier than 2009-05-01 |
| 119 |  | Component Standards (Define & Document) | 20d? | 2010-01-04 | 2010-01-29 |  |  | 80d | finish no earlier than 2010-01-29 |
| 120 | 1.3.3.3 | **Systems Engineering Analysis** | 252d? | 2009-05-01 A | 2010-04-19 |  | 1% | 24d |  |
| 121 | 1.3.3.3.1 | **Performance Budgets** | 166.67d? | 2009-05-01 A | 2009-12-21 |  | 1% | 84.33d |  |
| 122 | 1.3.3.3.1.1 | **Wavefront Error and Ensquared Energy** | 132.29d? | 2009-05-01 A | 2009-11-03 |  | 4% | 118.71d |  |
| 123 |  | LOWFS Sharpening WFE Budgets | 50d? | 2009-05-08 | 2009-07-16 | 127 |  | 131.5d | start no earlier than 2008-10-06 |
| 124 |  | LOWFS Low-order/Blind mode WFE Budget vs. Sky Coverage (linked) | 15d? | 2009-08-12 | 2009-09-01 | 168 |  | 163d | start no earlier than 2009-04-17 |
| 125 |  | Truth WFS Performance Budget | 15.62d? | 2009-08-28 | 2009-09-18 | 123 |  | 118.71d | start no earlier than 2009-08-28 |
| 126 | 1.3.3.3.1.1.4 | **Science Wavefront Error Flowdown Budgets** | 125.62d? | 2009-05-01 A | 2009-10-23 |  | 7% | 125.38d |  |
| 127 |  | Requirements Flowdown Methodology Memo | 5d? | 2009-05-01 A | 2009-05-07 |  | 50% | 131.5d | start no earlier than 2009-05-01 |
| 128 |  | Laser Photoreturn Budget Flowdown | 10d? | 2009-05-04 A | 2009-05-15 |  | 5% | 240d | start no earlier than 2009-05-04 |
| 129 |  | Correction Latency Budget Flowdown | 10d? | 2009-10-09 | 2009-10-23 | 147 |  | 118.71d | start no earlier than 2009-04-18 |
| 130 |  | Science Transmission Budget Flowdown | 10d? | 2009-05-08 A | 2009-05-21 | 127 | 5% | 236d | start no earlier than 2009-05-01 |
| 131 |  | Non-common Path WFE Budget Flowdown | 40d? | 2009-05-04 A | 2009-06-26 |  | 5% | 210d | start no earlier than 2009-05-04 |
| 132 |  | Uncorrectable Internal WFE Budget Flowdown | 6d? | 2009-05-04 A | 2009-05-11 |  | 5% | 244d | start no earlier than 2009-05-04 |
| 133 |  | Actuator-Pupil Registration Budget Flowdown | 10d? | 2009-05-01 A | 2009-05-14 |  | 5% | 241d | start no earlier than 2009-05-01 |
| 134 | 1.3.3.3.1.1.5 | **LOWFS Wavefront Error Flowdown Budgets** | 131.29d? | 2009-05-04 A | 2009-11-03 |  | 3% | 118.71d |  |
| 135 |  | LOWFS Uncorrectable Internal WFE Budget Flowdown | 6.67d? | 2009-05-04 A | 2009-05-12 |  | 5% | 243.33d | start no earlier than 2009-05-04 |
| 136 |  | LOWFS Servo Latency Budget Flowdown | 6.67d? | 2009-10-23 | 2009-11-03 | 129, 147 |  | 118.71d | start no earlier than 2009-04-18 |
| 137 | 1.3.3.3.1.2 | **Astrometric Precision** | 125d? | 2009-05-04 | 2009-10-23 |  |  | 125d |  |
| 138 |  | Develop Astrometric Budget Tool | 41.67d? | 2009-07-30 | 2009-09-25 | 143 |  | 125d | start no earlier than 2009-06-01 |
| 139 |  | Galactic Center Astrometric Analysis | 20d? | 2009-09-28 | 2009-10-23 | 138 |  | 125d | start no earlier than 2009-01-05 |
| 140 | 1.3.3.3.1.2.3 | **Astrometric Precision Flowdown Budgets** | 20d? | 2009-05-04 | 2009-05-29 |  |  | 230d |  |

| ID | WBS | Task | Duration | Start | Finish | Predecessors | Complete | Total float | Constraint |
| --- | --- | --- | --- | --- | --- | --- | --- | --- | --- |
| 141 |  | Dimensional Stability Budget Flowdown | 20d? | 2009-05-04 | 2009-05-29 |  |  | 230d | start no earlier than 2009-05-04 |
| 142 | 1.3.3.3.1.3 | **High Contrast** | 59.33d? | 2009-06-15 | 2009-09-04 |  |  | 125d |  |
| 143 |  | High Contrast Error Budget | 33.33d? | 2009-06-15 | 2009-07-30 |  |  | 125d | start no earlier than 2009-06-15 |
| 144 |  | High Contrast Error Flowdown | 26d? | 2009-07-30 | 2009-09-04 | 143 |  | 160.67d |  |
| 145 | 1.3.3.3.1.4 | **WFE/EE Budget Tool** | 166.67d? | 2009-05-01 | 2009-12-21 |  |  | 84.33d |  |
| 146 |  | Science Cases Performance Analysis | 50d? | 2009-06-17 | 2009-08-25 | 127 |  | 168d | start no earlier than 2009-06-17 |
| 147 |  | Improved Servo Bandwidth Model | 15d? | 2009-09-18 | 2009-10-09 | 125 |  | 118.71d | start no earlier than 2008-12-01 |
| 148 |  | Update Star Density Model(s) | 10d? | 2009-07-27 | 2009-08-07 |  |  | 180d | start no earlier than 2009-07-27 |
| 149 |  | Other WFE/EE Budget Tool Maintenance | 166.67d? | 2009-05-01 | 2009-12-21 |  |  | 84.33d | start no earlier than 2009-05-01 |
| 150 | 1.3.3.3.2 | **Engineering Budgets** | 191.67d? | 2009-05-01 A | 2010-01-25 |  | 8% | 84.33d |  |
| 151 | 1.3.3.3.2.1 | **Observing Efficiency** | 33.33d? | 2009-05-25 | 2009-07-09 |  |  | 226.67d |  |
| 152 |  | Observing Efficiency Analysis | 33.33d? | 2009-05-25 | 2009-07-09 |  |  | 226.67d | start no earlier than 2009-05-25 |
| 153 | 1.3.3.3.2.2 | **Observing Uptime** | 100d? | 2009-05-01 A | 2009-09-17 |  | 13% | 176d |  |
| 154 |  | Develop Observing Uptime Tool | 50d? | 2009-05-01 A | 2009-07-09 |  | 25% | 176d | start no earlier than 2009-05-01 |
| 155 |  | Observing Uptime Analysis | 50d? | 2009-07-10 | 2009-09-17 | 154 |  | 176d |  |
| 156 |  | Electrical Power Usage Budget | 25d? | 2009-12-21 | 2010-01-25 | 121 |  | 84.33d | start no earlier than 2009-04-16 |
| 157 |  | Heat Dissipation Budget | 1d? | 2009-05-15 | 2009-05-15 |  |  | 265d | start no earlier than 2009-05-15 |
| 158 | 1.3.3.3.3 | **Modeling & Analysis** | 252d? | 2009-05-01 A | 2010-04-19 |  |  | 24d |  |
| 159 |  | Sys Eng Support for Proposal Efforts | 239d? | 2009-05-01 | 2010-03-31 |  |  | 37d | finish no earlier than 2010-03-31 |
| 160 |  | Point and Shoot Subsystem Report | 23d? | 2009-11-16 | 2009-12-16 | 123, 172 |  | 45.5d | start no earlier than 2009-11-16 |
| 161 |  | Performance vs T/T NGS Report | 25.5d? | 2009-12-17 | 2010-01-21 | 160 |  | 45.5d | start no earlier than 2008-09-01 |
| 162 |  | Galactic Center Performance Report | 41d? | 2010-01-21 | 2010-03-19 | 161, 172 |  | 45.5d | start no earlier than 2009-03-02 |
| 163 |  | PSF Libraries (moved by linked tasks) | 124d? | 2009-10-28 | 2010-04-19 | 172 |  | 24d | finish no earlier than 2010-03-19 |
| 164 |  | Additional Performance Modeling/Anchoring | 27.5d? | 2010-02-10 | 2010-03-19 |  |  | 45d | finish no earlier than 2010-03-19 |
| 165 | 1.3.3.3.3.7 | **Integrated modeling** | 107d? | 2009-06-01 A | 2009-10-27 |  | 1% | 148d |  |
| 166 |  | MOAO capabilities added to LAOS | 32d? | 2009-06-01 A | 2009-07-14 |  | 5% | 24d | start no earlier than 2009-06-01 |
| 167 |  | Na Focus NGS focus | 20d? | 2009-07-15 | 2009-08-11 | 166 |  | 203d | start no earlier than 2009-04-21 |
| 168 |  | Tracking, Null mode & Blind Modes | 20d? | 2009-07-15 | 2009-08-11 | 166 |  | 24d | start no earlier than 2009-04-21 |
| 169 |  | Keck Pupil Rotation Effects (Analog Keck II PRC system) | 5d? | 2009-08-12 | 2009-08-18 | 168 |  | 24d | start no earlier than 2009-04-21 |
| 170 |  | WFS Physical Optics Effects (Na Var., Spot Var., DM-Lens Reg., etc.) | 25d? | 2009-08-19 | 2009-09-22 | 169 |  | 24d | start no earlier than 2009-04-21 |
| 171 |  | Cn2 Variability | 5d? | 2009-09-23 | 2009-09-29 | 170 |  | 24d | start no earlier than 2009-04-21 |
| 172 |  | "All- in" simulations (Suggested links to other tasks) | 20d? | 2009-09-30 | 2009-10-27 | 168, 171 |  | 24d | start no earlier than 2009-04-21 |
| 173 |  | PSF Calibration | 100d? | 2009-07-01 | 2009-11-17 |  |  | 133d | start no earlier than 2009-07-01 |
| 174 | 1.3.3.4 | **System Architecture** | 216d? | 2009-05-01 A | 2010-02-26 |  | 12% | 60d |  |
| 175 | 1.3.3.4.1 | **System Hardware Architecture** | 176d? | 2009-05-08 A | 2010-01-08 |  | 5% | 95d |  |
| 176 |  | Maintain Hardware Architecture | 176d? | 2009-05-08 A | 2010-01-08 |  | 5% | 95d | start no earlier than 2009-05-08 |
| 177 | 1.3.3.4.2 | **Software Architecture** | 66d? | 2009-05-01 A | 2009-07-31 |  | 30% | 60.5d |  |
| 178 |  | Container-Component Model | 5d? | 2009-05-01 A | 2009-05-07 A |  | 100% |  | start no earlier than 2009-05-01 |
| 179 | 1.3.3.4.2.2 | **Controls SW Infrastructure** | 41d? | 2009-05-08 A | 2009-07-03 | 178 | 41% | 60.5d |  |
| 180 |  | Class decomposition | 5d | 2009-05-08 A | 2009-05-14 |  | 75% | -19d | start no earlier than 2009-05-08 |
| 181 |  | Command-response pattern | 2.5d | 2009-05-15 A | 2009-05-19 | 180 | 75% | 71.75d | start no earlier than 2009-05-15 |
| 182 |  | Base component definition | 5d | 2009-05-19 A | 2009-05-26 | 181 | 75% | 68d | start no earlier than 2009-05-19 |
| 183 |  | Middleware abstraction | 5d? | 2009-05-26 A | 2009-06-02 | 182 | 75% | 64.25d | start no earlier than 2009-05-26 |
| 184 |  | Naming Scheme | 2.5d? | 2009-06-02 A | 2009-06-04 | 183 | 50% | 63d | start no earlier than 2009-05-08 |
| 185 |  | Configuration | 11d | 2009-06-05 | 2009-06-19 | 184 |  | 63d | start no earlier than 2009-05-08 |
| 186 |  | Common services | 10d? | 2009-06-22 A | 2009-07-03 | 185 | 25% | 60.5d | start no earlier than 2009-05-29 |
| 187 |  | Sequencer Architecture | 5d? | 2009-07-06 | 2009-07-10 | 186 |  | 60.5d | start no earlier than 2009-06-26 |
| 188 |  | UI Architecture | 5d? | 2009-07-13 | 2009-07-17 | 187 |  | 60.5d | start no earlier than 2009-06-26 |
| 189 |  | Middleware Evaluation | 43d? | 2009-05-01 A | 2009-06-30 |  | 25% | 73.5d | finish no earlier than 2009-06-30 |
| 190 |  | Document software architecture | 10d? | 2009-07-20 | 2009-07-31 | 188, 189 |  | 60.5d | start no earlier than 2009-07-03 |
| 191 | 1.3.3.4.3 | **Control Systems Architecture** | 206d? | 2009-05-15 A | 2010-02-26 |  | 13% | 60d |  |
| 192 |  | Controls hierarchy and philosophy | 5d? | 2009-08-03 | 2009-08-07 | 190 |  | 60.5d |  |
| 193 |  | Common state machine design | 5d? | 2009-08-10 | 2009-08-14 | 192 |  | 60.5d | start no earlier than 2008-07-17 |
| 194 |  | Class-Responsibility-Collaborator model | 10d? | 2009-08-17 A | 2009-08-28 | 193 | 25% | 60.5d |  |
| 195 |  | Main sequence definition | 10d? | 2009-08-31 | 2009-09-11 | 194 |  | 60.5d |  |
| 196 |  | Device control electronics architecture | 20d? | 2009-05-18 A | 2009-06-12 |  | 25% | 45d | start no earlier than 2009-05-18 |
| 197 |  | Motion control architecture update 1 | 33d? | 2009-05-15 A | 2009-06-30 |  | 25% | 233d | start no earlier than 2009-05-15 |
| 198 |  | Motion control architecture update 2 | 20d? | 2010-02-01 | 2010-02-26 |  |  | 60d | finish no earlier than 2010-02-26 |
| 199 |  | Document controls architecture | 16d? | 2009-09-14 | 2009-10-05 | 196, 195 |  | 164d |  |
| 200 | 1.3.3.4.4 | **Operations Sequences Architecture** | 65d? | 2009-07-13 | 2009-10-09 |  |  | 160d |  |
| 201 |  | Define Required System Level Sequences | 25d? | 2009-07-13 | 2009-08-14 |  |  | 200d | finish no earlier than 2009-08-14 |
| 202 |  | Sequences Definition Document | 40d? | 2009-08-17 | 2009-10-09 |  |  | 160d | start no earlier than 2009-08-17 |
| 203 | 1.3.3.5 | **External Interface Control** | 131d? | 2009-05-01 A | 2009-10-30 |  | 7% | 145d |  |
| 204 | 1.3.3.5.1 | **Observatory Interfaces** | 131d? | 2009-05-01 A | 2009-10-30 |  | 7% | 145d |  |
| 205 |  | AO to Telescope Optoelectromech ICD | 41d? | 2009-05-01 A | 2009-06-26 |  | 4% | 235d | finish no earlier than 2009-06-26 |
| 206 |  | AO to Keck Interferometer ICD | 55d? | 2009-05-25 | 2009-08-07 |  |  | 205d | finish no earlier than 2009-08-07 |
| 207 |  | AO to Telescope Acq, Guiding, & Pointing ICD | 13.33d? | 2009-08-10 | 2009-08-27 |  |  | 191.67d | start no earlier than 2009-08-10 |
| 208 |  | LGSF to Telescope Optoelectromech ICD | 88d? | 2009-07-01 | 2009-10-30 |  |  | 145d | finish no earlier than 2009-10-30 |
| 209 |  | LGSF to Telescope Software ICD | 26.67d? | 2009-09-15 A | 2009-10-21 |  | 50% | 152.33d | start no earlier than 2009-09-15 |
| 210 | 1.3.3.6 | **Internal Interface Control** | 148.67d? | 2009-06-15 A | 2010-01-07 |  | 8% | 96.33d |  |

| ID | WBS | Task | Duration | Start | Finish | Predecessors | Complete | Total float | Constraint |
| --- | --- | --- | --- | --- | --- | --- | --- | --- | --- |
| 211 |  | AO to NIR IFS ICD | 40d? | 2009-06-15 A | 2009-08-07 |  | 5% | 205d | start no earlier than 2009-06-15 |
| 212 |  | AO to LGSF ICD | 26.67d? | 2009-07-20 A | 2009-08-25 |  | 44% | 193.33d | start no earlier than 2009-07-20 |
| 213 |  | Multicommand Sequencer ICD | 26.67d? | 2009-08-25 | 2009-09-30 |  |  | 167.33d | start no earlier than 2009-08-25 |
| 214 |  | Data Server Telemetry ICD | 26.67d? | 2009-10-05 | 2009-11-10 |  |  | 138.33d | start no earlier than 2009-10-05 |
| 215 |  | Data Server Diagnostics ICD | 26.67d? | 2009-12-02 | 2010-01-07 |  |  | 96.33d | start no earlier than 2009-12-02 |
| 216 |  | Instrument to AO Science Tools ICD | 22d? | 2009-08-03 | 2009-09-01 |  |  | 188d | start no earlier than 2009-08-03 |
| 217 | 1.3.3.7 | **Configuration Control** | 41d? | 2009-10-05 | 2009-11-30 |  |  | 124d |  |
| 218 |  | Change Control Guidelines & Tools Definition | 41d? | 2009-10-05 | 2009-11-30 |  |  | 124d | finish no earlier than 2009-11-30 |
| 219 | 1.3.3.8 | **Documentation Control** | 149.6d? | 2009-05-01 | 2009-11-26 |  |  | 126.4d |  |
| 220 |  | Document Control Guidelines & Tools Definition | 149.6d? | 2009-05-01 | 2009-11-26 |  |  | 126.4d | start no earlier than 2009-05-01 |
| 221 | 1.3.3.9 | **Technical Risk Assessment & Mitigation** | 66d? | 2009-07-01 | 2009-09-30 |  |  | 167d |  |
| 222 | 1.3.3.9.1 | **Risk Assessment** | 25d? | 2009-07-27 | 2009-08-28 |  |  | 190d |  |
| 223 |  | Risk Assessment | 25d? | 2009-07-27 | 2009-08-28 |  |  | 190d | finish no earlier than 2009-08-28 |
| 224 | 1.3.3.9.2 | **Risk Mitigation Efforts** | 66d? | 2009-07-01 | 2009-09-30 |  |  | 167d |  |
| 225 | 1.3.3.9.2.1 | **PSF Calibration** | 66d? | 2009-07-01 | 2009-09-30 |  |  | 167d |  |
| 226 |  | Support/Monitor Profiler Implementation | 66d? | 2009-07-01 | 2009-09-30 |  |  | 167d | start no earlier than 2009-07-01 |
| 227 |  | Preliminary Design Manual | 20d? | 2010-03-05 | 2010-04-01 |  |  | 35d | finish no earlier than 2010-04-01 |
| 228 | 1.3.4 | **AO System Design** | 221.24d? | 2009-05-01 A | 2010-03-08 |  | 4% | 54.76d |  |
| 229 |  | AO Enclosure | 130d? | 2009-06-01 | 2009-11-27 |  |  | 125d | start no earlier than 2009-06-01 |
| 230 | 1.3.4.2 | **Opto-Mechanical** | 221.24d? | 2009-05-01 A | 2010-03-08 |  | 2% | 54.76d |  |
| 231 |  | AO Support Structure | 45d? | 2009-06-01 | 2009-07-31 |  |  | 210d | finish no earlier than 2009-07-31 |
| 232 |  | Rotator | 43d? | 2009-08-03 | 2009-09-30 |  |  | 167d | finish no earlier than 2009-09-30 |
| 233 |  | Optical Relays | 66d? | 2009-05-01 A | 2009-07-31 |  | 20% | 210d | finish no earlier than 2009-07-31 |
| 234 |  | Optical Switchyard | 15d? | 2009-06-01 | 2009-06-19 |  |  | 240d | finish no earlier than 2009-06-19 |
| 235 | 1.3.4.2.5 | **LGS Wavefront Sensor Assembly** | 101.67d? | 2009-05-20 A | 2009-10-08 |  | 1% | 62.76d |  |
| 236 |  | Review and conceptualize design for the LGS wavefront sensor unit | 10d | 2009-05-20 | 2009-06-02 |  |  | 64.85d | start no earlier than 2009-05-20 |
| 237 |  | Identify the issues with uplink TTM, asterism generation and OSM concepts to ensure it conforms to the dithering requirements | 15d | 2009-06-03 | 2009-06-23 | 236 |  | 65.68d |  |
| 238 |  | Develop optical design for the LGS Shack-Hartmann sensor | 10d? | 2009-06-24 A | 2009-07-07 | 237 | 5% | 109.43d |  |
| 239 |  | Develop optical design for LGS WFS OSM arms | 20d? | 2009-07-08 | 2009-08-04 | 238 |  | 109.43d |  |
| 240 |  | Interface LGS WFS design to overall NGAO Optical design | 75d? | 2009-05-20 | 2009-09-01 | 236SS |  | 89.43d |  |
| 241 | 1.3.4.2.5.6 | **Mechanical Detail of the LGS WFS Ass'ly** | 91.67d | 2009-06-03 A | 2009-10-08 |  | 2% | 62.76d |  |
| 242 |  | Design PnS LGS WFS sensor assl'y (including OSM) | 41.67d | 2009-06-03 A | 2009-07-30 | 236 | 5% | 62.76d |  |
| 243 |  | Design the science LGS WFS sensor (including tetrahedron pickoff) | 21.43d | 2009-07-30 | 2009-08-31 | 242 |  | 62.76d |  |
| 244 |  | Overall LGS WFS structure mechanical design | 28.57d | 2009-08-31 | 2009-10-08 | 243 |  | 62.76d | finish no earlier than 2009-07-30 |
| 245 |  | Identify stray light issues (incl. Rayleigh scatter) | 50d | 2009-06-24 | 2009-09-01 | 237 |  | 81.93d |  |
| 246 |  | Simulate/ conceptualize and design solutions to stray light | 7.5d | 2009-09-02 | 2009-09-11 | 245 |  | 81.93d | finish no earlier than 2009-07-09 |
| 247 |  | Identify LGS WFS motion control needs and specify solutions. | 18.75d | 2009-06-24 | 2009-07-20 | 237 |  | 65.68d |  |
| 248 |  | Identify LGS WFS design risks and mitigation | 15d | 2009-07-20 | 2009-08-10 | 247 |  | 65.68d |  |
| 249 |  | Develop preliminary LGS WFS ass'ly integration plan | 30d | 2009-08-10 | 2009-09-21 | 248 |  | 65.68d |  |
| 250 |  | Write LGS WFS Ass'ly Documentation as a KAON | 10d | 2009-09-21 | 2009-10-05 | 249 |  | 65.68d |  |
| 251 | 1.3.4.2.6 | **NGS Wavefront Sensor Assembly** | 86.57d? | 2009-11-05 | 2010-03-08 |  |  | 54.76d |  |
| 252 |  | Review concept design for NGS WFS assembly | 53.57d | 2009-11-05 | 2010-01-20 | 235FS-12w, 261FS-12w |  | 62.76d |  |
| 253 |  | Develop optical design for the NGS WFS | 10.71d? | 2010-01-28 | 2010-02-12 | 235, 261 |  | 70.62d |  |
| 254 |  | Interface NGS WFS design to overall NGAO optical design | 66.67d? | 2009-11-05 | 2010-02-08 | 235FS-12w, 261FS-12w |  | 74.67d |  |
| 255 |  | Develop mechanical detail for the NGS WFS ass'ly | 25d | 2010-01-20 | 2010-02-24 | 252 |  | 62.76d | finish no earlier than 2009-10-30 |
| 256 |  | Check compliance of design with the design of the field steering mirror assembly | 4d | 2010-02-18 | 2010-02-24 | 255FF |  | 62.76d |  |
| 257 |  | Identify NGS WFS motion control needs and specify solutions | 5d | 2010-01-20 | 2010-01-27 | 255SS |  | 54.76d | start no earlier than 2009-06-15 |
| 258 |  | Identify NGS WFS design risks and mitigation | 10d | 2010-01-27 | 2010-02-10 | 257 |  | 54.76d |  |
| 259 |  | Check compliance with alignment plan for the NGS OSM (written as part of opto-mechanical relay sub-system design effort). | 8d | 2010-02-10 | 2010-02-22 | 258 |  | 54.76d |  |
| 260 |  | Write NGS WFS Ass'ly Documentation as a KAON | 10d | 2010-02-22 | 2010-03-08 | 259 |  | 54.76d | finish no earlier than 2009-11-02 |
| 261 | 1.3.4.2.7 | **Low Order Wavefront Sensor Assembly** | 181.67d? | 2009-05-20 A | 2010-01-28 |  |  | 62.76d |  |
| 262 |  | Review concept design for LOWFS assembly | 50d | 2009-05-20 | 2009-07-28 | 235SS |  | 84.43d |  |
| 263 |  | Developing optimal dithering strategy | 40d | 2009-07-15 | 2009-09-08 | 262SS+8w |  | 84.43d |  |
| 264 |  | Develop optical design of the TT and TTFA/TWFS sensors | 15d? | 2009-10-08 | 2009-10-29 | 263, 235 |  | 62.76d |  |
| 265 |  | Develop thermal model and work emissivity details of the LOWFS assembly and feed into the overall emissivity budget | 10d | 2009-10-29 | 2009-11-12 | 264 |  | 66.1d |  |
| 266 | 1.3.4.2.7.5 | **Mechanical detail of the LOWFS ass'ly** | 82.92d? | 2009-10-05 | 2010-01-28 |  |  | 62.76d |  |
| 267 |  | Develop TT and TTFA/TWFS OSM | 25d? | 2009-10-05 | 2009-11-09 | 250 |  | 120.68d |  |
| 268 |  | Design the TT and the TTFA/TWFS sensor mechanics | 45d | 2009-10-29 | 2009-12-31 | 264 |  | 62.76d |  |
| 269 |  | Design the LOWFS cryostat | 30d | 2009-12-17 | 2010-01-28 | 268FS-2w |  | 62.76d |  |
| 270 |  | Develop future PSF monitor sensor option | 35.71d | 2009-10-08 | 2009-11-27 | 264SS |  | 107.05d |  |
| 271 |  | Identify LOWFS WFS motion control needs and specify solutions | 20d | 2009-10-05 A | 2009-11-02 | 267SS | 5% | 125.68d | start no earlier than 2009-06-15 |
| 272 |  | Identify LOWFS design risks and mitigation | 20d | 2009-11-12 | 2009-12-10 | 265 |  | 66.1d |  |
| 273 |  | Develop preliminary LOWFS ass'ly integration plan | 10d | 2009-12-10 | 2009-12-24 | 272 |  | 66.1d |  |
| 274 |  | Develop an initial performance verification test plan | 20d | 2009-12-03 | 2009-12-31 | 273FS-3w |  | 66.1d |  |
| 275 |  | Write LOWFS Ass'ly Documentation as a KAON | 16.67d | 2009-12-31 | 2010-01-25 | 274 |  | 66.1d | finish no earlier than 2009-11-02 |
| 276 | 1.3.4.2.8 | **Tip/Tilt Vibration Mitigation** | 31d? | 2009-05-01 A | 2009-06-12 |  | 25% | 245d |  |
| 277 |  | TT Vibration Mitigation Analysis | 31d? | 2009-05-01 A | 2009-06-12 |  | 25% | 245d | finish no earlier than 2009-06-12 |
| 278 | 1.3.4.2.9 | **Acquisition Cameras** | 65d? | 2009-08-03 | 2009-10-30 |  |  | 145d |  |
| 279 |  | Acquisition Camera Implementation Issues | 20d? | 2009-08-03 | 2009-08-28 |  |  | 190d | start no earlier than 2009-08-03 |
| 280 |  | Acquisition Camera Opto-Mechanical Design | 20d? | 2009-10-01 | 2009-10-30 |  |  | 145d | start no earlier than 2009-10-01 |

| ID | WBS | Task | Duration | Start | Finish | Complete | Total float | Constraint |
| --- | --- | --- | --- | --- | --- | --- | --- | --- |
| 281 | 1.3.4.2.10 | **Atmospheric Dispersion Correctors** | 43d? | 2009-07-01 | 2009-08-28 |  | 190d |  |
| 282 |  | LOWFS ADCs Mechanical Location | 20d? | 2009-08-03 | 2009-08-28 |  | 190d | finish no earlier than 2009-08-28 |
| 283 |  | Science ADC | 22d? | 2009-07-01 | 2009-07-30 |  | 211d | finish no earlier than 2009-07-30 |
| 284 | 1.3.4.3 | **Alignment, Calibration & Diagnostics** | 100d? | 2009-08-03 A | 2009-12-18 | 1% | 110d |  |
| 285 | 1.3.4.3.1 | **Simulator** | 50d? | 2009-08-03 A | 2009-10-09 | 2% | 160d |  |
| 286 |  | Simulator Requirements & Interfaces | 10d? | 2009-08-03 A | 2009-08-14 | 10% | 200d | start no earlier than 2009-08-03 |
| 287 |  | Simulator Optical Design | 10d? | 2009-08-17 | 2009-08-28 |  | 190d | start no earlier than 2009-08-17 |
| 288 |  | Simulator Mechanical Design | 10d? | 2009-08-31 | 2009-09-11 |  | 180d | start no earlier than 2009-08-31 |
| 289 |  | Simulator Electrical Design | 25d? | 2009-08-17 | 2009-09-18 |  | 175d | finish no earlier than 2009-09-18 |
| 290 |  | Simulator Assembly, Alignment & Test Plans | 10d? | 2009-09-28 | 2009-10-09 |  | 160d | start no earlier than 2009-09-28 |
| 291 | 1.3.4.3.2 | **System Alignment Tools** | 50d? | 2009-10-12 | 2009-12-18 |  | 110d |  |
| 292 |  | Alignment Requirements & Interfaces | 10d? | 2009-10-12 | 2009-10-23 |  | 150d | start no earlier than 2009-10-12 |
| 293 |  | Alignment Optical Design | 10d? | 2009-10-26 | 2009-11-06 |  | 140d | start no earlier than 2009-10-26 |
| 294 |  | Alignment Mechanical Design | 10d? | 2009-11-09 | 2009-11-20 |  | 130d | start no earlier than 2009-11-09 |
| 295 |  | Alignment Electrical Design | 10d? | 2009-11-23 | 2009-12-04 |  | 120d | start no earlier than 2009-11-23 |
| 296 |  | Alignment Assembly, Alignment & Test Plans | 10d? | 2009-12-07 | 2009-12-18 |  | 110d | start no earlier than 2009-12-07 |
| 297 | 1.3.4.4 | **Real-time Control** | 221d? | 2009-05-01 A | 2010-03-05 | 5% | 55d |  |
| 298 | 1.3.4.4.1 | **RTC Processor** | 221d? | 2009-05-01 A | 2010-03-05 | 6% | 55d |  |
| 299 |  | RTC Technical Management | 1743.42h? | 2009-05-01 A | 2010-03-02 | 10% | 58.07d | start no earlier than 2009-05-01 |
| 300 | 1.3.4.4.1.2 | **Develop Internal Budgets** | 35.59d? | 2009-05-01 A | 2009-06-19 | 38% | 240.41d |  |
| 301 |  | Wavefront Error Budget | 28.59d? | 2009-05-01 A | 2009-06-19 | 33% | 240.41d | start no earlier than 2009-05-01 |
| 302 |  | Power Budget | 34d? | 2009-05-04 A | 2009-06-18 | 20% | 241d | start no earlier than 2009-05-03 |
| 303 |  | Volume Budget | 33d | 2009-05-04 A | 2009-06-17 | 60% | 242d | start no earlier than 2009-05-03 |
| 304 | 1.3.4.4.1.3 | **Algorithm Development Support** | 60d? | 2009-05-01 | 2009-07-23 |  | 216d |  |
| 305 |  | MPP off-line simulator | 60d? | 2009-05-01 | 2009-07-23 |  | 216d | start no earlier than 2009-05-01 |
| 306 |  | Split tomography algorithm development | 14d? | 2009-05-01 | 2009-05-20 |  | 262d | start no earlier than 2009-05-01 |
| 307 |  | Woofer-tweeter algorithm development | 19d? | 2009-05-01 | 2009-05-27 |  | 257d | finish no earlier than 2009-05-27 |
| 308 | 1.3.4.4.1.4 | **RTC Hardware** | 175d? | 2009-05-01 | 2009-12-31 |  | 101d |  |
| 309 |  | Number and Function of RTC Processor Boards | 87d? | 2009-05-01 | 2009-08-31 |  | 189d | finish no earlier than 2009-08-31 |
| 310 |  | Layout of Processors on Boards | 66d? | 2009-05-01 | 2009-07-31 |  | 210d | start no earlier than 2009-05-01 |
| 311 |  | Interconnect of processors on-board | 34d? | 2009-06-29 | 2009-08-13 |  | 201d | finish no earlier than 2009-08-13 |
| 312 |  | Interconnection of boards to each other | 142d? | 2009-05-01 | 2009-11-16 |  | 134d | start no earlier than 2009-05-01 |
| 313 |  | Clock Distribution and Synchronization | 59d? | 2009-05-25 | 2009-08-13 |  | 201d | start no earlier than 2009-05-25 |
| 314 |  | Trade chip processing capacity with power dissipation capacity and manage generated heat | 15d? | 2009-06-08 | 2009-06-26 |  | 235d | finish no earlier than 2009-06-26 |
| 315 |  | Hardware Interfaces to HOWFS and LOWFS cameras | 124d? | 2009-07-13 | 2009-12-31 |  | 101d | finish no earlier than 2009-12-31 |
| 316 |  | Hardware Interfaces to DM drivers | 135d? | 2009-05-01 | 2009-11-05 |  | 141d | start no earlier than 2009-05-01 |
| 317 |  | Hardware Interface to Telemetry Data Capture System | 137d? | 2009-06-08 | 2009-12-15 |  | 113d | finish no earlier than 2009-12-15 |
| 318 | 1.3.4.4.1.5 | **RTC Software - Time-critical tasks on Processing Engine (PE)** | 109d? | 2009-05-01 A | 2009-09-30 | 27% | 167d |  |
| 319 |  | Wavefront reconstructor software | 43d? | 2009-05-01 A | 2009-06-30 | 60% | 233d | finish no earlier than 2009-06-30 |
| 320 |  | Tomography Algorithm Software | 46d? | 2009-05-01 A | 2009-07-03 | 60% | 230d | finish no earlier than 2009-07-03 |
| 321 |  | DM Control Software (inverse DM response function and open-loop control) | 17d? | 2009-07-27 | 2009-08-18 |  | 198d | finish no earlier than 2009-08-18 |
| 322 |  | Pseudo-Open Loop Control Software | 33d? | 2009-08-17 | 2009-09-30 |  | 167d | finish no earlier than 2009-09-30 |
| 323 | 1.3.4.4.1.5.5 | **Telemetry and Diagnostic Streams Software - RTC side** | 61.67d? | 2009-07-06 | 2009-09-29 |  | 168.33d |  |
| 324 |  | Telemetry Data Streams Software | 10.42d? | 2009-07-06 | 2009-07-20 |  | 219.58d | start no earlier than 2009-07-06 |
| 325 | 1.3.4.4.1.5.5.2 | **Monitoring and Diagnostics Streams Software** | 51.67d? | 2009-07-20 | 2009-09-29 |  | 168.33d |  |
| 326 |  | Periodic and On-Demand Status Updates Stream to supervisory control | 31d? | 2009-07-20 | 2009-08-31 |  | 189d | finish no earlier than 2009-08-31 |
| 327 |  | Self-monitoring and Alarms | 16.67d? | 2009-09-07 | 2009-09-29 |  | 168.33d | start no earlier than 2009-09-07 |
| 328 | 1.3.4.4.1.6 | **RTC Software - non-time-critical tasks on Control Processor** | 45d? | 2009-06-01 A | 2009-07-31 | 20% | 210d |  |
| 329 |  | Parameter Loader | 45d? | 2009-06-01 A | 2009-07-31 | 20% | 210d | finish no earlier than 2009-07-31 |
| 330 |  | Real-time Control Sequencer | 25d? | 2009-06-01 A | 2009-07-03 | 20% | 230d | start no earlier than 2009-06-01 |
| 331 | 1.3.4.4.1.7 | **Software Internal Interfaces** | 175d? | 2009-05-01 | 2009-12-31 |  | 101d |  |
| 332 |  | Control Processor (CP) to Processing Engine (PE) | 65d? | 2009-06-29 | 2009-09-25 |  | 170d | finish no earlier than 2009-09-25 |
| 333 | 1.3.4.4.1.7.2 | **WFS Camera Interfaces** | 146d? | 2009-05-01 | 2009-11-20 |  | 130d |  |
| 334 |  | HOWFS Camera Interface | 146d? | 2009-05-01 | 2009-11-20 |  | 130d | finish no earlier than 2009-11-20 |
| 335 |  | LOWFS Camera Interface | 25d? | 2009-05-25 | 2009-06-26 |  | 235d | start no earlier than 2009-05-25 |
| 336 |  | DM Driver Interfaces | 89d? | 2009-08-31 | 2009-12-31 |  | 101d | finish no earlier than 2009-12-31 |
| 337 | 1.3.4.4.1.8 | **Software External Interfaces** | 25d? | 2009-09-14 A | 2009-10-16 | 5% | 155d |  |
| 338 |  | RTC Server on Control Processor (CP) | 25d? | 2009-09-14 A | 2009-10-16 | 5% | 155d | start no earlier than 2009-09-14 |
| 339 |  | Interface to Data Telemetry Capture System | 25d? | 2009-09-14 A | 2009-10-16 | 5% | 155d | start no earlier than 2009-09-14 |
| 340 | 1.3.4.4.1.9 | **RTC Integration and Testing Plan** | 175d? | 2009-05-01 A | 2009-12-31 | 6% | 101d |  |
| 341 |  | Hardware Test Plan | 89d? | 2009-08-31 | 2009-12-31 |  | 101d | finish no earlier than 2009-12-31 |
| 342 | 1.3.4.4.1.9.2 | **Software Test Plan** | 162d? | 2009-05-01 A | 2009-12-14 | 7% | 114d |  |
| 343 |  | Centroider / Wavefront Reconstructor test | 156d? | 2009-05-01 A | 2009-12-04 | 10% | 120d | finish no earlier than 2009-12-04 |
| 344 |  | Tomography Test | 50d? | 2009-09-28 | 2009-12-04 |  | 120d | finish no earlier than 2009-12-04 |
| 345 |  | LOWFS processing test | 151d? | 2009-05-01 A | 2009-11-27 | 10% | 125d | finish no earlier than 2009-11-27 |
| 346 |  | DM processing test | 61d? | 2009-09-14 | 2009-12-07 |  | 119d | finish no earlier than 2009-12-07 |
| 347 |  | Hybrid control loop test | 66d? | 2009-09-14 | 2009-12-14 |  | 114d | finish no earlier than 2009-12-14 |
| 348 |  | External interfaces test | 141d? | 2009-05-01 A | 2009-11-13 | 10% | 135d | finish no earlier than 2009-11-13 |
| 349 | 1.3.4.4.1.10 | **Documentation** | 186d? | 2009-05-01 A | 2010-01-15 | 3% | 90d |  |
| 350 |  | Summary of Documents | 2d? | 2009-05-01 A | 2009-05-04 | 5% | 274d | finish no earlier than 2009-05-04 |

| ID | WBS | Task | Duration | Start | Finish | Complete | Total float | Constraint |
| --- | --- | --- | --- | --- | --- | --- | --- | --- |
| 351 |  | Control Loops and Offloading Paths Diagram | 43d? | 2009-05-01 A | 2009-06-30 | 5% | 233d | finish no earlier than 2009-06-30 |
| 352 |  | Processor Engine (PE) design | 131d? | 2009-05-01 A | 2009-10-30 | 1% | 145d | finish no earlier than 2009-10-30 |
| 353 |  | RTC Algorithms Description | 124d? | 2009-05-01 A | 2009-10-21 | 5% | 152d | finish no earlier than 2009-10-21 |
| 354 |  | Control Processor (CP) design | 128d? | 2009-05-01 A | 2009-10-27 | 5% | 148d | finish no earlier than 2009-10-27 |
| 355 |  | Hardware Interface Documentation | 175d? | 2009-05-01 A | 2009-12-31 | 1% | 101d | finish no earlier than 2009-12-31 |
| 356 |  | Integration and Test Plan | 55d? | 2009-11-02 A | 2010-01-15 | 1% | 90d | finish no earlier than 2010-01-15 |
| 357 | 1.3.4.4.1.10.8 | **Document milestones** | 121d? | 2009-05-15 | 2009-10-30 |  | 145d |  |
| 358 |  | Version 0.1 | 1d? | 2009-05-15 | 2009-05-15 |  | 265d | start no earlier than 2009-05-15 |
| 359 |  | Version 0.2 | 1d? | 2009-08-31 | 2009-08-31 |  | 189d | start no earlier than 2009-08-31 |
| 360 |  | Version 1.0 | 1d? | 2009-10-30 | 2009-10-30 |  | 145d | start no earlier than 2009-10-30 |
| 361 | 1.3.4.4.1.11 | **Costing and Design Iteration Milestones** | 70d? | 2009-11-30 | 2010-03-05 |  | 55d |  |
| 362 |  | Update 1 to cost estimate | 1d? | 2009-11-30 | 2009-11-30 |  | 124d | start no earlier than 2009-11-30 |
| 363 |  | Design Iteration 1 | 1d? | 2010-01-29 | 2010-01-29 |  | 80d | start no earlier than 2010-01-29 |
| 364 |  | Update 2 to cost estimate | 1d? | 2010-03-05 | 2010-03-05 |  | 55d | start no earlier than 2010-03-05 |
| 365 | 1.3.4.4.2 | **DMs & Tip/Tilt Stages** | 96d? | 2009-05-01 | 2009-09-11 |  | 180d |  |
| 366 | 1.3.4.4.2.1 | **Woofer DM/TT** | 96d? | 2009-05-01 | 2009-09-11 |  | 180d |  |
| 367 |  | Evaluate Tip/Tilt Mount Options | 71d? | 2009-05-01 | 2009-08-07 |  | 205d | finish no earlier than 2009-08-07 |
| 368 |  | Evaluate Combined DM & Tip/Tilt Performance | 11d? | 2009-08-07 | 2009-08-21 |  | 195d | finish no earlier than 2009-08-21 |
| 369 |  | Select Tip/Tilt Mount | 6d? | 2009-08-21 | 2009-08-28 |  | 190d | finish no earlier than 2009-08-28 |
| 370 |  | Design Mechanical Package | 11d? | 2009-08-28 | 2009-09-11 |  | 180d | finish no earlier than 2009-09-11 |
| 371 |  | Obtain Quotes | 66d? | 2009-05-01 | 2009-07-31 |  | 210d | start no earlier than 2009-05-01 |
| 372 | 1.3.4.4.2.2 | **Tweeter DM/TT** | 87d? | 2009-05-01 | 2009-08-31 |  | 189d |  |
| 373 |  | Evaluate Options & Select Tip/Tilt Mount | 66d? | 2009-05-01 | 2009-07-31 |  | 210d | finish no earlier than 2009-07-31 |
| 374 |  | Design Mechanical Package | 10d? | 2009-08-03 | 2009-08-14 |  | 200d | start no earlier than 2009-08-03 |
| 375 |  | Obtain Quotes | 87d? | 2009-05-01 | 2009-08-31 |  | 189d | finish no earlier than 2009-08-31 |
| 376 | 1.3.4.4.2.3 | **LOWFS DM/TT** | 90d? | 2009-05-01 | 2009-09-03 |  | 186d |  |
| 377 |  | Evaluate Options & Select Tip/Tilt Mount | 46d? | 2009-05-01 | 2009-07-03 |  | 230d | finish no earlier than 2009-07-03 |
| 378 |  | Design Mechanical Package | 26d? | 2009-07-03 | 2009-08-07 |  | 205d | finish no earlier than 2009-08-07 |
| 379 |  | Obtain Quotes | 90d? | 2009-05-01 | 2009-09-03 |  | 186d | finish no earlier than 2009-09-03 |
| 380 | 1.3.4.5 | **AO System Lab I&T** | 80d? | 2009-11-02 | 2010-02-19 |  | 65d |  |
| 381 |  | AO System Lab I&T Scope Definition | 6.25d? | 2009-11-02 | 2009-11-10 |  | 138.75d | start no earlier than 2009-11-02 |
| 382 |  | AO System Lab Facility Plan | 70d? | 2009-11-16 | 2010-02-19 |  | 65d | finish no earlier than 2010-02-19 |
| 383 |  | AO System Lab Integration Plan | 70d? | 2009-11-16 | 2010-02-19 |  | 65d | finish no earlier than 2010-02-19 |
| 384 |  | AO System Lab Test Plan | 70d? | 2009-11-16 | 2010-02-19 |  | 65d | finish no earlier than 2010-02-19 |
| 385 | 1.3.5 | **Laser Guide Star Facility (LGSF) Design** | 241d? | 2009-04-28 A | 2010-03-30 | 25% | 38d |  |
| 386 | 1.3.5.1 | **Laser Enclosure (LE)** | 45d? | 2009-10-05 | 2009-12-04 |  | 120d |  |
| 387 |  | LE Mechanical Design | 10d? | 2009-10-05 | 2009-10-16 |  | 155d | start no earlier than 2009-10-05 |
| 388 |  | LE Environmental Control Design | 12d? | 2009-10-19 | 2009-11-03 |  | 143d | start no earlier than 2009-10-19 |
| 389 |  | LE Assembly & Test Plans | 10d? | 2009-11-23 | 2009-12-04 |  | 120d | start no earlier than 2009-11-23 |
| 390 | 1.3.5.2 | **Laser Units** | 241d? | 2009-04-28 A | 2010-03-30 | 6% | 38d |  |
| 391 |  | Laser PD Contract Management | 174d? | 2009-05-01 A | 2009-12-30 | 10% | 102d | start no earlier than 2009-05-01 |
| 392 |  | Laser Preliminary Design Evaluations | 39d? | 2009-10-15 | 2009-12-08 |  | 118d | start no earlier than 2009-10-15 |
| 393 |  | Laser Detailed Design Definition/Collaborations | 76d? | 2009-12-15 | 2010-03-30 |  | 38d | start no earlier than 2009-12-15 |
| 394 | 1.3.5.2.4 | **FASORtronics PD Milestones** | 144d | 2009-04-28 | 2009-11-16 |  | 135d |  |
| 395 |  | Progress Report 1 | 0d | 2009-04-28 | 2009-04-28 |  | 279d | start no earlier than 2009-04-28 |
| 396 |  | Progress Report 2 | 0d | 2009-06-24 | 2009-06-24 |  | 238d | start no earlier than 2009-06-24 |
| 397 |  | Progress Report 3 | 0d | 2009-08-26 | 2009-08-26 |  | 193d | start no earlier than 2009-08-26 |
| 398 |  | Progress Report 4 | 0d | 2009-10-28 | 2009-10-28 |  | 148d | start no earlier than 2009-10-28 |
| 399 |  | Preliminary Design Review | 0d | 2009-11-16 | 2009-11-16 |  | 135d | start no earlier than 2009-11-16 |
| 400 | 1.3.5.2.5 | **TOPTICA PD Milestones** | 141d | 2009-05-15 | 2009-11-30 |  | 125d |  |
| 401 |  | Progress Report 1 | 0d | 2009-05-15 | 2009-05-15 |  | 266d | start no earlier than 2009-05-15 |
| 402 |  | Progress Report 2 | 0d | 2009-06-19 | 2009-06-19 |  | 241d | start no earlier than 2009-06-19 |
| 403 |  | Progress Report 3 | 0d | 2009-08-04 | 2009-08-04 |  | 209d | start no earlier than 2009-08-04 |
| 404 |  | Progress Report 4 | 0d | 2009-10-15 | 2009-10-15 |  | 157d | start no earlier than 2009-10-15 |
| 405 |  | Preliminary Design Review | 0d | 2009-11-30 | 2009-11-30 |  | 125d | start no earlier than 2009-11-30 |
| 406 | 1.3.5.2.6 | **AURA Sub-Award Quarterly Reports** | 174d | 2009-04-30 | 2009-12-30 |  | 103d |  |
| 407 |  | Report 1 | 0d | 2009-04-30 | 2009-04-30 |  | 277d | start no earlier than 2009-04-30 |
| 408 |  | Report 2 | 0d | 2009-06-30 | 2009-06-30 |  | 234d | start no earlier than 2009-06-30 |
| 409 |  | Report 3 | 0d | 2009-09-30 | 2009-09-30 |  | 168d | start no earlier than 2009-09-30 |
| 410 |  | Final Report | 0d | 2009-12-30 | 2009-12-30 |  | 103d | start no earlier than 2009-12-30 |
| 411 | 1.3.5.3 | **Laser Launch Facility (LLF)** | 161d? | 2009-05-01 A | 2009-12-11 | 19% | 115d |  |
| 412 |  | LLF Requirements & Interfaces | 41d? | 2009-05-01 A | 2009-06-26 | 90% | 235d | finish no earlier than 2009-06-26 |
| 413 |  | LLF Optical Design | 86d? | 2009-05-01 A | 2009-08-28 | 20% | 190d | finish no earlier than 2009-08-28 |
| 414 |  | LLF Launch Telescope Preliminary Design Contract (Resue KI?? MRI/NSF) | 55d? | 2009-05-18 | 2009-07-31 |  | 210d | start no earlier than 2009-05-18 |
| 415 |  | LLF Mechanical Design | 38d? | 2009-08-10 | 2009-09-30 |  | 167d | start no earlier than 2009-08-10 |
| 416 |  | LLF Electrical Design | 40d? | 2009-09-07 | 2009-10-30 |  | 145d | start no earlier than 2009-09-07 |
| 417 |  | LLF Assembly, Alignment & Test Plans | 30d? | 2009-11-02 | 2009-12-11 |  | 115d | finish no earlier than 2009-12-11 |
| 418 | 1.3.5.4 | **Laser Safety Systems** | 88d? | 2009-06-01 A | 2009-09-30 | 53% | 167d |  |
| 419 | 1.3.5.4.1 | **Personnel & Equipment Safety System** | 43d? | 2009-08-03 A | 2009-09-30 | 50% | 167d |  |
| 420 |  | Safety Requirements & Interfaces | 10d? | 2009-08-03 A | 2009-08-14 | 50% | 200d | start no earlier than 2009-08-03 |

| ID | WBS | Task | Duration | Start | Finish | Predecessors | Complete | Total float | Constraint |
| --- | --- | --- | --- | --- | --- | --- | --- | --- | --- |
| 421 |  | Safety Algorithms, Diagrams & Dataflow | 33d? | 2009-08-17 A | 2009-09-30 |  | 50% | 167d | start no earlier than 2009-08-17 |
| 422 |  | Safety Communication Protocols & Methods | 33d? | 2009-08-17 A | 2009-09-30 |  | 50% | 167d | start no earlier than 2009-08-17 |
| 423 |  | Safety Performance Estimate | 33d? | 2009-08-17 A | 2009-09-30 |  | 50% | 167d | start no earlier than 2009-08-17 |
| 424 |  | Safety Electronics, Shutter & Interlocks | 33d? | 2009-08-17 A | 2009-09-30 |  | 50% | 167d | start no earlier than 2009-08-17 |
| 425 |  | Safety Test Plans | 33d? | 2009-08-17 A | 2009-09-30 |  | 50% | 167d | start no earlier than 2009-08-17 |
| 426 | 1.3.5.4.2 | **Laser Traffic Control System (LTCS) Modifications (Doug can start earlier per JC)** | 20d? | 2009-06-01 A | 2009-06-26 |  | 50% | 235d |  |
| 427 |  | LTCS Requirements & Interfaces (LTCS mods. independent of other pieces laser facility design) | 20d? | 2009-06-01 A | 2009-06-26 |  | 50% | 235d | finish no earlier than 2009-06-26 |
| 428 |  | LTCS Algorithms, Diagrams & Dataflow | 20d? | 2009-06-01 A | 2009-06-26 |  | 50% | 235d | finish no earlier than 2009-06-26 |
| 429 |  | LTCS Communication Protocols & Methods | 20d? | 2009-06-01 A | 2009-06-26 |  | 50% | 235d | finish no earlier than 2009-06-26 |
| 430 |  | LTCS Performance Estimate | 20d? | 2009-06-01 A | 2009-06-26 |  | 50% | 235d | finish no earlier than 2009-06-26 |
| 431 |  | LTCS Test Plans | 20d? | 2009-06-01 A | 2009-06-26 |  | 50% | 235d | finish no earlier than 2009-06-26 |
| 432 | 1.3.5.4.3 | **Space Command Laser Clearing House (LCH)** | 33d? | 2009-08-17 A | 2009-09-30 |  | 75% | 167d |  |
| 433 |  | LCH Requirements & Interfaces | 33d? | 2009-08-17 A | 2009-09-30 |  | 75% | 167d | finish no earlier than 2009-09-30 |
| 434 |  | Laser System Lab I&T Plan | 20d? | 2009-10-05 | 2009-10-30 |  |  | 145d | finish no earlier than 2009-10-30 |
| 435 | 1.3.6 | **Control System Design** | 200d? | 2009-06-15 | 2010-03-19 |  |  | 45d |  |
| 436 | 1.3.6.1 | **Controls electronics** | 200d? | 2009-06-15 | 2010-03-19 |  |  | 45d |  |
| 437 |  | Controls Infrastructure | 10d? | 2009-06-15 | 2009-06-26 | 196 |  | 45d | start no earlier than 2009-05-29 |
| 438 |  | Camera control | 10d? | 2009-06-29 | 2009-07-10 | 437 |  | 45d | start no earlier than 2009-06-12 |
| 439 |  | DM & TT Control | 33d? | 2009-07-13 | 2009-08-26 | 438 |  | 45d | finish no earlier than 2009-08-26 |
| 440 |  | Environmental and power control | 22d? | 2009-08-27 | 2009-09-25 | 439 |  | 45d | finish no earlier than 2009-08-10 |
| 441 |  | RTC control | 10d? | 2009-09-28 | 2009-10-09 | 440 |  | 45d |  |
| 442 |  | Laser control | 10d? | 2009-10-12 | 2009-10-23 | 441 |  | 45d |  |
| 443 |  | Laser Safety System Control | 10d? | 2009-10-26 | 2009-11-06 | 442 |  | 45d | start no earlier than 2009-08-03 |
| 444 |  | Motion control | 95d? | 2009-11-09 | 2010-03-19 | 443 |  | 45d | finish no earlier than 2010-03-19 |
| 445 | 1.3.6.2 | **Controls Software** | 119.5d? | 2009-09-14 | 2010-02-26 |  |  | 60.5d |  |
| 446 |  | Controls Infrastructure | 6d? | 2009-09-14 | 2009-09-21 | 195 |  | 60.5d | start no earlier than 2009-07-17 |
| 447 | 1.3.6.2.2 | **Common services** | 31d? | 2009-09-22 | 2009-11-03 | 446 |  | 60.5d |  |
| 448 |  | Telemetry | 3d? | 2009-09-22 | 2009-09-24 |  |  | 60.5d | start no earlier than 2009-07-24 |
| 449 |  | Health monitoring | 3d? | 2009-09-25 | 2009-09-29 | 448 |  | 60.5d | start no earlier than 2009-07-29 |
| 450 |  | Logging | 3d? | 2009-09-30 | 2009-10-02 | 449 |  | 60.5d | start no earlier than 2009-07-31 |
| 451 |  | Archiving | 3d? | 2009-10-05 | 2009-10-07 | 450 |  | 60.5d | start no earlier than 2009-08-05 |
| 452 |  | Alarming | 7.5d? | 2009-10-08 | 2009-10-19 | 451 |  | 60.5d | start no earlier than 2009-08-07 |
| 453 |  | Configuration | 11.5d? | 2009-10-19 | 2009-11-03 | 452 |  | 60.5d | start no earlier than 2009-08-17 |
| 454 |  | Camera control | 7.5d? | 2009-11-04 | 2009-11-13 | 447 |  | 60.5d | start no earlier than 2009-09-07 |
| 455 |  | DM & TT Control | 7.5d? | 2009-11-13 | 2009-11-24 | 454 |  | 60.5d | start no earlier than 2009-09-16 |
| 456 |  | Environmental and power control | 7.5d? | 2009-11-25 | 2009-12-04 | 455 |  | 60.5d | start no earlier than 2009-09-24 |
| 457 |  | RTC control | 7.5d? | 2009-12-04 | 2009-12-15 | 456 |  | 60.5d | start no earlier than 2009-10-02 |
| 458 |  | Laser control | 7.5d? | 2009-12-16 | 2009-12-25 | 457 |  | 60.5d | start no earlier than 2009-10-12 |
| 459 |  | Laser Safety System Control | 7.5d? | 2009-12-25 | 2010-01-05 | 458 |  | 60.5d | start no earlier than 2009-10-21 |
| 460 |  | Alignment & calibration source control | 7.5d? | 2010-01-06 | 2010-01-15 | 459 |  | 60.5d | start no earlier than 2009-10-29 |
| 461 |  | Motion Control | 30d? | 2010-01-15 | 2010-02-26 | 460 |  | 60.5d | start no earlier than 2009-11-06 |
| 462 | 1.3.6.3 | **Acquisition, Guiding & Offload (AGO) Control** | 43d? | 2009-10-01 | 2009-11-30 |  |  | 124d |  |
| 463 |  | Acquisition | 22d? | 2009-10-01 | 2009-10-30 |  |  | 145d | finish no earlier than 2009-10-30 |
| 464 |  | Focus management | 22d? | 2009-10-01 | 2009-10-30 |  |  | 145d | start no earlier than 2009-10-01 |
| 465 | 1.3.6.3.3 | **Offloading** | 21d? | 2009-11-02 | 2009-11-30 |  |  | 124d |  |
| 466 |  | Tip-Tilt offloading | 21d? | 2009-11-02 | 2009-11-30 |  |  | 124d | start no earlier than 2009-11-02 |
| 467 |  | Focus offloading | 21d? | 2009-11-02 | 2009-11-30 |  |  | 124d | start no earlier than 2009-11-02 |
| 468 |  | Coma offloading | 21d? | 2009-11-02 | 2009-11-30 |  |  | 124d | start no earlier than 2009-11-02 |
| 469 |  | Rotation offloading | 21d? | 2009-11-02 | 2009-11-30 |  |  | 124d | start no earlier than 2009-11-02 |
| 470 |  | ACS offloading | 21d? | 2009-11-02 | 2009-11-30 |  |  | 124d | start no earlier than 2009-11-02 |
| 471 | 1.3.7 | **Science Operations Tools Design** | 190d? | 2009-07-06 | 2010-03-26 |  |  | 40d |  |
| 472 | 1.3.7.1 | **Multi-Systems Command Sequencer (MCS)** | 154d? | 2009-07-06 | 2010-02-04 |  |  | 76d |  |
| 473 | 1.3.7.1.1 | **Setup Sequences: Configuration & Calibration** | 89d? | 2009-07-06 | 2009-11-05 |  |  | 141d |  |
| 474 | 1.3.7.1.1.1 | **Setup Sequences Common Structure** | 89d? | 2009-07-06 | 2009-11-05 |  |  | 141d |  |
| 475 |  | Setup Sequences Operations Concept Document | 89d? | 2009-07-06 | 2009-11-05 |  |  | 141d | start no earlier than 2009-07-06 |
| 476 |  | Setup Sequences Software Requirements | 89d? | 2009-07-06 | 2009-11-05 |  |  | 141d | start no earlier than 2009-07-06 |
| 477 |  | Setup Sequences Module Definitions | 89d? | 2009-07-06 | 2009-11-05 |  |  | 141d | start no earlier than 2009-07-06 |
| 478 | 1.3.7.1.1.2 | **Configuration Sequences** | 89d? | 2009-07-06 | 2009-11-05 |  |  | 141d |  |
| 479 |  | Config Sequences Functional Requirements | 89d? | 2009-07-06 | 2009-11-05 |  |  | 141d | start no earlier than 2009-07-06 |
| 480 |  | Interface Definitions | 1d? | 2009-07-06 | 2009-07-06 |  |  | 229d | start no earlier than 2009-07-06 |
| 481 | 1.3.7.1.1.3 | **Calibration Sequences** | 89d? | 2009-07-06 | 2009-11-05 |  |  | 141d |  |
| 482 |  | Calibration Sequences Functional Requirements | 89d? | 2009-07-06 | 2009-11-05 |  |  | 141d | start no earlier than 2009-07-06 |
| 483 |  | Interface Definitions | 1d? | 2009-07-06 | 2009-07-06 |  |  | 229d | start no earlier than 2009-07-06 |
| 484 | 1.3.7.1.2 | **Observing Sequences** | 89d? | 2009-10-05 | 2010-02-04 |  |  | 76d |  |
| 485 | 1.3.7.1.2.1 | **Observing Sequences Common Structure** | 89d? | 2009-10-05 | 2010-02-04 |  |  | 76d |  |
| 486 |  | Observing Sequences Operations Concept Document | 87d? | 2009-10-05 | 2010-02-02 |  |  | 78d | start no earlier than 2009-10-05 |
| 487 |  | Observing Sequences Software Requirements | 89d? | 2009-10-05 | 2010-02-04 |  |  | 76d | start no earlier than 2009-10-05 |
| 488 |  | Observing Sequences Module Definitions | 89d? | 2009-10-05 | 2010-02-04 |  |  | 76d | start no earlier than 2009-10-05 |
| 489 | 1.3.7.1.2.2 | **Acquisition Sequences** | 89d? | 2009-10-05 | 2010-02-04 |  |  | 76d |  |
| 490 |  | Acquisition Sequences Functional Requirements | 89d? | 2009-10-05 | 2010-02-04 |  |  | 76d | start no earlier than 2009-10-05 |

| ID | WBS | Task | Duration | Start | Finish | Total float | Constraint |
| --- | --- | --- | --- | --- | --- | --- | --- |
| 491 |  | Acquisition Sequences Interface Definitions | 89d? | 2009-10-05 | 2010-02-04 | 76d | start no earlier than 2009-10-05 |
| 492 | 1.3.7.1.2.3 | **Observing Sequences** | 89d? | 2009-10-05 | 2010-02-04 | 76d |  |
| 493 |  | Observing Sequences Functional Requirements | 89d? | 2009-10-05 | 2010-02-04 | 76d | start no earlier than 2009-10-05 |
| 494 |  | Interface Definitions | 1d? | 2009-10-05 | 2009-10-05 | 164d | start no earlier than 2009-10-05 |
| 495 | 1.3.7.1.2.4 | **Quality Monitoring Sequences** | 89d? | 2009-10-05 | 2010-02-04 | 76d |  |
| 496 |  | Quality Monitoring Functional Requirements | 89d? | 2009-10-05 | 2010-02-04 | 76d | start no earlier than 2009-10-05 |
| 497 |  | Interface Definitions | 1d? | 2009-10-05 | 2009-10-05 | 164d | start no earlier than 2009-10-05 |
| 498 | 1.3.7.1.2.5 | **Optimization Sequences** | 89d? | 2009-10-05 | 2010-02-04 | 76d |  |
| 499 |  | Optimization Sequences Functional Requirements | 89d? | 2009-10-05 | 2010-02-04 | 76d | start no earlier than 2009-10-05 |
| 500 |  | Interface Definitions | 1d? | 2009-10-05 | 2009-10-05 | 164d | start no earlier than 2009-10-05 |
| 501 | 1.3.7.1.3 | **Alarm Handler & Troubleshooting Sequences** | 89d? | 2009-10-05 | 2010-02-04 | 76d |  |
| 502 | 1.3.7.1.3.1 | **Alarm Handler & Troubleshooting Common Structure** | 89d? | 2009-10-05 | 2010-02-04 | 76d |  |
| 503 |  | Alarm & Troubleshooting Operations Concept Document | 89d? | 2009-10-05 | 2010-02-04 | 76d | start no earlier than 2009-10-05 |
| 504 |  | Alarm & Troubleshooting Software Requirements | 89d? | 2009-10-05 | 2010-02-04 | 76d | start no earlier than 2009-10-05 |
| 505 |  | Alarm & Troubleshooting Module Definitions | 89d? | 2009-10-05 | 2010-02-04 | 76d | start no earlier than 2009-10-05 |
| 506 | 1.3.7.1.3.2 | **Alarm Handler Sequences** | 1d? | 2009-10-05 | 2009-10-05 | 164d |  |
| 507 |  | Functional Requirements | 1d? | 2009-10-05 | 2009-10-05 | 164d | start no earlier than 2009-10-05 |
| 508 |  | Interface Definitions | 1d? | 2009-10-05 | 2009-10-05 | 164d | start no earlier than 2009-10-05 |
| 509 | 1.3.7.1.3.3 | **Troubleshooting Sequences** | 1d? | 2009-10-05 | 2009-10-05 | 164d |  |
| 510 |  | Functional Requirements | 1d? | 2009-10-05 | 2009-10-05 | 164d | start no earlier than 2009-10-05 |
| 511 |  | Interface Definitions | 1d? | 2009-10-05 | 2009-10-05 | 164d | start no earlier than 2009-10-05 |
| 512 | 1.3.7.2 | **User Interfaces** | 190d? | 2009-07-06 | 2010-03-26 | 40d |  |
| 513 | 1.3.7.2.1 | **User Interface (UI) Infrastructure** | 89d? | 2009-07-06 | 2009-11-05 | 141d |  |
| 514 | 1.3.7.2.1.1 | **UI Command Interface (CI) to MCS** | 89d? | 2009-07-06 | 2009-11-05 | 141d |  |
| 515 |  | UI to MCS Functional Requirements | 89d? | 2009-07-06 | 2009-11-05 | 141d | start no earlier than 2009-07-06 |
| 516 |  | UI to MCS Interface Definitions | 89d? | 2009-07-06 | 2009-11-05 | 141d | start no earlier than 2009-07-06 |
| 517 | 1.3.7.2.1.2 | **UI Command Interface to Pre- & Post-Observing Tools** | 89d? | 2009-07-06 | 2009-11-05 | 141d |  |
| 518 |  | UI to Pre/Post Obs Tools Functional Requirements | 89d? | 2009-07-06 | 2009-11-05 | 141d | start no earlier than 2009-07-06 |
| 519 |  | UI to Pre/Post Obs Tools Interface Definitions | 89d? | 2009-07-06 | 2009-11-05 | 141d | start no earlier than 2009-07-06 |
| 520 | 1.3.7.2.2 | **Setup User Interfaces** | 125d? | 2009-10-05 | 2010-03-26 | 40d |  |
| 521 | 1.3.7.2.2.1 | **Setup UI Common Structure** | 125d? | 2009-10-05 | 2010-03-26 | 40d |  |
| 522 |  | Setup UI Operations Concept Document | 125d? | 2009-10-05 | 2010-03-26 | 40d | finish no earlier than 2010-03-26 |
| 523 |  | Setup UI Software Requirements | 125d? | 2009-10-05 | 2010-03-26 | 40d | finish no earlier than 2010-03-26 |
| 524 |  | Setup UI Module Definitions | 125d? | 2009-10-05 | 2010-03-26 | 40d | finish no earlier than 2010-03-26 |
| 525 | 1.3.7.2.2.2 | **Setup UI Configurations** | 125d? | 2009-10-05 | 2010-03-26 | 40d |  |
| 526 |  | Setup UI Config Functional Requirements | 125d? | 2009-10-05 | 2010-03-26 | 40d | finish no earlier than 2010-03-26 |
| 527 |  | Setup UI Config Interface Definitions | 125d? | 2009-10-05 | 2010-03-26 | 40d | finish no earlier than 2010-03-26 |
| 528 | 1.3.7.2.2.3 | **Setup UI Calibrations** | 125d? | 2009-10-05 | 2010-03-26 | 40d |  |
| 529 |  | Setup UI Calib Functional Requirements | 125d? | 2009-10-05 | 2010-03-26 | 40d | finish no earlier than 2010-03-26 |
| 530 |  | Setup UI Calib Interface Definitions | 125d? | 2009-10-05 | 2010-03-26 | 40d | finish no earlier than 2010-03-26 |
| 531 | 1.3.7.2.3 | **Observations User Interfaces** | 125d? | 2009-10-05 | 2010-03-26 | 40d |  |
| 532 | 1.3.7.2.3.1 | **Observations UI Common Structure** | 125d? | 2009-10-05 | 2010-03-26 | 40d |  |
| 533 |  | Observations UI Operations Concept Document | 125d? | 2009-10-05 | 2010-03-26 | 40d | finish no earlier than 2010-03-26 |
| 534 |  | Observations UI Software Requirements | 125d? | 2009-10-05 | 2010-03-26 | 40d | finish no earlier than 2010-03-26 |
| 535 |  | Observations UI Module Definitions | 125d? | 2009-10-05 | 2010-03-26 | 40d | finish no earlier than 2010-03-26 |
| 536 | 1.3.7.2.3.2 | **Acquisition & AO Control UI** | 125d? | 2009-10-05 | 2010-03-26 | 40d |  |
| 537 |  | Acq/AO Control UI Functional Requirements | 125d? | 2009-10-05 | 2010-03-26 | 40d | finish no earlier than 2010-03-26 |
| 538 |  | Acq/AO Control UI Interface Definitions | 125d? | 2009-10-05 | 2010-03-26 | 40d | finish no earlier than 2010-03-26 |
| 539 | 1.3.7.2.3.3 | **Observing Sequences UI** | 125d? | 2009-10-05 | 2010-03-26 | 40d |  |
| 540 |  | Obs Seq UI Functional Requirements | 125d? | 2009-10-05 | 2010-03-26 | 40d | finish no earlier than 2010-03-26 |
| 541 |  | Obs Seq UI Interface Definitions | 125d? | 2009-10-05 | 2010-03-26 | 40d | finish no earlier than 2010-03-26 |
| 542 | 1.3.7.2.3.4 | **Status & Graph UI** | 125d? | 2009-10-05 | 2010-03-26 | 40d |  |
| 543 |  | Status & Graph UI Functional Requirements | 125d? | 2009-10-05 | 2010-03-26 | 40d | finish no earlier than 2010-03-26 |
| 544 |  | Status & Graph UI Interface Definitions | 125d? | 2009-10-05 | 2010-03-26 | 40d | finish no earlier than 2010-03-26 |
| 545 | 1.3.7.2.3.5 | **Advanced Monitoring UI** | 125d? | 2009-10-05 | 2010-03-26 | 40d |  |
| 546 |  | Adv Monitoring UI Functional Requirements | 125d? | 2009-10-05 | 2010-03-26 | 40d | finish no earlier than 2010-03-26 |
| 547 |  | Adv Monitoring UI Interface Definitions | 125d? | 2009-10-05 | 2010-03-26 | 40d | finish no earlier than 2010-03-26 |
| 548 | 1.3.7.2.3.6 | **Optimization & Troubleshooting UI** | 125d? | 2009-10-05 | 2010-03-26 | 40d |  |
| 549 |  | Opt & Trouble UI Functional Requirements | 125d? | 2009-10-05 | 2010-03-26 | 40d | finish no earlier than 2010-03-26 |
| 550 |  | Opt & Trouble UI Interface Definitions | 125d? | 2009-10-05 | 2010-03-26 | 40d | finish no earlier than 2010-03-26 |
| 551 | 1.3.7.3 | **Pre- & Post-Observing Science Support Tools** | 148d? | 2009-09-01 | 2010-03-25 | 41d |  |
| 552 | 1.3.7.3.1 | **User Documentation** | 148d? | 2009-09-01 | 2010-03-25 | 41d |  |
| 553 |  | User Documentation Operations Concept | 148d? | 2009-09-01 | 2010-03-25 | 41d | finish no earlier than 2010-03-25 |
| 554 |  | User Documentation Functional Requirements | 148d? | 2009-09-01 | 2010-03-25 | 41d | finish no earlier than 2010-03-25 |
| 555 | 1.3.7.3.2 | **Science Observations Planning Tools** | 148d? | 2009-09-01 | 2010-03-25 | 41d |  |
| 556 | 1.3.7.3.2.1 | **NGS Star Finder** | 148d? | 2009-09-01 | 2010-03-25 | 41d |  |
| 557 |  | NGS Star Finder Operations Concept | 148d? | 2009-09-01 | 2010-03-25 | 41d | start no earlier than 2009-09-01 |
| 558 |  | NGS Star Finder Functional Requirements & Use Case Definitions | 148d? | 2009-09-01 | 2010-03-25 | 41d | start no earlier than 2009-09-01 |
| 559 |  | Interface Definitions | 148d? | 2009-09-01 | 2010-03-25 | 41d | start no earlier than 2009-09-01 |
| 560 |  | Module Definitions | 148d? | 2009-09-01 | 2010-03-25 | 41d | start no earlier than 2009-09-01 |

| ID | WBS | Task | Duration | Start | Finish | Complete | Total float | Constraint |
| --- | --- | --- | --- | --- | --- | --- | --- | --- |
| 561 | 1.3.7.3.2.2 | **Performance Prediction Tool** | 148d? | 2009-09-01 | 2010-03-25 |  | 41d |  |
| 562 |  | Performance Prediction Operations Concept | 148d? | 2009-09-01 | 2010-03-25 |  | 41d | start no earlier than 2009-09-01 |
| 563 |  | Performance Prediction Functional Requirements & Use Case Definitions | 148d? | 2009-09-01 | 2010-03-25 |  | 41d | start no earlier than 2009-09-01 |
| 564 |  | Performance Prediction Interface Definitions | 148d? | 2009-09-01 | 2010-03-25 |  | 41d | start no earlier than 2009-09-01 |
| 565 |  | Performance Predictions Module Definitions | 148d? | 2009-09-01 | 2010-03-25 |  | 41d | start no earlier than 2009-09-01 |
| 566 | 1.3.7.3.2.3 | **Observation Planning & Efficiency Tool** | 148d? | 2009-09-01 | 2010-03-25 |  | 41d |  |
| 567 |  | Observing Planning & Efficiency Tool Operations Concept | 148d? | 2009-09-01 | 2010-03-25 |  | 41d | start no earlier than 2009-09-01 |
| 568 |  | Observing Planning & Efficiency Tool Functional Requirements & Use Case Definitions | 148d? | 2009-09-01 | 2010-03-25 |  | 41d | start no earlier than 2009-09-01 |
| 569 |  | Observing Planning & Efficiency Tool Interface Definitions | 148d? | 2009-09-01 | 2010-03-25 |  | 41d | start no earlier than 2009-09-01 |
| 570 |  | Observing Planning & Efficiency Tool Module Definitions | 148d? | 2009-09-01 | 2010-03-25 |  | 41d | start no earlier than 2009-09-01 |
| 571 | 1.3.7.3.2.4 | **Laser Clearinghouse Coordination Tool** | 148d? | 2009-09-01 | 2010-03-25 |  | 41d |  |
| 572 |  | Operations Concept | 148d? | 2009-09-01 | 2010-03-25 |  | 41d | start no earlier than 2009-09-01 |
| 573 |  | Functional Requirements & Use Case Definitions | 148d? | 2009-09-01 | 2010-03-25 |  | 41d | start no earlier than 2009-09-01 |
| 574 |  | Interface Definitions | 148d? | 2009-09-01 | 2010-03-25 |  | 41d | start no earlier than 2009-09-01 |
| 575 |  | Module Definitions | 148d? | 2009-09-01 | 2010-03-25 |  | 41d | start no earlier than 2009-09-01 |
| 576 | 1.3.7.3.3 | **Data Products** | 126d? | 2009-10-01 | 2010-03-25 |  | 41d |  |
| 577 | 1.3.7.3.3.1 | **Generic Data Products** | 126d? | 2009-10-01 | 2010-03-25 |  | 41d |  |
| 578 |  | Generic Data Operations Concept | 126d? | 2009-10-01 | 2010-03-25 |  | 41d | finish no earlier than 2010-03-25 |
| 579 |  | Generic Data Functional Requirements & Use Case Definitions | 126d? | 2009-10-01 | 2010-03-25 |  | 41d | finish no earlier than 2010-03-25 |
| 580 |  | Generic Data Interface Definitions | 126d? | 2009-10-01 | 2010-03-25 |  | 41d | finish no earlier than 2010-03-25 |
| 581 | 1.3.7.3.3.2 | **Science Data Quality Assessment** | 126d? | 2009-10-01 | 2010-03-25 |  | 41d |  |
| 582 | 1.3.7.3.3.2.1 | **Quality Metrics & Logged Information** | 126d? | 2009-10-01 | 2010-03-25 |  | 41d |  |
| 583 |  | Quality Metrics Operations Concept | 126d? | 2009-10-01 | 2010-03-25 |  | 41d | finish no earlier than 2010-03-25 |
| 584 |  | Quality Metrics Functional Requirements & Use Case Definitions | 126d? | 2009-10-01 | 2010-03-25 |  | 41d | finish no earlier than 2010-03-25 |
| 585 |  | Interface Definitions | 126d? | 2009-10-01 | 2010-03-25 |  | 41d | finish no earlier than 2010-03-25 |
| 586 | 1.3.7.3.3.2.2 | **PSF Calibration** | 126d? | 2009-10-01 | 2010-03-25 |  | 41d |  |
| 587 |  | PSF Calibration Operations Concept | 126d? | 2009-10-01 | 2010-03-25 |  | 41d | finish no earlier than 2010-03-25 |
| 588 |  | PSF Calibration Functional Requirements & Use Case Definitions | 126d? | 2009-10-01 | 2010-03-25 |  | 41d | finish no earlier than 2010-03-25 |
| 589 |  | Interface Definitions | 126d? | 2009-10-01 | 2010-03-25 |  | 41d | finish no earlier than 2010-03-25 |
| 590 |  | Module Definitions | 126d? | 2009-10-01 | 2010-03-25 |  | 41d | finish no earlier than 2010-03-25 |
| 591 | 1.3.7.3.3.3 | **Science Data Archiving** | 126d? | 2009-10-01 | 2010-03-25 |  | 41d |  |
| 592 |  | Science Data Operations Concept | 126d? | 2009-10-01 | 2010-03-25 |  | 41d | finish no earlier than 2010-03-25 |
| 593 |  | Functional Requirements & Use Case Definitions | 126d? | 2009-10-01 | 2010-03-25 |  | 41d | finish no earlier than 2010-03-25 |
| 594 |  | Interface Definitions | 126d? | 2009-10-01 | 2010-03-25 |  | 41d | finish no earlier than 2010-03-25 |
| 595 | 1.3.7.4 | **Data Server** | 107d? | 2009-10-01 | 2010-02-26 |  | 60d |  |
| 596 |  | Data Server: Architecture | 107d? | 2009-10-01 | 2010-02-26 |  | 60d | finish no earlier than 2010-02-26 |
| 597 |  | Data Server: HW & SW Specification & Selection | 107d? | 2009-10-01 | 2010-02-26 |  | 60d | finish no earlier than 2010-02-26 |
| 598 |  | Data Server: Software Design | 0d? | 2009-10-01 | 2009-10-01 |  | 167d | start no earlier than 2009-10-01 |
| 599 |  | Data Server: Compliance Matrix | 0d? | 2009-10-01 | 2009-10-01 |  | 167d | start no earlier than 2009-10-01 |
| 600 |  | Data Server: Test Plan | 0d? | 2009-10-01 | 2009-10-01 |  | 167d | start no earlier than 2009-10-01 |
| 601 |  | Data Server: Summary Report | 107d? | 2009-10-01 | 2010-02-26 |  | 60d | finish no earlier than 2010-02-26 |
| 602 | 1.3.8 | **Telescope & Summit Engineering Design** | 200d? | 2009-05-04 | 2010-02-05 |  | 75d |  |
| 603 |  | Telescope Performance | 1d? | 2009-05-04 | 2009-05-04 |  | 274d | start no earlier than 2009-05-04 |
| 604 | 1.3.8.2 | **Infrastructure Modifications for AO** | 165d? | 2009-06-08 | 2010-01-22 |  | 85d |  |
| 605 |  | AO Infrastructure Requirements & Interfaces | 20d? | 2009-06-08 | 2009-07-03 |  | 230d | start no earlier than 2009-06-08 |
| 606 |  | AO Infrastructure Mechanical Modifications | 40d? | 2009-07-06 | 2009-08-28 |  | 190d | finish no earlier than 2009-08-28 |
| 607 |  | AO Infrastructure Electrical Modifications | 41.25d? | 2009-10-05 | 2009-12-01 |  | 123.75d | start no earlier than 2009-10-05 |
| 608 |  | AO Infrastructure Glycol Cooling Modifications | 45d? | 2009-10-19 | 2009-12-18 |  | 110d | start no earlier than 2009-10-19 |
| 609 |  | AO Infrastructure CCR Modifications | 45d? | 2009-10-19 | 2009-12-18 |  | 110d | start no earlier than 2009-10-19 |
| 610 |  | AO Infrastructure Implementation & Test Plans | 25d? | 2009-12-21 | 2010-01-22 |  | 85d | start no earlier than 2009-12-21 |
| 611 | 1.3.8.3 | **Infrastructure modifications for LGSF** | 200d? | 2009-05-04 | 2010-02-05 |  | 75d |  |
| 612 |  | LGSF Infrastructure Requirements & Interfaces | 20d? | 2009-05-04 | 2009-05-29 |  | 255d | finish no earlier than 2009-05-29 |
| 613 |  | LGSF Infrastructure Mechanical Modifications | 41d? | 2009-07-03 | 2009-08-28 |  | 190d | start no earlier than 2009-07-03 |
| 614 |  | LGSF Infrastructure Electrical Modifications | 45d? | 2009-12-07 | 2010-02-05 |  | 75d | start no earlier than 2009-12-07 |
| 615 |  | LGSF Infrastructure Glycol Cooling Modifications | 45d? | 2009-07-13 | 2009-09-11 |  | 180d | finish no earlier than 2009-09-11 |
| 616 |  | LGSF Infrastructure Implementation & Test Plans | 23.12d? | 2009-09-01 | 2009-10-02 |  | 165d | finish no earlier than 2009-10-02 |
| 617 | 1.3.8.4 | **Interferometer Modifications** | 40d? | 2009-07-01 | 2009-08-25 |  | 193d |  |
| 618 |  | Optical Design of Post Field Selector Optics | 40d? | 2009-07-01 | 2009-08-25 |  | 193d | start no earlier than 2009-07-01 |
| 619 |  | Evaluation of Optical Design Impact on Interferometer | 40d? | 2009-07-01 | 2009-08-25 |  | 193d | start no earlier than 2009-07-01 |
| 620 | 1.3.9 | **Telescope Integration & Test** | 85d? | 2009-10-05 A | 2010-01-29 | 7% | 80d |  |
| 621 | 1.3.9.1 | **Old AO/Laser Removal** | 30d? | 2009-10-05 A | 2009-11-13 | 40% | 135d |  |
| 622 |  | AO Removal Plan | 26.67d? | 2009-10-05 | 2009-11-10 |  | 138.33d | start no earlier than 2009-10-05 |
| 623 |  | Laser Removal Plan | 30d? | 2009-10-05 A | 2009-11-13 | 75% | 135d | start no earlier than 2009-10-05 |
| 624 |  | Laser Enclosure Integration | 1d? | 2009-10-05 | 2009-10-05 |  | 164d | start no earlier than 2009-10-05 |
| 625 |  | AO Enclosure Integration | 1d? | 2009-10-05 | 2009-10-05 |  | 164d | start no earlier than 2009-10-05 |
| 626 | 1.3.9.4 | **AO System Install + I&T** | 35d? | 2009-11-02 | 2009-12-18 |  | 110d |  |
| 627 |  | Opto-Mechanical Integration Plan | 27d? | 2009-11-02 | 2009-12-08 |  | 118d | start no earlier than 2009-11-02 |
| 628 |  | Electronics Integration Plan | 35d? | 2009-11-02 | 2009-12-18 |  | 110d | start no earlier than 2009-11-02 |
| 629 |  | Computer Integration Plan | 35d? | 2009-11-02 | 2009-12-18 |  | 110d | start no earlier than 2009-11-02 |
| 630 |  | AO System Integration Plan | 35d? | 2009-11-02 | 2009-12-18 |  | 110d | start no earlier than 2009-11-02 |

| ID | WBS | Task | Duration | Start | Finish | Complete | Total float | Constraint |
| --- | --- | --- | --- | --- | --- | --- | --- | --- |
| 631 |  | AO System Test Plan | 35d? | 2009-11-02 | 2009-12-18 |  | 110d | start no earlier than 2009-11-02 |
| 632 | 1.3.9.5 | **Laser System Install + I&T** | 40.83d? | 2009-10-23 | 2009-12-18 |  | 110d |  |
| 633 |  | LGSF Installation & Integration Plan | 40.83d? | 2009-10-23 | 2009-12-18 |  | 110d | finish no earlier than 2009-12-18 |
| 634 |  | LGSF System Test Plan | 35d? | 2009-11-02 | 2009-12-18 |  | 110d | start no earlier than 2009-11-02 |
| 635 |  | LGS AO System On-sky I&T Plan | 10d? | 2010-01-04 | 2010-01-15 |  | 90d | start no earlier than 2010-01-04 |
| 636 |  | Performance Characterization | 1d? | 2010-01-04 | 2010-01-04 |  | 99d | start no earlier than 2010-01-04 |
| 637 |  | Science Verification Plan | 20d? | 2010-01-04 | 2010-01-29 |  | 80d | start no earlier than 2010-01-04 |
| 638 | 1.3.10 | **Operations Transition** | 227d? | 2009-05-01 A | 2010-03-15 | 13% | 49d |  |
| 639 | 1.3.10.1 | **Operations Plans** | 140d? | 2009-09-01 A | 2010-03-15 | 11% | 49d |  |
| 640 |  | Operations Support Plan | 65d? | 2009-09-01 | 2009-11-30 |  | 124d | start no earlier than 2009-09-01 |
| 641 |  | Operations Maintenance & Spares Plan Template | 51d? | 2010-01-04 A | 2010-03-15 | 25% | 49d | finish no earlier than 2010-03-15 |
| 642 | 1.3.10.2 | **Operations Handover** | 152d? | 2009-05-01 A | 2009-11-30 | 15% | 124d |  |
| 643 |  | Operations Handover Success Criteria | 6d? | 2009-05-01 A | 2009-05-08 | 75% | 270d | finish no earlier than 2009-05-08 |
| 644 |  | Operations Personnel Training Plan | 65d? | 2009-09-01 A | 2009-11-30 | 25% | 124d | start no earlier than 2009-09-01 |
| 645 |  | Documentation Transition Plan | 65d? | 2009-09-01 | 2009-11-30 |  | 124d | start no earlier than 2009-09-01 |

## Version 2 (saved 2009-07-21, file NGAO_Design_B2C_Replan_v8_tracked_Jun09.mpp)

Last finish stays 2010-05-21. Complete tasks 3 → 13.

Changed:

| ID | Task | Start | Finish | Complete | Total float |
| --- | --- | --- | --- | --- | --- |
| 1 | **NGAO Design** |  |  | 4% → 10% |  |
| 4 | **Preliminary Design** |  |  | 4% → 10% |  |
| 6 | **PD Phase Management** |  |  | 7% → 12% |  |
| 7 | **Planning** |  |  | 21% → 25% |  |
| 8 | **Replans (PD phase)** |  | 2009-06-12 A | 75% → 100% | 245d → none |
| 9 | B2C Replan |  | 2009-06-12 A | 75% → 100% | 245d → none |
| 21 | **Project Management & Meetings** |  |  | 8% → 12% |  |
| 22 | **Senior Management Committee** |  |  | 10% → 15% |  |
| 23 | Senior Management Activities |  |  | 10% → 15% |  |
| 24 | Senior Management Telecons |  |  | 10% → 15% |  |
| 25 | **Team Meetings** |  |  | 10% → 15% |  |
| 26 | Meeting Participation |  |  | 10% → 15% |  |
| 30 | **Tracking & Reporting** |  |  | 9% → 13% |  |
| 31 | **Monthly Status Reports** |  |  | 10% → 15% |  |
| 32 | Monthly Team Status Reports |  |  | 10% → 15% |  |
| 33 | Monthly Project Reports (TSIP, Directors) |  |  | 10% → 15% |  |
| 34 | TSIP Project Report Telecons |  |  | 10% → 15% |  |
| 35 | **SSC Meetings** | 2009-07-08 A |  | 0% → 19% |  |
| 36 | SSC Meeting (Keck) | 2009-07-08 A | 2009-07-09 A | 0% → 100% | 226.88d → none |
| 43 | **Proposals** |  |  | 1% → 12% |  |
| 44 | Advancement Support | 2009-05-01 A |  | 0% → 10% |  |
| 45 | MRI-R2 Proposals |  |  | 8% → 38% |  |
| 46 | TSIP Proposal | 2009-06-01 A |  | 0% → 10% |  |
| 66 | **Project Support** |  |  | 10% → 15% |  |
| 67 | Administrative/Contract Support |  |  | 10% → 15% |  |
| 68 | Shared Infrastructure |  |  | 10% → 15% |  |
| 69 | **Systems Engineering** |  |  | 2% → 13% |  |
| 70 | **Science Case Requirements** | 2009-05-01 A |  | 0% → 12% |  |
| 71 | **Science Case Requirements** | 2009-05-01 A |  | 0% → 4% |  |
| 72 | **Science Simulations** | 2009-05-01 A |  | 0% → 4% |  |
| 73 | High-z Galaxies | 2009-05-01 A |  | 0% → 8% |  |
| 74 | BH Measurements in Nearby AGN | 2009-05-01 A |  | 0% → 9% |  |
| 76 | Extrasolar Planets | 2009-06-22 A |  | 0% → 1% |  |
| 79 | Debris Disks and QSO Host Galaxies | 2009-11-02 A |  | 0% → 7% |  |
| 86 | Review Science Requirements in Requirements Database | 2009-05-18 A |  | 0% → 20% |  |
| 88 | **Science Observing Planning & Execution** | 2009-05-01 A |  | 0% → 65% |  |
| 89 | Develop Observing Scenarios for all Key Science Drivers | 2009-05-01 A |  | 0% → 65% |  |
| 90 | **Science Performance Input** | 2009-05-01 A |  | 0% → 24% |  |
| 93 | Input to Preliminary Operations Concept Document | 2009-05-01 A |  | 0% → 40% |  |
| 94 | **Science Competitiveness** | 2009-05-01 A |  | 0% → 18% |  |
| 95 | Update List of Science Goals for Other Facilities | 2009-05-01 A |  | 0% → 20% |  |
| 96 | Evaluate NGAO Potential to Compliment Other Facilities | 2009-05-01 A |  | 0% → 15% |  |
| 97 | **User Community Liaison** | 2009-05-01 A |  | 0% → 5% |  |
| 102 | Progress Reporting | 2009-05-01 A |  | 0% → 20% |  |
| 103 | **Science Advisory Team Meetings** | 2009-05-01 A |  | 0% → 27% |  |
| 104 | Prepare Minutes, Presentations & KAONs | 2009-05-01 A |  | 0% → 50% |  |
| 106 | Science Postdoc Research Time | 2009-05-01 A |  | 0% → 15% |  |
| 107 | **Requirements** |  |  | 11% → 21% |  |
| 108 | **Operations Concept Document (OCD)** |  |  | 13% → 31% |  |
| 109 | OOCD Release 1 |  |  | 35% → 85% |  |
| 111 | **System Requirements (SRD)** | 2009-05-01 A |  | 0% → 13% |  |
| 112 | SRD PD Release 1 | 2009-05-01 A |  | 0% → 20% |  |
| 114 | **Functional Requirements (FRD)** |  |  | 23% → 28% |  |
| 115 | FRD PD Release 1 |  |  | 43% → 52% |  |
| 120 | **Systems Engineering Analysis** |  |  | 1% → 11% |  |
| 121 | **Performance Budgets** |  |  | 1% → 13% | 84.33d → 90.58d |
| 122 | **Wavefront Error and Ensquared Energy** |  |  | 4% → 29% | 118.71d → 124.96d |
| 123 | LOWFS Sharpening WFE Budgets | 2009-05-08 A |  | 0% → 10% |  |
| 126 | **Science Wavefront Error Flowdown Budgets** |  |  | 7% → 49% | 125.38d → 131.62d |
| 127 | Requirements Flowdown Methodology Memo |  | 2009-05-07 A | 50% → 100% | 131.5d → none |
| 128 | Laser Photoreturn Budget Flowdown |  |  | 5% → 50% | 240d → 246.25d |
| 129 | Correction Latency Budget Flowdown | 2009-10-09 A |  | 0% → 25% | 118.71d → 126.62d |
| 130 | Science Transmission Budget Flowdown |  |  | 5% → 75% | 236d → 242.25d |
| 131 | Non-common Path WFE Budget Flowdown |  |  | 5% → 40% | 210d → 216.25d |
| 132 | Uncorrectable Internal WFE Budget Flowdown |  |  | 5% → 75% | 244d → 250.25d |
| 133 | Actuator-Pupil Registration Budget Flowdown |  |  | 5% → 40% | 241d → 247.25d |
| 134 | **LOWFS Wavefront Error Flowdown Budgets** |  |  | 3% → 38% | 118.71d → 124.96d |
| 135 | LOWFS Uncorrectable Internal WFE Budget Flowdown |  |  | 5% → 50% | 243.33d → 249.58d |
| 136 | LOWFS Servo Latency Budget Flowdown | 2009-10-23 A |  | 0% → 25% | 118.71d → 124.96d |
| 137 | **Astrometric Precision** | 2009-05-04 A |  | 0% → 4% | 125d → 131.25d |

| ID | Task | Start | Finish | Complete | Total float |
| --- | --- | --- | --- | --- | --- |
| 140 | **Astrometric Precision Flowdown Budgets** | 2009-05-04 A |  | 0% → 15% | 230d → 236.25d |
| 141 | Dimensional Stability Budget Flowdown | 2009-05-04 A |  | 0% → 15% | 230d → 236.25d |
| 142 | **High Contrast** | 2009-06-15 A |  | 0% → 14% | 125d → 166.92d |
| 143 | High Contrast Error Budget | 2009-06-15 A |  | 0% → 25% | 125d → 131.25d |
| 145 | **WFE/EE Budget Tool** | 2009-05-01 A |  | 0% → 3% | 84.33d → 90.58d |
| 149 | Other WFE/EE Budget Tool Maintenance | 2009-05-01 A |  | 0% → 4% | 84.33d → 90.58d |
| 150 | **Engineering Budgets** |  |  | 8% → 46% |  |
| 151 | **Observing Efficiency** | 2009-05-25 A |  | 0% → 50% |  |
| 152 | Observing Efficiency Analysis | 2009-05-25 A |  | 0% → 50% |  |
| 153 | **Observing Uptime** |  |  | 13% → 50% |  |
| 154 | Develop Observing Uptime Tool |  | 2009-07-09 A | 25% → 100% | 176d → none |
| 156 | Electrical Power Usage Budget | 2009-12-21 A |  | 0% → 25% |  |
| 158 | **Modeling & Analysis** |  |  | 0% → 2% |  |
| 164 | Additional Performance Modeling/Anchoring | 2010-02-10 A |  | 0% → 25% |  |
| 165 | **Integrated modeling** |  |  | 1% → 3% |  |
| 166 | MOAO capabilities added to LAOS |  |  | 5% → 10% |  |
| 174 | **System Architecture** |  |  | 12% → 22% |  |
| 177 | **Software Architecture** |  |  | 30% → 54% | 60.5d → 63d |
| 179 | **Controls SW Infrastructure** |  |  | 41% → 73% | 60.5d → 65.5d |
| 185 | Configuration | 2009-06-05 A |  | 0% → 75% | 63d → 70.5d |
| 186 | Common services |  |  | 25% → 75% | 60.5d → 63d |
| 189 | Middleware Evaluation |  |  | 25% → 50% | 73.5d → 76d |
| 190 | Document software architecture | 2009-07-20 A |  | 0% → 25% | 60.5d → 63d |
| 191 | **Control Systems Architecture** |  |  | 13% → 29% |  |
| 196 | Device control electronics architecture |  |  | 25% → 75% |  |
| 197 | Motion control architecture update 1 |  |  | 25% → 50% |  |
| 203 | **External Interface Control** |  |  | 7% → 20% |  |
| 204 | **Observatory Interfaces** |  |  | 7% → 20% |  |
| 205 | AO to Telescope Optoelectromech ICD |  |  | 4% → 29% |  |
| 206 | AO to Keck Interferometer ICD | 2009-05-25 A |  | 0% → 35% |  |
| 221 | **Technical Risk Assessment & Mitigation** | 2009-07-01 A |  | 0% → 4% |  |
| 224 | **Risk Mitigation Efforts** | 2009-07-01 A |  | 0% → 5% |  |
| 225 | **PSF Calibration** | 2009-07-01 A |  | 0% → 5% |  |
| 226 | Support/Monitor Profiler Implementation | 2009-07-01 A |  | 0% → 5% |  |
| 228 | **AO System Design** |  |  | 4% → 15% |  |
| 230 | **Opto-Mechanical** |  |  | 2% → 19% |  |
| 231 | AO Support Structure | 2009-06-01 A |  | 0% → 30% |  |
| 233 | Optical Relays |  |  | 20% → 50% |  |
| 234 | Optical Switchyard | 2009-06-01 A |  | 0% → 20% |  |
| 235 | **LGS Wavefront Sensor Assembly** |  |  | 1% → 27% |  |
| 236 | Review and conceptualize design for the LGS wavefront sensor unit | 2009-05-20 A | 2009-06-02 A | 0% → 100% | 64.85d → none |
| 237 | Identify the issues with uplink TTM, asterism generation and OSM concepts to ensure it conforms to the dithering requirements | 2009-06-03 A | 2009-06-23 A | 0% → 100% | 65.68d → none |
| 238 | Develop optical design for the LGS Shack-Hartmann sensor |  |  | 5% → 25% | 109.43d → 113.43d |
| 239 | Develop optical design for LGS WFS OSM arms | 2009-07-08 A |  | 0% → 20% |  |
| 240 | Interface LGS WFS design to overall NGAO Optical design | 2009-05-20 A |  | 0% → 50% |  |
| 241 | **Mechanical Detail of the LGS WFS Ass'ly** |  |  | 2% → 20% |  |
| 242 | Design PnS LGS WFS sensor assl'y (including OSM) |  |  | 5% → 20% | 62.76d → 72.76d |
| 243 | Design the science LGS WFS sensor (including tetrahedron pickoff) | 2009-07-30 A |  | 0% → 20% | 62.76d → 68.48d |
| 244 | Overall LGS WFS structure mechanical design | 2009-08-31 A |  | 0% → 20% |  |
| 247 | Identify LGS WFS motion control needs and specify solutions. | 2009-06-24 A |  | 0% → 33% | 65.68d → 0d |
| 261 | **Low Order Wavefront Sensor Assembly** |  |  | 0% → 15% |  |
| 262 | Review concept design for LOWFS assembly | 2009-05-20 A | 2009-07-28 A | 0% → 100% | 84.43d → none |
| 276 | **Tip/Tilt Vibration Mitigation** |  |  | 25% → 95% |  |
| 277 | TT Vibration Mitigation Analysis |  |  | 25% → 95% |  |
| 297 | **Real-time Control** |  |  | 5% → 16% |  |
| 298 | **RTC Processor** |  |  | 6% → 18% |  |
| 299 | RTC Technical Management |  |  | 10% → 20% |  |
| 300 | **Develop Internal Budgets** |  |  | 38% → 72% |  |
| 301 | Wavefront Error Budget |  |  | 33% → 74% |  |
| 302 | Power Budget |  |  | 20% → 52% |  |
| 303 | Volume Budget |  |  | 60% → 90% |  |
| 304 | **Algorithm Development Support** | 2009-05-01 A |  | 0% → 20% |  |
| 305 | MPP off-line simulator | 2009-05-01 A |  | 0% → 20% |  |
| 306 | Split tomography algorithm development | 2009-05-01 A |  | 0% → 20% |  |
| 307 | Woofer-tweeter algorithm development | 2009-05-01 A |  | 0% → 20% |  |
| 308 | **RTC Hardware** | 2009-05-01 A |  | 0% → 12% |  |
| 309 | Number and Function of RTC Processor Boards | 2009-05-01 A |  | 0% → 4% |  |
| 310 | Layout of Processors on Boards | 2009-05-01 A |  | 0% → 12% |  |
| 311 | Interconnect of processors on-board | 2009-06-29 A |  | 0% → 10% |  |
| 312 | Interconnection of boards to each other | 2009-05-01 A |  | 0% → 7% |  |

| ID | Task | Start | Finish | Duration | Complete | Total float | Other |
| --- | --- | --- | --- | --- | --- | --- | --- |
| 313 | Clock Distribution and Synchronization | 2009-05-25 A |  |  | 0% → 20% |  |  |
| 314 | Trade chip processing capacity with power dissipation capacity and manage generated heat | 2009-06-08 A |  |  | 0% → 6% |  |  |
| 315 | Hardware Interfaces to HOWFS and LOWFS cameras | 2009-07-13 A |  |  | 0% → 20% |  |  |
| 316 | Hardware Interfaces to DM drivers | 2009-05-01 A |  |  | 0% → 3% |  |  |
| 317 | Hardware Interface to Telemetry Data Capture System | 2009-06-08 A |  |  | 0% → 20% |  |  |
| 318 | **RTC Software - Time-critical tasks on Processing Engine (PE)** |  |  |  | 27% → 46% |  |  |
| 319 | Wavefront reconstructor software |  | 2009-06-30 A |  | 60% → 100% | 233d → none |  |
| 320 | Tomography Algorithm Software |  | 2009-07-03 A |  | 60% → 100% | 230d → none |  |
| 321 | DM Control Software (inverse DM response function and open-loop control) | 2009-07-27 A |  |  | 0% → 10% |  |  |
| 328 | **RTC Software - non-time-critical tasks on Control Processor** |  |  |  | 20% → 40% |  |  |
| 329 | Parameter Loader |  |  |  | 20% → 40% |  |  |
| 330 | Real-time Control Sequencer |  |  |  | 20% → 40% |  |  |
| 331 | **Software Internal Interfaces** | 2009-05-01 A |  |  | 0% → 15% |  |  |
| 332 | Control Processor (CP) to Processing Engine (PE) | 2009-06-29 A |  |  | 0% → 15% |  |  |
| 333 | **WFS Camera Interfaces** | 2009-05-01 A |  |  | 0% → 15% |  |  |
| 334 | HOWFS Camera Interface | 2009-05-01 A |  |  | 0% → 15% |  |  |
| 335 | LOWFS Camera Interface | 2009-05-25 A |  |  | 0% → 15% |  |  |
| 336 | DM Driver Interfaces | 2009-08-31 A |  |  | 0% → 15% |  |  |
| 337 | **Software External Interfaces** |  |  |  | 5% → 15% |  |  |
| 338 | RTC Server on Control Processor (CP) |  |  |  | 5% → 15% |  |  |
| 339 | Interface to Data Telemetry Capture System |  |  |  | 5% → 15% |  |  |
| 340 | **RTC Integration and Testing Plan** |  |  |  | 6% → 16% |  |  |
| 342 | **Software Test Plan** |  |  |  | 7% → 19% |  |  |
| 343 | Centroider / Wavefront Reconstructor test |  |  |  | 10% → 20% |  |  |
| 344 | Tomography Test | 2009-09-28 A |  |  | 0% → 15% |  |  |
| 345 | LOWFS processing test |  |  |  | 10% → 20% |  |  |
| 346 | DM processing test | 2009-09-14 A |  |  | 0% → 15% |  |  |
| 347 | Hybrid control loop test | 2009-09-14 A |  |  | 0% → 15% |  |  |
| 348 | External interfaces test |  |  |  | 10% → 20% |  |  |
| 349 | **Documentation** |  |  |  | 3% → 11% |  |  |
| 350 | Summary of Documents |  | 2009-05-04 A |  | 5% → 100% | 274d → none |  |
| 351 | Control Loops and Offloading Paths Diagram |  |  |  | 5% → 20% |  |  |
| 352 | Processor Engine (PE) design |  |  |  | 1% → 3% |  |  |
| 353 | RTC Algorithms Description |  |  |  | 5% → 20% |  |  |
| 354 | Control Processor (CP) design |  |  |  | 5% → 20% |  |  |
| 355 | Hardware Interface Documentation |  |  |  | 1% → 3% |  |  |
| 356 | Integration and Test Plan |  |  |  | 1% → 4% |  |  |
| 385 | **Laser Guide Star Facility (LGSF) Design** |  |  |  | 25% → 29% |  |  |
| 390 | **Laser Units** |  |  |  | 6% → 15% |  |  |
| 391 | Laser PD Contract Management |  |  |  | 10% → 25% |  |  |
| 406 | **AURA Sub-Award Quarterly Reports** |  | 2009-12-30 → 2010-01-29 (+30d) | 174d → 196d |  | 103d → 81d |  |
| 408 | Report 2 | 2009-06-30 → 2009-07-31 (+31d) | 2009-06-30 → 2009-07-31 (+31d) |  |  | 234d → 211d | constraint start no earlier than 2009-06-30 → start no earlier than 2009-07-31 |
| 409 | Report 3 | 2009-09-30 → 2009-10-30 (+30d) | 2009-09-30 → 2009-10-30 (+30d) |  |  | 168d → 146d | constraint start no earlier than 2009-09-30 → start no earlier than 2009-10-30 |
| 410 | Final Report | 2009-12-30 → 2010-01-29 (+30d) | 2009-12-30 → 2010-01-29 (+30d) |  |  | 103d → 81d | constraint start no earlier than 2009-12-30 → start no earlier than 2010-01-29 |
| 411 | **Laser Launch Facility (LLF)** |  |  |  | 19% → 22% |  |  |
| 413 | LLF Optical Design |  |  |  | 20% → 30% |  |  |
| 418 | **Laser Safety Systems** |  |  |  | 53% → 54% |  |  |
| 432 | **Space Command Laser Clearing House (LCH)** |  |  |  | 75% → 85% |  |  |
| 433 | LCH Requirements & Interfaces |  |  |  | 75% → 85% |  |  |

## Version 3 (saved 2009-08-20, file NGAO_Design_B2C_Replan_v8_tracked_Jul09.mpp)

Last finish stays 2010-05-21. Complete tasks 13 → 25.

Changed:

| ID | Task | Start | Finish | Complete | Total float |
| --- | --- | --- | --- | --- | --- |
| 1 | **NGAO Design** |  |  | 10% → 13% |  |
| 4 | **Preliminary Design** |  |  | 10% → 13% |  |
| 6 | **PD Phase Management** |  |  | 12% → 19% |  |
| 21 | **Project Management & Meetings** |  |  | 12% → 19% |  |
| 22 | **Senior Management Committee** |  |  | 15% → 25% |  |
| 23 | Senior Management Activities |  |  | 15% → 25% |  |
| 24 | Senior Management Telecons |  |  | 15% → 25% |  |
| 25 | **Team Meetings** |  |  | 15% → 25% |  |
| 26 | Meeting Participation |  |  | 15% → 25% |  |
| 30 | **Tracking & Reporting** |  |  | 13% → 22% |  |
| 31 | **Monthly Status Reports** |  |  | 15% → 25% |  |
| 32 | Monthly Team Status Reports |  |  | 15% → 25% |  |
| 33 | Monthly Project Reports (TSIP, Directors) |  |  | 15% → 25% |  |
| 34 | TSIP Project Report Telecons |  |  | 15% → 25% |  |
| 43 | **Proposals** |  |  | 12% → 20% |  |
| 45 | MRI-R2 Proposals |  |  | 38% → 88% |  |
| 52 | **Risk Mitigation** |  |  | 1% → 2% |  |
| 53 | Science Instruments |  |  | 2% → 3% |  |
| 66 | **Project Support** |  |  | 15% → 25% |  |
| 67 | Administrative/Contract Support |  |  | 15% → 25% |  |
| 68 | Shared Infrastructure |  |  | 15% → 25% |  |
| 69 | **Systems Engineering** |  |  | 13% → 18% |  |
| 70 | **Science Case Requirements** |  |  | 12% → 18% |  |
| 71 | **Science Case Requirements** |  |  | 4% → 9% |  |
| 72 | **Science Simulations** |  |  | 4% → 10% |  |
| 73 | High-z Galaxies |  |  | 8% → 15% |  |
| 74 | BH Measurements in Nearby AGN |  |  | 9% → 27% |  |
| 86 | Review Science Requirements in Requirements Database |  |  | 20% → 40% |  |
| 90 | **Science Performance Input** |  |  | 24% → 41% |  |
| 93 | Input to Preliminary Operations Concept Document |  |  | 40% → 70% |  |
| 97 | **User Community Liaison** |  |  | 5% → 8% |  |
| 102 | Progress Reporting |  |  | 20% → 30% |  |
| 103 | **Science Advisory Team Meetings** |  |  | 27% → 36% |  |
| 105 | Evaluate Science Impact of Proposed Changes | 2009-05-01 A |  | 0% → 20% |  |
| 106 | Science Postdoc Research Time |  |  | 15% → 25% |  |
| 107 | **Requirements** |  |  | 21% → 23% |  |
| 114 | **Functional Requirements (FRD)** |  |  | 28% → 35% |  |
| 115 | FRD PD Release 1 |  |  | 52% → 65% |  |
| 120 | **Systems Engineering Analysis** |  |  | 11% → 14% |  |
| 121 | **Performance Budgets** |  |  | 13% → 19% |  |
| 122 | **Wavefront Error and Ensquared Energy** |  |  | 29% → 36% |  |
| 126 | **Science Wavefront Error Flowdown Budgets** |  |  | 49% → 63% |  |
| 128 | Laser Photoreturn Budget Flowdown |  |  | 50% → 60% |  |
| 130 | Science Transmission Budget Flowdown |  | 2009-05-21 A | 75% → 100% | 242.25d → none |
| 131 | Non-common Path WFE Budget Flowdown |  |  | 40% → 60% |  |
| 132 | Uncorrectable Internal WFE Budget Flowdown |  | 2009-05-11 A | 75% → 100% | 250.25d → none |
| 142 | **High Contrast** |  |  | 14% → 50% |  |
| 143 | High Contrast Error Budget |  |  | 25% → 50% |  |
| 144 | High Contrast Error Flowdown | 2009-07-30 A |  | 0% → 50% |  |
| 158 | **Modeling & Analysis** |  |  | 2% → 4% |  |
| 164 | Additional Performance Modeling/Anchoring |  |  | 25% → 40% |  |
| 165 | **Integrated modeling** |  |  | 3% → 13% |  |
| 166 | MOAO capabilities added to LAOS |  |  | 10% → 50% |  |
| 174 | **System Architecture** |  |  | 22% → 29% |  |
| 177 | **Software Architecture** |  |  | 54% → 78% |  |
| 179 | **Controls SW Infrastructure** |  | 2009-07-03 A | 73% → 100% | 65.5d → none |
| 180 | Class decomposition |  | 2009-05-14 A | 75% → 100% | -19d → none |
| 181 | Command-response pattern |  | 2009-05-19 A | 75% → 100% | 87.5d → none |
| 182 | Base component definition |  | 2009-05-26 A | 75% → 100% | 83.75d → none |
| 183 | Middleware abstraction |  | 2009-06-02 A | 75% → 100% | 80d → none |
| 184 | Naming Scheme |  | 2009-06-04 A | 50% → 100% | 78.75d → none |
| 185 | Configuration |  | 2009-06-19 A | 75% → 100% | 70.5d → none |
| 186 | Common services |  | 2009-07-03 A | 75% → 100% | 63d → none |
| 187 | Sequencer Architecture | 2009-07-06 A | 2009-07-10 A | 0% → 100% | 63d → none |
| 188 | UI Architecture | 2009-07-13 A | 2009-07-17 A | 0% → 100% | 63d → none |
| 190 | Document software architecture |  |  | 25% → 75% |  |
| 191 | **Control Systems Architecture** |  |  | 29% → 36% |  |
| 197 | Motion control architecture update 1 |  |  | 50% → 75% |  |
| 203 | **External Interface Control** |  |  | 20% → 26% |  |
| 204 | **Observatory Interfaces** |  |  | 20% → 26% |  |

| ID | Task | Start | Finish | Complete | Total float |
| --- | --- | --- | --- | --- | --- |
| 205 | AO to Telescope Optoelectromech ICD |  |  | 29% → 41% |  |
| 206 | AO to Keck Interferometer ICD |  |  | 35% → 50% |  |
| 221 | **Technical Risk Assessment & Mitigation** |  |  | 4% → 25% |  |
| 224 | **Risk Mitigation Efforts** |  |  | 5% → 35% |  |
| 225 | **PSF Calibration** |  |  | 5% → 35% |  |
| 226 | Support/Monitor Profiler Implementation |  |  | 5% → 35% |  |
| 228 | **AO System Design** |  |  | 15% → 20% |  |
| 229 | AO Enclosure | 2009-06-01 A |  | 0% → 2% |  |
| 230 | **Opto-Mechanical** |  |  | 19% → 25% |  |
| 231 | AO Support Structure |  |  | 30% → 70% |  |
| 233 | Optical Relays |  |  | 50% → 85% |  |
| 234 | Optical Switchyard |  |  | 20% → 85% |  |
| 235 | **LGS Wavefront Sensor Assembly** |  |  | 27% → 32% |  |
| 238 | Develop optical design for the LGS Shack-Hartmann sensor |  |  | 25% → 50% |  |
| 239 | Develop optical design for LGS WFS OSM arms |  |  | 20% → 50% |  |
| 241 | **Mechanical Detail of the LGS WFS Ass'ly** |  |  | 20% → 30% |  |
| 242 | Design PnS LGS WFS sensor assl'y (including OSM) |  |  | 20% → 30% | 72.76d → 74.9d |
| 243 | Design the science LGS WFS sensor (including tetrahedron pickoff) |  |  | 20% → 30% |  |
| 244 | Overall LGS WFS structure mechanical design |  |  | 20% → 30% |  |
| 297 | **Real-time Control** |  |  | 16% → 21% |  |
| 298 | **RTC Processor** |  |  | 18% → 25% |  |
| 299 | RTC Technical Management |  |  | 20% → 25% |  |
| 304 | **Algorithm Development Support** |  |  | 20% → 70% |  |
| 305 | MPP off-line simulator |  |  | 20% → 70% |  |
| 306 | Split tomography algorithm development |  |  | 20% → 70% |  |
| 307 | Woofer-tweeter algorithm development |  |  | 20% → 70% |  |
| 308 | **RTC Hardware** |  |  | 12% → 13% |  |
| 309 | Number and Function of RTC Processor Boards |  |  | 4% → 5% |  |
| 310 | Layout of Processors on Boards |  |  | 12% → 16% |  |
| 311 | Interconnect of processors on-board |  |  | 10% → 15% |  |
| 312 | Interconnection of boards to each other |  |  | 7% → 9% |  |
| 318 | **RTC Software - Time-critical tasks on Processing Engine (PE)** |  |  | 46% → 54% |  |
| 321 | DM Control Software (inverse DM response function and open-loop control) |  | 2009-08-18 A | 10% → 100% | 198d → none |
| 328 | **RTC Software - non-time-critical tasks on Control Processor** |  |  | 40% → 70% |  |
| 329 | Parameter Loader |  |  | 40% → 70% |  |
| 330 | Real-time Control Sequencer |  |  | 40% → 70% |  |
| 331 | **Software Internal Interfaces** |  |  | 15% → 30% |  |
| 332 | Control Processor (CP) to Processing Engine (PE) |  |  | 15% → 30% |  |
| 333 | **WFS Camera Interfaces** |  |  | 15% → 30% |  |
| 334 | HOWFS Camera Interface |  |  | 15% → 30% |  |
| 335 | LOWFS Camera Interface |  |  | 15% → 30% |  |
| 336 | DM Driver Interfaces |  |  | 15% → 30% |  |
| 337 | **Software External Interfaces** |  |  | 15% → 50% |  |
| 338 | RTC Server on Control Processor (CP) |  |  | 15% → 50% |  |
| 339 | Interface to Data Telemetry Capture System |  |  | 15% → 50% |  |
| 349 | **Documentation** |  |  | 11% → 16% |  |
| 351 | Control Loops and Offloading Paths Diagram |  |  | 20% → 30% |  |
| 352 | Processor Engine (PE) design |  |  | 3% → 5% |  |
| 353 | RTC Algorithms Description |  |  | 20% → 30% |  |
| 354 | Control Processor (CP) design |  |  | 20% → 30% |  |
| 355 | Hardware Interface Documentation |  |  | 3% → 4% |  |
| 356 | Integration and Test Plan |  |  | 4% → 7% |  |
| 385 | **Laser Guide Star Facility (LGSF) Design** |  |  | 29% → 33% |  |
| 386 | **Laser Enclosure (LE)** | 2009-10-05 A |  | 0% → 1% |  |
| 387 | LE Mechanical Design | 2009-10-05 A |  | 0% → 4% |  |
| 390 | **Laser Units** |  |  | 15% → 21% |  |
| 391 | Laser PD Contract Management |  |  | 25% → 35% |  |
| 411 | **Laser Launch Facility (LLF)** |  |  | 22% → 30% |  |
| 413 | LLF Optical Design |  |  | 30% → 50% |  |
| 415 | LLF Mechanical Design | 2009-08-10 A |  | 0% → 15% |  |
| 602 | **Telescope & Summit Engineering Design** | 2009-05-04 A |  |  |  |
| 617 | **Interferometer Modifications** | 2009-07-01 A |  | 0% → 1% |  |
| 618 | Optical Design of Post Field Selector Optics | 2009-07-01 A |  | 0% → 2% |  |
| 620 | **Telescope Integration & Test** |  |  | 7% → 8% |  |
| 621 | **Old AO/Laser Removal** |  |  | 40% → 48% |  |
| 623 | Laser Removal Plan |  |  | 75% → 90% |  |

## Version 4 (saved 2009-09-23, file NGAO_Design_B2C_Replan_v8_tracked_Aug09.mpp)

Last finish stays 2010-05-21. Complete tasks 25 → 29.

Changed:

| ID | Task | Start | Finish | Complete | Total float |
| --- | --- | --- | --- | --- | --- |
| 1 | **NGAO Design** |  |  | 13% → 16% |  |
| 4 | **Preliminary Design** |  |  | 13% → 16% |  |
| 6 | **PD Phase Management** |  |  | 19% → 24% |  |
| 21 | **Project Management & Meetings** |  |  | 19% → 24% |  |
| 22 | **Senior Management Committee** |  |  | 25% → 30% |  |
| 23 | Senior Management Activities |  |  | 25% → 30% |  |
| 24 | Senior Management Telecons |  |  | 25% → 30% |  |
| 25 | **Team Meetings** |  |  | 25% → 35% |  |
| 26 | Meeting Participation |  |  | 25% → 35% |  |
| 30 | **Tracking & Reporting** |  |  | 22% → 27% |  |
| 31 | **Monthly Status Reports** |  |  | 25% → 32% |  |
| 32 | Monthly Team Status Reports |  |  | 25% → 35% |  |
| 33 | Monthly Project Reports (TSIP, Directors) |  |  | 25% → 30% |  |
| 34 | TSIP Project Report Telecons |  |  | 25% → 30% |  |
| 40 | **Other Presentations** | 2009-05-01 A |  |  |  |
| 41 | Keck Science Meeting 09 | 2009-09-17 A |  | 0% → 8% |  |
| 43 | **Proposals** |  |  | 20% → 26% |  |
| 44 | Advancement Support |  |  | 10% → 15% |  |
| 45 | MRI-R2 Proposals |  | 2009-08-10 A | 88% → 100% | 0d → none |
| 46 | TSIP Proposal |  |  | 10% → 20% |  |
| 49 | **Programmatic Risk Assessment & Mitigation** |  |  | 1% → 4% |  |
| 52 | **Risk Mitigation** |  |  | 2% → 4% |  |
| 53 | Science Instruments |  |  | 3% → 9% |  |
| 66 | **Project Support** |  |  | 25% → 32% |  |
| 67 | Administrative/Contract Support |  |  | 25% → 30% |  |
| 68 | Shared Infrastructure |  |  | 25% → 35% |  |
| 69 | **Systems Engineering** |  |  | 18% → 24% |  |
| 70 | **Science Case Requirements** |  |  | 18% → 22% |  |
| 71 | **Science Case Requirements** |  |  | 9% → 13% |  |
| 72 | **Science Simulations** |  |  | 10% → 14% |  |
| 73 | High-z Galaxies |  |  | 15% → 22% |  |
| 74 | BH Measurements in Nearby AGN |  |  | 27% → 36% |  |
| 76 | Extrasolar Planets |  |  | 1% → 2% |  |
| 86 | Review Science Requirements in Requirements Database |  |  | 40% → 50% |  |
| 94 | **Science Competitiveness** |  |  | 18% → 32% |  |
| 95 | Update List of Science Goals for Other Facilities |  |  | 20% → 33% |  |
| 96 | Evaluate NGAO Potential to Compliment Other Facilities |  |  | 15% → 30% |  |
| 97 | **User Community Liaison** |  |  | 8% → 12% |  |
| 98 | **SSC & Keck Science Meeting** | 2009-05-01 A |  | 0% → 4% |  |
| 99 | Prepare & Give Presentations | 2009-05-01 A |  | 0% → 7% |  |
| 102 | Progress Reporting |  |  | 30% → 40% |  |
| 107 | **Requirements** |  |  | 23% → 30% |  |
| 108 | **Operations Concept Document (OCD)** |  |  | 31% → 36% |  |
| 109 | OOCD Release 1 |  | 2009-06-12 A | 85% → 100% | 245d → none |
| 111 | **System Requirements (SRD)** |  |  | 13% → 33% |  |
| 112 | SRD PD Release 1 |  |  | 20% → 50% |  |
| 120 | **Systems Engineering Analysis** |  |  | 14% → 23% |  |
| 121 | **Performance Budgets** |  |  | 19% → 39% |  |
| 122 | **Wavefront Error and Ensquared Energy** |  |  | 36% → 46% |  |
| 123 | LOWFS Sharpening WFE Budgets |  |  | 10% → 25% |  |
| 126 | **Science Wavefront Error Flowdown Budgets** |  |  | 63% → 71% |  |
| 128 | Laser Photoreturn Budget Flowdown |  |  | 60% → 80% |  |
| 131 | Non-common Path WFE Budget Flowdown |  |  | 60% → 75% |  |
| 132 | Uncorrectable Internal WFE Budget Flowdown |  | 2009-05-11 A → 2009-05-11 | 100% → 75% | none → 250.25d |
| 133 | Actuator-Pupil Registration Budget Flowdown |  |  | 40% → 50% |  |
| 134 | **LOWFS Wavefront Error Flowdown Budgets** |  |  | 38% → 57% |  |
| 135 | LOWFS Uncorrectable Internal WFE Budget Flowdown |  |  | 50% → 90% |  |
| 137 | **Astrometric Precision** |  |  | 4% → 44% |  |
| 138 | Develop Astrometric Budget Tool | 2009-07-30 A |  | 0% → 80% |  |
| 142 | **High Contrast** |  |  | 50% → 83% |  |
| 143 | High Contrast Error Budget |  |  | 50% → 90% | 131.25d → 164.58d |
| 144 | High Contrast Error Flowdown |  |  | 50% → 75% |  |
| 145 | **WFE/EE Budget Tool** |  |  | 3% → 21% |  |
| 149 | Other WFE/EE Budget Tool Maintenance |  |  | 4% → 30% |  |
| 150 | **Engineering Budgets** |  |  | 46% → 51% |  |
| 151 | **Observing Efficiency** |  |  | 50% → 75% |  |
| 152 | Observing Efficiency Analysis |  |  | 50% → 75% |  |
| 158 | **Modeling & Analysis** |  |  | 4% → 5% |  |
| 164 | Additional Performance Modeling/Anchoring |  |  | 40% → 45% |  |
| 174 | **System Architecture** |  |  | 29% → 39% |  |

| ID | Task | Start | Finish | Complete | Total float |
| --- | --- | --- | --- | --- | --- |
| 175 | **System Hardware Architecture** |  |  | 5% → 25% |  |
| 176 | Maintain Hardware Architecture |  |  | 5% → 25% |  |
| 177 | **Software Architecture** |  |  | 78% → 80% | 63d → 210d |
| 190 | Document software architecture |  | 2009-07-31 A | 75% → 100% | 63d → none |
| 191 | **Control Systems Architecture** |  |  | 36% → 43% |  |
| 193 | Common state machine design | 2009-08-10 A |  | 0% → 25% |  |
| 197 | Motion control architecture update 1 |  | 2009-06-30 A | 75% → 100% | 233d → none |
| 203 | **External Interface Control** |  |  | 26% → 34% |  |
| 204 | **Observatory Interfaces** |  |  | 26% → 34% |  |
| 205 | AO to Telescope Optoelectromech ICD |  |  | 41% → 58% |  |
| 206 | AO to Keck Interferometer ICD |  |  | 50% → 70% |  |
| 210 | **Internal Interface Control** |  |  | 8% → 19% |  |
| 211 | AO to NIR IFS ICD |  |  | 5% → 50% |  |
| 217 | **Configuration Control** | 2009-10-05 A |  | 0% → 20% |  |
| 218 | Change Control Guidelines & Tools Definition | 2009-10-05 A |  | 0% → 20% |  |
| 227 | Preliminary Design Manual | 2010-03-05 A |  | 0% → 4% |  |
| 228 | **AO System Design** |  |  | 20% → 24% |  |
| 230 | **Opto-Mechanical** |  |  | 25% → 34% |  |
| 231 | AO Support Structure |  |  | 70% → 80% |  |
| 232 | Rotator | 2009-08-03 A |  | 0% → 7% |  |
| 233 | Optical Relays |  |  | 85% → 90% |  |
| 234 | Optical Switchyard |  |  | 85% → 90% |  |
| 235 | **LGS Wavefront Sensor Assembly** |  |  | 32% → 45% | 62.76d → 68.76d |
| 239 | Develop optical design for LGS WFS OSM arms |  |  | 50% → 60% | 109.43d → 115.43d |
| 240 | Interface LGS WFS design to overall NGAO Optical design |  |  | 50% → 70% | 89.43d → 95.43d |
| 241 | **Mechanical Detail of the LGS WFS Ass'ly** |  |  | 30% → 59% | 62.76d → 68.76d |
| 242 | Design PnS LGS WFS sensor assl'y (including OSM) |  |  | 30% → 80% | 74.9d → 89.48d |
| 244 | Overall LGS WFS structure mechanical design |  |  | 30% → 50% | 62.76d → 68.76d |
| 247 | Identify LGS WFS motion control needs and specify solutions. |  |  | 33% → 48% |  |
| 261 | **Low Order Wavefront Sensor Assembly** |  |  | 15% → 27% |  |
| 263 | Developing optimal dithering strategy | 2009-07-15 A |  | 0% → 25% | 84.43d → 90.43d |
| 264 | Develop optical design of the TT and TTFA/TWFS sensors | 2009-10-08 A |  | 0% → 40% |  |
| 266 | **Mechanical detail of the LOWFS ass'ly** | 2009-10-05 A |  | 0% → 18% |  |
| 267 | Develop TT and TTFA/TWFS OSM | 2009-10-05 A |  | 0% → 30% |  |
| 268 | Design the TT and the TTFA/TWFS sensor mechanics | 2009-10-29 A |  | 0% → 22% |  |
| 271 | Identify LOWFS WFS motion control needs and specify solutions |  |  | 5% → 40% |  |
| 281 | **Atmospheric Dispersion Correctors** | 2009-07-01 A |  | 0% → 6% |  |
| 283 | Science ADC | 2009-07-01 A |  | 0% → 11% |  |
| 297 | **Real-time Control** |  |  | 21% → 24% |  |
| 298 | **RTC Processor** |  |  | 25% → 27% |  |
| 299 | RTC Technical Management |  |  | 25% → 28% |  |
| 308 | **RTC Hardware** |  |  | 13% → 15% |  |
| 313 | Clock Distribution and Synchronization |  |  | 20% → 25% |  |
| 314 | Trade chip processing capacity with power dissipation capacity and manage generated heat |  |  | 6% → 8% |  |
| 315 | Hardware Interfaces to HOWFS and LOWFS cameras |  |  | 20% → 25% |  |
| 316 | Hardware Interfaces to DM drivers |  |  | 3% → 4% |  |
| 317 | Hardware Interface to Telemetry Data Capture System |  |  | 20% → 25% |  |
| 318 | **RTC Software - Time-critical tasks on Processing Engine (PE)** |  |  | 54% → 58% |  |
| 322 | Pseudo-Open Loop Control Software | 2009-08-17 A |  | 0% → 10% |  |
| 323 | **Telemetry and Diagnostic Streams Software - RTC side** | 2009-07-06 A |  | 0% → 10% |  |
| 324 | Telemetry Data Streams Software | 2009-07-06 A |  | 0% → 10% |  |
| 325 | **Monitoring and Diagnostics Streams Software** | 2009-07-20 A |  | 0% → 10% |  |
| 326 | Periodic and On-Demand Status Updates Stream to supervisory control | 2009-07-20 A |  | 0% → 10% |  |
| 327 | Self-monitoring and Alarms | 2009-09-07 A |  | 0% → 10% |  |
| 331 | **Software Internal Interfaces** |  |  | 30% → 40% |  |
| 332 | Control Processor (CP) to Processing Engine (PE) |  |  | 30% → 40% |  |
| 333 | **WFS Camera Interfaces** |  |  | 30% → 40% |  |
| 334 | HOWFS Camera Interface |  |  | 30% → 40% |  |
| 335 | LOWFS Camera Interface |  |  | 30% → 40% |  |
| 336 | DM Driver Interfaces |  |  | 30% → 40% |  |
| 349 | **Documentation** |  |  | 16% → 19% |  |
| 351 | Control Loops and Offloading Paths Diagram |  |  | 30% → 35% |  |
| 352 | Processor Engine (PE) design |  |  | 5% → 6% |  |
| 353 | RTC Algorithms Description |  |  | 30% → 35% |  |
| 354 | Control Processor (CP) design |  |  | 30% → 35% |  |
| 355 | Hardware Interface Documentation |  |  | 4% → 5% |  |
| 356 | Integration and Test Plan |  |  | 7% → 8% |  |
| 385 | **Laser Guide Star Facility (LGSF) Design** |  |  | 33% → 39% |  |
| 386 | **Laser Enclosure (LE)** |  |  | 1% → 2% |  |
| 387 | LE Mechanical Design |  |  | 4% → 5% |  |

| ID | Task | Start | Finish | Complete | Total float |
| --- | --- | --- | --- | --- | --- |
| 390 | **Laser Units** |  |  | 21% → 27% |  |
| 391 | Laser PD Contract Management |  |  | 35% → 45% |  |
| 411 | **Laser Launch Facility (LLF)** |  |  | 30% → 43% |  |
| 412 | LLF Requirements & Interfaces |  | 2009-06-26 A | 90% → 100% | 235d → none |
| 413 | LLF Optical Design |  |  | 50% → 75% |  |
| 414 | LLF Launch Telescope Preliminary Design Contract (Resue KI?? MRI/NSF) | 2009-05-18 A |  | 0% → 20% |  |
| 415 | LLF Mechanical Design |  |  | 15% → 20% |  |
| 602 | **Telescope & Summit Engineering Design** |  |  | 0% → 1% |  |
| 617 | **Interferometer Modifications** |  |  | 1% → 5% |  |
| 618 | Optical Design of Post Field Selector Optics |  |  | 2% → 10% |  |

## Version 5 (saved 2009-10-28, file NGAO_Design_B2C_Replan_v8_tracked_Sep09.mpp)

Last finish stays 2010-05-21. Complete tasks 29 → 38.

Changed:

| ID | Task | Start | Finish | Complete | Total float |
| --- | --- | --- | --- | --- | --- |
| 1 | **NGAO Design** |  |  | 16% → 19% |  |
| 4 | **Preliminary Design** |  |  | 16% → 20% |  |
| 6 | **PD Phase Management** |  |  | 24% → 33% |  |
| 21 | **Project Management & Meetings** |  |  | 24% → 32% |  |
| 22 | **Senior Management Committee** |  |  | 30% → 40% |  |
| 23 | Senior Management Activities |  |  | 30% → 40% |  |
| 24 | Senior Management Telecons |  |  | 30% → 40% |  |
| 25 | **Team Meetings** |  |  | 35% → 45% |  |
| 26 | Meeting Participation |  |  | 35% → 45% |  |
| 30 | **Tracking & Reporting** |  |  | 27% → 36% |  |
| 31 | **Monthly Status Reports** |  |  | 32% → 42% |  |
| 32 | Monthly Team Status Reports |  |  | 35% → 45% |  |
| 33 | Monthly Project Reports (TSIP, Directors) |  |  | 30% → 40% |  |
| 34 | TSIP Project Report Telecons |  |  | 30% → 40% |  |
| 40 | **Other Presentations** |  |  | 0% → 3% |  |
| 41 | Keck Science Meeting 09 |  | 2009-09-21 A | 8% → 100% | 174d → none |
| 43 | **Proposals** |  |  | 26% → 41% |  |
| 46 | TSIP Proposal |  | 2009-09-15 A | 20% → 100% | 178d → none |
| 47 | ATI Proposal(s) | 2009-09-15 A |  | 0% → 15% |  |
| 49 | **Programmatic Risk Assessment & Mitigation** |  |  | 4% → 8% |  |
| 52 | **Risk Mitigation** |  |  | 4% → 8% |  |
| 54 | Funding | 2009-05-01 A |  | 0% → 8% |  |
| 66 | **Project Support** |  |  | 32% → 45% |  |
| 67 | Administrative/Contract Support |  |  | 30% → 40% |  |
| 68 | Shared Infrastructure |  |  | 35% → 50% |  |
| 69 | **Systems Engineering** |  |  | 24% → 27% |  |
| 70 | **Science Case Requirements** |  |  | 22% → 25% |  |
| 71 | **Science Case Requirements** |  |  | 13% → 17% |  |
| 72 | **Science Simulations** |  |  | 14% → 18% |  |
| 73 | High-z Galaxies |  |  | 22% → 30% |  |
| 74 | BH Measurements in Nearby AGN |  |  | 36% → 45% |  |
| 76 | Extrasolar Planets |  |  | 2% → 3% |  |
| 86 | Review Science Requirements in Requirements Database |  |  | 50% → 70% |  |
| 97 | **User Community Liaison** |  |  | 12% → 19% |  |
| 98 | **SSC & Keck Science Meeting** |  |  | 4% → 11% |  |
| 99 | Prepare & Give Presentations |  |  | 7% → 22% |  |
| 102 | Progress Reporting |  |  | 40% → 50% |  |
| 107 | **Requirements** |  |  | 30% → 35% |  |
| 111 | **System Requirements (SRD)** |  |  | 33% → 57% |  |
| 112 | SRD PD Release 1 |  |  | 50% → 85% |  |
| 120 | **Systems Engineering Analysis** |  |  | 23% → 25% |  |
| 150 | **Engineering Budgets** |  |  | 51% → 67% |  |
| 153 | **Observing Uptime** |  |  | 50% → 75% |  |
| 155 | Observing Uptime Analysis | 2009-07-10 A |  | 0% → 50% |  |
| 174 | **System Architecture** |  |  | 39% → 41% |  |
| 191 | **Control Systems Architecture** |  |  | 43% → 50% |  |
| 193 | Common state machine design |  |  | 25% → 75% |  |
| 196 | Device control electronics architecture |  | 2009-06-12 A | 75% → 100% | 45d → none |
| 221 | **Technical Risk Assessment & Mitigation** |  |  | 25% → 73% |  |
| 224 | **Risk Mitigation Efforts** |  | 2009-09-30 A | 35% → 100% | 167d → none |
| 225 | **PSF Calibration** |  | 2009-09-30 A | 35% → 100% | 167d → none |
| 226 | Support/Monitor Profiler Implementation |  | 2009-09-30 A | 35% → 100% | 167d → none |
| 228 | **AO System Design** |  |  | 24% → 32% |  |
| 229 | AO Enclosure |  |  | 2% → 20% |  |
| 230 | **Opto-Mechanical** |  |  | 34% → 38% |  |
| 231 | AO Support Structure |  |  | 80% → 90% |  |
| 232 | Rotator |  |  | 7% → 69% | 167d → 0d |
| 233 | Optical Relays |  | 2009-07-31 A | 90% → 100% | 210d → none |
| 234 | Optical Switchyard |  |  | 90% → 95% |  |
| 278 | **Acquisition Cameras** | 2009-08-03 A |  | 0% → 38% |  |
| 279 | Acquisition Camera Implementation Issues | 2009-08-03 A |  | 0% → 75% |  |
| 284 | **Alignment, Calibration & Diagnostics** |  |  | 1% → 7% |  |
| 285 | **Simulator** |  |  | 2% → 12% |  |
| 286 | Simulator Requirements & Interfaces |  |  | 10% → 50% |  |
| 287 | Simulator Optical Design | 2009-08-17 A |  | 0% → 25% |  |
| 297 | **Real-time Control** |  |  | 24% → 33% |  |
| 298 | **RTC Processor** |  |  | 27% → 31% |  |
| 299 | RTC Technical Management |  |  | 28% → 38% |  |
| 300 | **Develop Internal Budgets** |  |  | 72% → 77% |  |
| 301 | Wavefront Error Budget |  |  | 74% → 82% |  |

| ID | Task | Start | Finish | Complete | Total float |
| --- | --- | --- | --- | --- | --- |
| 302 | Power Budget |  |  | 52% → 56% |  |
| 303 | Volume Budget |  |  | 90% → 94% |  |
| 318 | **RTC Software - Time-critical tasks on Processing Engine (PE)** |  |  | 58% → 68% |  |
| 322 | Pseudo-Open Loop Control Software |  |  | 10% → 30% |  |
| 323 | **Telemetry and Diagnostic Streams Software - RTC side** |  |  | 10% → 30% |  |
| 324 | Telemetry Data Streams Software |  |  | 10% → 30% |  |
| 325 | **Monitoring and Diagnostics Streams Software** |  |  | 10% → 30% |  |
| 326 | Periodic and On-Demand Status Updates Stream to supervisory control |  |  | 10% → 30% |  |
| 327 | Self-monitoring and Alarms |  |  | 10% → 30% |  |
| 328 | **RTC Software - non-time-critical tasks on Control Processor** |  |  | 70% → 75% |  |
| 329 | Parameter Loader |  |  | 70% → 75% |  |
| 330 | Real-time Control Sequencer |  |  | 70% → 75% |  |
| 331 | **Software Internal Interfaces** |  |  | 40% → 50% |  |
| 332 | Control Processor (CP) to Processing Engine (PE) |  |  | 40% → 50% |  |
| 333 | **WFS Camera Interfaces** |  |  | 40% → 50% |  |
| 334 | HOWFS Camera Interface |  |  | 40% → 50% |  |
| 335 | LOWFS Camera Interface |  |  | 40% → 50% |  |
| 336 | DM Driver Interfaces |  |  | 40% → 50% |  |
| 337 | **Software External Interfaces** |  |  | 50% → 65% |  |
| 338 | RTC Server on Control Processor (CP) |  |  | 50% → 65% |  |
| 339 | Interface to Data Telemetry Capture System |  |  | 50% → 65% |  |
| 340 | **RTC Integration and Testing Plan** |  |  | 16% → 23% |  |
| 341 | Hardware Test Plan | 2009-08-31 A |  | 0% → 6% | 101d → 0d |
| 342 | **Software Test Plan** |  |  | 19% → 25% |  |
| 343 | Centroider / Wavefront Reconstructor test |  |  | 20% → 25% |  |
| 344 | Tomography Test |  |  | 15% → 25% |  |
| 345 | LOWFS processing test |  |  | 20% → 25% |  |
| 346 | DM processing test |  |  | 15% → 25% |  |
| 347 | Hybrid control loop test |  |  | 15% → 25% |  |
| 348 | External interfaces test |  |  | 20% → 25% |  |
| 365 | **DMs & Tip/Tilt Stages** | 2009-05-01 A |  | 0% → 42% |  |
| 366 | **Woofer DM/TT** | 2009-05-01 A |  | 0% → 36% |  |
| 367 | Evaluate Tip/Tilt Mount Options | 2009-05-01 A |  | 0% → 61% | 205d → 0d |
| 368 | Evaluate Combined DM & Tip/Tilt Performance | 2009-08-07 A |  | 0% → 65% |  |
| 369 | Select Tip/Tilt Mount | 2009-08-21 A |  | 0% → 30% | 190d → 0d |
| 370 | Design Mechanical Package | 2009-08-28 A |  | 0% → 65% |  |
| 372 | **Tweeter DM/TT** | 2009-05-01 A |  | 0% → 47% |  |
| 373 | Evaluate Options & Select Tip/Tilt Mount | 2009-05-01 A | 2009-07-31 A | 0% → 100% | 210d → none |
| 374 | Design Mechanical Package | 2009-08-03 A | 2009-08-14 A | 0% → 100% | 200d → none |
| 376 | **LOWFS DM/TT** | 2009-05-01 A |  | 0% → 44% |  |
| 377 | Evaluate Options & Select Tip/Tilt Mount | 2009-05-01 A | 2009-07-03 A | 0% → 100% | 230d → none |
| 378 | Design Mechanical Package | 2009-07-03 A | 2009-08-07 A | 0% → 100% | 205d → none |
| 385 | **Laser Guide Star Facility (LGSF) Design** |  |  | 39% → 46% |  |
| 390 | **Laser Units** |  |  | 27% → 36% |  |
| 391 | Laser PD Contract Management |  |  | 45% → 60% |  |
| 411 | **Laser Launch Facility (LLF)** |  |  | 43% → 57% |  |
| 413 | LLF Optical Design |  |  | 75% → 90% |  |
| 414 | LLF Launch Telescope Preliminary Design Contract (Resue KI?? MRI/NSF) |  |  | 20% → 30% |  |
| 415 | LLF Mechanical Design |  |  | 20% → 80% |  |
| 435 | **Control System Design** | 2009-06-15 A |  | 0% → 5% |  |
| 436 | **Controls electronics** | 2009-06-15 A |  | 0% → 11% |  |
| 437 | Controls Infrastructure | 2009-06-15 A |  | 0% → 50% |  |
| 439 | DM & TT Control | 2009-07-13 A |  | 0% → 50% |  |
| 602 | **Telescope & Summit Engineering Design** |  |  | 1% → 2% |  |
| 617 | **Interferometer Modifications** |  |  | 5% → 13% |  |
| 618 | Optical Design of Post Field Selector Optics |  |  | 10% → 25% |  |

## Version 6 (saved 2009-11-17, file NGAO_Design_B2C_Replan_v8_tracked_Oct09.mpp)

Last finish stays 2010-05-21. Complete tasks 38 → 52.

Changed:

| ID | Task | Start | Finish | Complete | Total float |
| --- | --- | --- | --- | --- | --- |
| 1 | **NGAO Design** |  |  | 19% → 24% |  |
| 4 | **Preliminary Design** |  |  | 20% → 25% |  |
| 6 | **PD Phase Management** |  |  | 33% → 39% |  |
| 21 | **Project Management & Meetings** |  |  | 32% → 37% |  |
| 22 | **Senior Management Committee** |  |  | 40% → 48% |  |
| 23 | Senior Management Activities |  |  | 40% → 50% |  |
| 24 | Senior Management Telecons |  |  | 40% → 45% |  |
| 25 | **Team Meetings** |  |  | 45% → 50% |  |
| 26 | Meeting Participation |  |  | 45% → 50% |  |
| 30 | **Tracking & Reporting** |  |  | 36% → 43% |  |
| 31 | **Monthly Status Reports** |  |  | 42% → 48% |  |
| 32 | Monthly Team Status Reports |  |  | 45% → 50% |  |
| 33 | Monthly Project Reports (TSIP, Directors) |  |  | 40% → 50% |  |
| 34 | TSIP Project Report Telecons |  |  | 40% → 45% |  |
| 35 | **SSC Meetings** |  |  | 19% → 69% |  |
| 37 | SSC Meeting (Caltech) | 2009-11-03 A | 2009-11-04 A | 0% → 100% | 142.88d → none |
| 38 | SSC Meeting (Keck) | 2010-02-24 A | 2010-02-25 A | 0% → 100% | 61.12d → none |
| 43 | **Proposals** |  |  | 41% → 50% |  |
| 47 | ATI Proposal(s) |  |  | 15% → 95% |  |
| 49 | **Programmatic Risk Assessment & Mitigation** |  |  | 8% → 19% |  |
| 52 | **Risk Mitigation** |  |  | 8% → 19% |  |
| 53 | Science Instruments |  |  | 9% → 20% |  |
| 54 | Funding |  |  | 8% → 18% |  |
| 66 | **Project Support** |  |  | 45% → 52% |  |
| 67 | Administrative/Contract Support |  |  | 40% → 50% |  |
| 68 | Shared Infrastructure |  |  | 50% → 55% |  |
| 69 | **Systems Engineering** |  |  | 27% → 35% |  |
| 70 | **Science Case Requirements** |  |  | 25% → 35% |  |
| 71 | **Science Case Requirements** |  |  | 17% → 22% |  |
| 72 | **Science Simulations** |  |  | 18% → 24% |  |
| 73 | High-z Galaxies |  |  | 30% → 35% |  |
| 74 | BH Measurements in Nearby AGN |  |  | 45% → 50% |  |
| 78 | Resolved Stellar Populations | 2010-01-05 A |  | 0% → 25% |  |
| 80 | Other Science Write-ups | 2010-01-05 A |  | 0% → 40% |  |
| 86 | Review Science Requirements in Requirements Database |  |  | 70% → 90% |  |
| 97 | **User Community Liaison** |  |  | 19% → 39% |  |
| 98 | **SSC & Keck Science Meeting** |  |  | 11% → 31% |  |
| 100 | Obtain & Document Feedback | 2009-05-01 A |  | 0% → 40% |  |
| 101 | Proposal Writing | 2009-05-01 A |  | 0% → 33% |  |
| 102 | Progress Reporting |  |  | 50% → 60% |  |
| 103 | **Science Advisory Team Meetings** |  |  | 36% → 47% |  |
| 104 | Prepare Minutes, Presentations & KAONs |  |  | 50% → 70% |  |
| 106 | Science Postdoc Research Time |  |  | 25% → 50% |  |
| 107 | **Requirements** |  |  | 35% → 39% |  |
| 111 | **System Requirements (SRD)** |  |  | 57% → 70% |  |
| 112 | SRD PD Release 1 |  | 2009-07-09 A | 85% → 100% | 226d → none |
| 113 | SRD PD Release 2 | 2009-11-09 A |  | 0% → 10% |  |
| 120 | **Systems Engineering Analysis** |  |  | 25% → 34% |  |
| 121 | **Performance Budgets** |  |  | 39% → 50% |  |
| 122 | **Wavefront Error and Ensquared Energy** |  |  | 46% → 65% |  |
| 123 | LOWFS Sharpening WFE Budgets |  |  | 25% → 40% |  |
| 125 | Truth WFS Performance Budget | 2009-08-28 A |  | 0% → 75% | 129.12d → 134.12d |
| 126 | **Science Wavefront Error Flowdown Budgets** |  |  | 71% → 84% |  |
| 128 | Laser Photoreturn Budget Flowdown |  | 2009-05-15 A | 80% → 100% | 246.25d → none |
| 129 | Correction Latency Budget Flowdown |  |  | 25% → 75% |  |
| 131 | Non-common Path WFE Budget Flowdown |  |  | 75% → 85% |  |
| 132 | Uncorrectable Internal WFE Budget Flowdown |  |  | 75% → 85% |  |
| 134 | **LOWFS Wavefront Error Flowdown Budgets** |  |  | 57% → 83% |  |
| 136 | LOWFS Servo Latency Budget Flowdown |  |  | 25% → 75% |  |
| 137 | **Astrometric Precision** |  |  | 44% → 55% |  |
| 138 | Develop Astrometric Budget Tool |  | 2009-09-25 A | 80% → 100% | 131.25d → none |
| 142 | **High Contrast** |  |  | 83% → 93% |  |
| 143 | High Contrast Error Budget |  | 2009-07-30 A | 90% → 100% | 164.58d → none |
| 144 | High Contrast Error Flowdown |  |  | 75% → 85% |  |
| 145 | **WFE/EE Budget Tool** |  |  | 21% → 26% |  |
| 149 | Other WFE/EE Budget Tool Maintenance |  |  | 30% → 38% |  |
| 150 | **Engineering Budgets** |  |  | 67% → 72% |  |
| 151 | **Observing Efficiency** |  | 2009-07-09 A | 75% → 100% | 226.67d → none |
| 152 | Observing Efficiency Analysis |  | 2009-07-09 A | 75% → 100% | 226.67d → none |
| 158 | **Modeling & Analysis** |  |  | 5% → 15% |  |

| ID | Task | Start | Finish | Complete | Total float |
| --- | --- | --- | --- | --- | --- |
| 159 | Sys Eng Support for Proposal Efforts | 2009-05-01 A |  | 0% → 25% |  |
| 174 | **System Architecture** |  |  | 41% → 50% |  |
| 175 | **System Hardware Architecture** |  |  | 25% → 50% |  |
| 176 | Maintain Hardware Architecture |  |  | 25% → 50% |  |
| 191 | **Control Systems Architecture** |  |  | 50% → 51% |  |
| 193 | Common state machine design |  | 2009-08-14 A | 75% → 100% | 63d → none |
| 217 | **Configuration Control** |  |  | 20% → 40% |  |
| 218 | Change Control Guidelines & Tools Definition |  |  | 20% → 40% |  |
| 228 | **AO System Design** |  |  | 32% → 40% |  |
| 229 | AO Enclosure |  |  | 20% → 40% |  |
| 230 | **Opto-Mechanical** |  |  | 38% → 45% |  |
| 235 | **LGS Wavefront Sensor Assembly** |  |  | 45% → 51% | 68.76d → 33.75d |
| 238 | Develop optical design for the LGS Shack-Hartmann sensor |  |  | 50% → 70% | 127.43d → 96.42d |
| 239 | Develop optical design for LGS WFS OSM arms |  |  | 60% → 80% | 115.43d → 80.42d |
| 241 | **Mechanical Detail of the LGS WFS Ass'ly** |  |  | 59% → 69% | 68.76d → 33.75d |
| 243 | Design the science LGS WFS sensor (including tetrahedron pickoff) |  |  | 30% → 60% | 83.05d → 50.9d |
| 244 | Overall LGS WFS structure mechanical design |  |  | 50% → 60% | 68.76d → 33.75d |
| 247 | Identify LGS WFS motion control needs and specify solutions. |  |  | 48% → 70% |  |
| 248 | Identify LGS WFS design risks and mitigation | 2009-07-20 A |  | 0% → 15% | 71.68d → 36.67d |
| 261 | **Low Order Wavefront Sensor Assembly** |  |  | 27% → 36% |  |
| 264 | Develop optical design of the TT and TTFA/TWFS sensors |  |  | 40% → 45% | 62.76d → 27d |
| 266 | **Mechanical detail of the LOWFS ass'ly** |  |  | 18% → 48% |  |
| 267 | Develop TT and TTFA/TWFS OSM |  |  | 30% → 80% |  |
| 268 | Design the TT and the TTFA/TWFS sensor mechanics |  |  | 22% → 60% | 62.76d → 0d |
| 269 | Design the LOWFS cryostat | 2009-12-17 A |  | 0% → 3% |  |
| 278 | **Acquisition Cameras** |  |  | 38% → 50% |  |
| 279 | Acquisition Camera Implementation Issues |  | 2009-08-28 A | 75% → 100% | 190d → none |
| 281 | **Atmospheric Dispersion Correctors** |  |  | 6% → 54% |  |
| 282 | LOWFS ADCs Mechanical Location | 2009-08-03 A | 2009-08-28 A | 0% → 100% | 190d → none |
| 284 | **Alignment, Calibration & Diagnostics** |  |  | 7% → 9% |  |
| 285 | **Simulator** |  |  | 12% → 15% |  |
| 286 | Simulator Requirements & Interfaces |  |  | 50% → 75% |  |
| 297 | **Real-time Control** |  |  | 33% → 42% |  |
| 298 | **RTC Processor** |  |  | 31% → 41% |  |
| 299 | RTC Technical Management |  |  | 38% → 55% |  |
| 300 | **Develop Internal Budgets** |  | 2009-06-19 A | 77% → 100% | 240.41d → none |
| 301 | Wavefront Error Budget |  | 2009-06-19 A | 82% → 100% | 240.41d → none |
| 302 | Power Budget |  | 2009-06-18 A | 56% → 100% | 241d → none |
| 303 | Volume Budget |  | 2009-06-17 A | 94% → 100% | 242d → none |
| 318 | **RTC Software - Time-critical tasks on Processing Engine (PE)** |  |  | 68% → 88% |  |
| 322 | Pseudo-Open Loop Control Software |  | 2009-09-30 A | 30% → 100% | 167d → none |
| 323 | **Telemetry and Diagnostic Streams Software - RTC side** |  |  | 30% → 60% |  |
| 324 | Telemetry Data Streams Software |  |  | 30% → 60% |  |
| 325 | **Monitoring and Diagnostics Streams Software** |  |  | 30% → 60% |  |
| 326 | Periodic and On-Demand Status Updates Stream to supervisory control |  |  | 30% → 60% |  |
| 327 | Self-monitoring and Alarms |  |  | 30% → 60% |  |
| 328 | **RTC Software - non-time-critical tasks on Control Processor** |  |  | 75% → 80% |  |
| 329 | Parameter Loader |  |  | 75% → 80% |  |
| 330 | Real-time Control Sequencer |  |  | 75% → 80% |  |
| 331 | **Software Internal Interfaces** |  |  | 50% → 75% |  |
| 332 | Control Processor (CP) to Processing Engine (PE) |  |  | 50% → 75% |  |
| 333 | **WFS Camera Interfaces** |  |  | 50% → 75% |  |
| 334 | HOWFS Camera Interface |  |  | 50% → 75% |  |
| 335 | LOWFS Camera Interface |  |  | 50% → 75% |  |
| 336 | DM Driver Interfaces |  |  | 50% → 75% |  |
| 349 | **Documentation** |  |  | 19% → 41% |  |
| 351 | Control Loops and Offloading Paths Diagram |  |  | 35% → 60% |  |
| 352 | Processor Engine (PE) design |  |  | 6% → 24% | 145d → 0d |
| 353 | RTC Algorithms Description |  |  | 35% → 60% |  |
| 354 | Control Processor (CP) design |  |  | 35% → 60% |  |
| 355 | Hardware Interface Documentation |  |  | 5% → 28% | 101d → 0d |
| 356 | Integration and Test Plan |  |  | 8% → 14% |  |
| 385 | **Laser Guide Star Facility (LGSF) Design** |  |  | 46% → 52% |  |
| 390 | **Laser Units** |  |  | 36% → 45% |  |
| 391 | Laser PD Contract Management |  |  | 60% → 75% |  |
| 411 | **Laser Launch Facility (LLF)** |  |  | 57% → 65% |  |
| 414 | LLF Launch Telescope Preliminary Design Contract (Resue KI?? MRI/NSF) |  |  | 30% → 35% |  |
| 415 | LLF Mechanical Design |  |  | 80% → 85% |  |
| 416 | LLF Electrical Design | 2009-09-07 A |  | 0% → 25% |  |
| 417 | LLF Assembly, Alignment & Test Plans | 2009-11-02 A |  | 0% → 25% |  |

| ID | Task | Start | Complete | Total float |
| --- | --- | --- | --- | --- |
| 435 | **Control System Design** |  | 5% → 14% |  |
| 436 | **Controls electronics** |  | 11% → 28% |  |
| 437 | Controls Infrastructure |  | 50% → 75% | 45d → 69.5d |
| 440 | Environmental and power control | 2009-08-27 A | 0% → 25% | 45d → 47.5d |
| 442 | Laser control | 2009-10-12 A | 0% → 25% |  |
| 444 | Motion control | 2009-11-09 A | 0% → 25% |  |
| 445 | **Controls Software** | 2009-09-14 A | 0% → 6% |  |
| 461 | Motion Control | 2010-01-15 A | 0% → 25% |  |
| 602 | **Telescope & Summit Engineering Design** |  | 2% → 3% |  |
| 604 | **Infrastructure Modifications for AO** | 2009-06-08 A | 0% → 2% |  |
| 605 | AO Infrastructure Requirements & Interfaces | 2009-06-08 A | 0% → 20% |  |

## Version 7 (saved 2009-12-19, file NGAO_Design_B2C_Replan_v8_tracked_Nov09.mpp)

Last finish stays 2010-05-21. Complete tasks 52 → 53.

Changed:

| ID | Task | Start | Finish | Complete | Total float |
| --- | --- | --- | --- | --- | --- |
| 1 | **NGAO Design** |  |  | 24% → 28% |  |
| 4 | **Preliminary Design** |  |  | 25% → 28% |  |
| 6 | **PD Phase Management** |  |  | 39% → 45% |  |
| 21 | **Project Management & Meetings** |  |  | 37% → 44% |  |
| 22 | **Senior Management Committee** |  |  | 48% → 55% |  |
| 23 | Senior Management Activities |  |  | 50% → 55% |  |
| 24 | Senior Management Telecons |  |  | 45% → 55% |  |
| 25 | **Team Meetings** |  |  | 50% → 60% |  |
| 26 | Meeting Participation |  |  | 50% → 60% |  |
| 30 | **Tracking & Reporting** |  |  | 43% → 49% |  |
| 31 | **Monthly Status Reports** |  |  | 48% → 57% |  |
| 32 | Monthly Team Status Reports |  |  | 50% → 60% |  |
| 33 | Monthly Project Reports (TSIP, Directors) |  |  | 50% → 55% |  |
| 34 | TSIP Project Report Telecons |  |  | 45% → 55% |  |
| 35 | **SSC Meetings** |  |  | 69% → 38% |  |
| 38 | SSC Meeting (Keck) | 2010-02-24 A → 2010-02-24 | 2010-02-25 A → 2010-02-25 | 100% → 0% | none → 61.12d |
| 43 | **Proposals** |  |  | 50% → 51% |  |
| 47 | ATI Proposal(s) |  | 2009-11-30 A | 95% → 100% | 124d → none |
| 49 | **Programmatic Risk Assessment & Mitigation** |  |  | 19% → 24% |  |
| 52 | **Risk Mitigation** |  |  | 19% → 25% |  |
| 53 | Science Instruments |  |  | 20% → 26% |  |
| 54 | Funding |  |  | 18% → 23% |  |
| 66 | **Project Support** |  |  | 52% → 60% |  |
| 67 | Administrative/Contract Support |  |  | 50% → 55% |  |
| 68 | Shared Infrastructure |  |  | 55% → 65% |  |
| 69 | **Systems Engineering** |  |  | 35% → 38% |  |
| 70 | **Science Case Requirements** |  |  | 35% → 37% |  |
| 71 | **Science Case Requirements** |  |  | 22% → 26% |  |
| 72 | **Science Simulations** |  |  | 24% → 26% |  |
| 73 | High-z Galaxies |  |  | 35% → 45% |  |
| 85 | Science Requirements Summary Matrix | 2010-02-15 A |  | 0% → 90% |  |
| 97 | **User Community Liaison** |  |  | 39% → 42% |  |
| 102 | Progress Reporting |  |  | 60% → 70% |  |
| 107 | **Requirements** |  |  | 39% → 42% |  |
| 111 | **System Requirements (SRD)** |  |  | 70% → 75% |  |
| 113 | SRD PD Release 2 |  |  | 10% → 25% |  |
| 114 | **Functional Requirements (FRD)** |  |  | 35% → 42% |  |
| 115 | FRD PD Release 1 |  |  | 65% → 78% |  |
| 120 | **Systems Engineering Analysis** |  |  | 34% → 41% |  |
| 121 | **Performance Budgets** |  |  | 50% → 55% |  |
| 122 | **Wavefront Error and Ensquared Energy** |  |  | 65% → 69% |  |
| 123 | LOWFS Sharpening WFE Budgets |  |  | 40% → 50% | 131.5d → 45.62d |
| 125 | Truth WFS Performance Budget |  | 2009-09-18 A | 75% → 100% | 134.12d → none |
| 142 | **High Contrast** |  |  | 93% → 98% |  |
| 144 | High Contrast Error Flowdown |  |  | 85% → 95% |  |
| 145 | **WFE/EE Budget Tool** |  |  | 26% → 33% |  |
| 148 | Update Star Density Model(s) | 2009-07-27 A |  | 0% → 50% |  |
| 149 | Other WFE/EE Budget Tool Maintenance |  |  | 38% → 45% |  |
| 150 | **Engineering Budgets** |  |  | 72% → 80% |  |
| 153 | **Observing Uptime** |  |  | 75% → 88% |  |
| 155 | Observing Uptime Analysis |  |  | 50% → 75% |  |
| 158 | **Modeling & Analysis** |  |  | 15% → 24% |  |
| 159 | Sys Eng Support for Proposal Efforts |  |  | 25% → 50% |  |
| 174 | **System Architecture** |  |  | 50% → 56% |  |
| 175 | **System Hardware Architecture** |  |  | 50% → 60% |  |
| 176 | Maintain Hardware Architecture |  |  | 50% → 60% |  |
| 191 | **Control Systems Architecture** |  |  | 51% → 58% |  |
| 194 | Class-Responsibility-Collaborator model |  |  | 25% → 50% | 60.5d → 70.5d |
| 195 | Main sequence definition | 2009-08-31 A |  | 0% → 25% | 60.5d → 68d |
| 199 | Document controls architecture | 2009-09-14 A |  | 0% → 25% |  |
| 228 | **AO System Design** |  |  | 40% → 50% |  |
| 230 | **Opto-Mechanical** |  |  | 45% → 48% |  |
| 235 | **LGS Wavefront Sensor Assembly** |  |  | 51% → 59% | 33.75d → 74.35d |
| 238 | Develop optical design for the LGS Shack-Hartmann sensor |  |  | 70% → 90% | 96.42d → 139.01d |
| 239 | Develop optical design for LGS WFS OSM arms |  |  | 80% → 90% | 80.42d → 121.01d |
| 241 | **Mechanical Detail of the LGS WFS Ass'ly** |  |  | 69% → 81% | 33.75d → 74.35d |
| 242 | Design PnS LGS WFS sensor assl'y (including OSM) |  |  | 80% → 90% | 63.75d → 111.13d |
| 243 | Design the science LGS WFS sensor (including tetrahedron pickoff) |  |  | 60% → 85% | 50.9d → 92.92d |
| 244 | Overall LGS WFS structure mechanical design |  |  | 60% → 65% | 33.75d → 74.35d |
| 247 | Identify LGS WFS motion control needs and specify solutions. |  |  | 70% → 80% | 0d → 92.76d |

| ID | Task | Start | Complete | Total float |
| --- | --- | --- | --- | --- |
| 248 | Identify LGS WFS design risks and mitigation |  | 15% → 70% | 36.67d → 82.26d |
| 250 | Write LGS WFS Ass'ly Documentation as a KAON | 2009-09-21 A | 0% → 50% | 36.67d → 77.26d |
| 261 | **Low Order Wavefront Sensor Assembly** |  | 36% → 39% |  |
| 264 | Develop optical design of the TT and TTFA/TWFS sensors |  | 45% → 55% | 27d → 66.1d |
| 266 | **Mechanical detail of the LOWFS ass'ly** |  | 48% → 54% |  |
| 269 | Design the LOWFS cryostat |  | 3% → 23% |  |
| 297 | **Real-time Control** |  | 42% → 56% |  |
| 298 | **RTC Processor** |  | 41% → 57% |  |
| 299 | RTC Technical Management |  | 55% → 60% |  |
| 318 | **RTC Software - Time-critical tasks on Processing Engine (PE)** |  | 88% → 91% |  |
| 323 | **Telemetry and Diagnostic Streams Software - RTC side** |  | 60% → 70% |  |
| 324 | Telemetry Data Streams Software |  | 60% → 70% |  |
| 325 | **Monitoring and Diagnostics Streams Software** |  | 60% → 70% |  |
| 326 | Periodic and On-Demand Status Updates Stream to supervisory control |  | 60% → 70% |  |
| 327 | Self-monitoring and Alarms |  | 60% → 70% |  |
| 328 | **RTC Software - non-time-critical tasks on Control Processor** |  | 80% → 85% |  |
| 329 | Parameter Loader |  | 80% → 85% |  |
| 330 | Real-time Control Sequencer |  | 80% → 85% |  |
| 331 | **Software Internal Interfaces** |  | 75% → 80% |  |
| 332 | Control Processor (CP) to Processing Engine (PE) |  | 75% → 80% |  |
| 333 | **WFS Camera Interfaces** |  | 75% → 80% |  |
| 334 | HOWFS Camera Interface |  | 75% → 80% |  |
| 335 | LOWFS Camera Interface |  | 75% → 80% |  |
| 336 | DM Driver Interfaces |  | 75% → 80% |  |
| 337 | **Software External Interfaces** |  | 65% → 90% |  |
| 338 | RTC Server on Control Processor (CP) |  | 65% → 90% |  |
| 339 | Interface to Data Telemetry Capture System |  | 65% → 90% |  |
| 340 | **RTC Integration and Testing Plan** |  | 23% → 48% |  |
| 341 | Hardware Test Plan |  | 6% → 35% | 0d → 101d |
| 342 | **Software Test Plan** |  | 25% → 50% |  |
| 343 | Centroider / Wavefront Reconstructor test |  | 25% → 50% |  |
| 344 | Tomography Test |  | 25% → 50% |  |
| 345 | LOWFS processing test |  | 25% → 50% |  |
| 346 | DM processing test |  | 25% → 50% |  |
| 347 | Hybrid control loop test |  | 25% → 50% |  |
| 348 | External interfaces test |  | 25% → 50% |  |
| 349 | **Documentation** |  | 41% → 84% |  |
| 351 | Control Loops and Offloading Paths Diagram |  | 60% → 90% |  |
| 352 | Processor Engine (PE) design |  | 24% → 81% | 0d → 145d |
| 353 | RTC Algorithms Description |  | 60% → 90% |  |
| 354 | Control Processor (CP) design |  | 60% → 90% |  |
| 355 | Hardware Interface Documentation |  | 28% → 82% | 0d → 101d |
| 356 | Integration and Test Plan |  | 14% → 69% |  |
| 365 | **DMs & Tip/Tilt Stages** |  | 42% → 44% |  |
| 366 | **Woofer DM/TT** |  | 36% → 40% |  |
| 367 | Evaluate Tip/Tilt Mount Options |  | 61% → 67% | 0d → 205d |
| 368 | Evaluate Combined DM & Tip/Tilt Performance |  | 65% → 70% |  |
| 369 | Select Tip/Tilt Mount |  | 30% → 40% | 0d → 190d |
| 370 | Design Mechanical Package |  | 65% → 70% |  |
| 385 | **Laser Guide Star Facility (LGSF) Design** |  | 52% → 56% |  |
| 390 | **Laser Units** |  | 45% → 60% |  |
| 391 | Laser PD Contract Management |  | 75% → 90% |  |
| 392 | Laser Preliminary Design Evaluations | 2009-10-15 A | 0% → 25% |  |
| 393 | Laser Detailed Design Definition/Collaborations | 2009-12-15 A | 0% → 10% |  |
| 411 | **Laser Launch Facility (LLF)** |  | 65% → 66% |  |
| 414 | LLF Launch Telescope Preliminary Design Contract (Resue KI?? MRI/NSF) |  | 35% → 40% |  |
| 445 | **Controls Software** |  | 6% → 7% |  |
| 458 | Laser control | 2009-12-16 A | 0% → 19% | 60.5d → 68d |

## Version 8 (saved 2010-01-25, file NGAO_Design_B2C_Replan_v8_tracked_Dec09.mpp)

Last finish stays 2010-05-21. Complete tasks 53 → 74.

Changed:

| ID | Task | Start | Finish | Complete | Total float |
| --- | --- | --- | --- | --- | --- |
| 1 | **NGAO Design** |  |  | 28% → 31% |  |
| 4 | **Preliminary Design** |  |  | 28% → 31% |  |
| 6 | **PD Phase Management** |  |  | 45% → 52% |  |
| 21 | **Project Management & Meetings** |  |  | 44% → 50% |  |
| 22 | **Senior Management Committee** |  |  | 55% → 65% |  |
| 23 | Senior Management Activities |  |  | 55% → 65% |  |
| 24 | Senior Management Telecons |  |  | 55% → 65% |  |
| 25 | **Team Meetings** |  |  | 60% → 65% |  |
| 26 | Meeting Participation |  |  | 60% → 65% |  |
| 30 | **Tracking & Reporting** |  |  | 49% → 57% |  |
| 31 | **Monthly Status Reports** |  |  | 57% → 65% |  |
| 32 | Monthly Team Status Reports |  |  | 60% → 65% |  |
| 33 | Monthly Project Reports (TSIP, Directors) |  |  | 55% → 65% |  |
| 34 | TSIP Project Report Telecons |  |  | 55% → 65% |  |
| 43 | **Proposals** |  |  | 51% → 56% |  |
| 44 | Advancement Support |  |  | 15% → 25% |  |
| 49 | **Programmatic Risk Assessment & Mitigation** |  |  | 24% → 45% |  |
| 52 | **Risk Mitigation** |  |  | 25% → 46% |  |
| 53 | Science Instruments |  |  | 26% → 43% |  |
| 54 | Funding |  |  | 23% → 49% |  |
| 55 | **Preliminary Design Review** | 2009-06-29 A |  | 0% → 2% |  |
| 57 | Review Setup (Date, Participants, Charter) | 2009-11-06 A |  | 0% → 25% |  |
| 66 | **Project Support** |  |  | 60% → 67% |  |
| 67 | Administrative/Contract Support |  |  | 55% → 65% |  |
| 68 | Shared Infrastructure |  |  | 65% → 70% |  |
| 69 | **Systems Engineering** |  |  | 38% → 41% |  |
| 70 | **Science Case Requirements** |  |  | 37% → 38% |  |
| 71 | **Science Case Requirements** |  |  | 26% → 28% |  |
| 72 | **Science Simulations** |  |  | 26% → 28% |  |
| 73 | High-z Galaxies |  |  | 45% → 55% |  |
| 85 | Science Requirements Summary Matrix |  |  | 90% → 96% |  |
| 97 | **User Community Liaison** |  |  | 42% → 45% |  |
| 102 | Progress Reporting |  |  | 70% → 80% |  |
| 107 | **Requirements** |  |  | 42% → 44% |  |
| 111 | **System Requirements (SRD)** |  |  | 75% → 83% |  |
| 113 | SRD PD Release 2 |  |  | 25% → 50% |  |
| 120 | **Systems Engineering Analysis** |  |  | 41% → 46% |  |
| 121 | **Performance Budgets** |  |  | 55% → 67% |  |
| 122 | **Wavefront Error and Ensquared Energy** |  |  | 69% → 87% |  |
| 123 | LOWFS Sharpening WFE Budgets |  | 2009-07-16 A | 50% → 100% | 45.62d → none |
| 126 | **Science Wavefront Error Flowdown Budgets** |  |  | 84% → 92% |  |
| 131 | Non-common Path WFE Budget Flowdown |  | 2009-06-26 A | 85% → 100% | 216.25d → none |
| 132 | Uncorrectable Internal WFE Budget Flowdown |  | 2009-05-11 A | 85% → 100% | 250.25d → none |
| 134 | **LOWFS Wavefront Error Flowdown Budgets** |  |  | 83% → 88% |  |
| 135 | LOWFS Uncorrectable Internal WFE Budget Flowdown |  | 2009-05-12 A | 90% → 100% | 249.58d → none |
| 145 | **WFE/EE Budget Tool** |  |  | 33% → 47% |  |
| 146 | Science Cases Performance Analysis | 2009-06-17 A |  | 0% → 18% |  |
| 147 | Improved Servo Bandwidth Model | 2009-09-18 A |  | 0% → 25% |  |
| 148 | Update Star Density Model(s) |  | 2009-08-07 A | 50% → 100% | 186.25d → none |
| 149 | Other WFE/EE Budget Tool Maintenance |  |  | 45% → 55% | 90.58d → 0d |
| 158 | **Modeling & Analysis** |  |  | 24% → 25% |  |
| 164 | Additional Performance Modeling/Anchoring |  |  | 45% → 50% |  |
| 174 | **System Architecture** |  |  | 56% → 61% |  |
| 175 | **System Hardware Architecture** |  |  | 60% → 70% |  |
| 176 | Maintain Hardware Architecture |  |  | 60% → 70% |  |
| 191 | **Control Systems Architecture** |  |  | 58% → 64% |  |
| 195 | Main sequence definition |  |  | 25% → 50% | 68d → 70.78d |
| 199 | Document controls architecture |  |  | 25% → 50% |  |
| 228 | **AO System Design** |  |  | 50% → 56% |  |
| 229 | AO Enclosure |  |  | 40% → 50% |  |
| 230 | **Opto-Mechanical** |  |  | 48% → 59% |  |
| 231 | AO Support Structure |  | 2009-07-31 A | 90% → 100% | 210d → none |
| 232 | Rotator |  |  | 69% → 90% | 167d → 0d |
| 234 | Optical Switchyard |  | 2009-06-19 A | 95% → 100% | 240d → none |
| 235 | **LGS Wavefront Sensor Assembly** |  |  | 59% → 69% | 74.35d → 48.75d |
| 238 | Develop optical design for the LGS Shack-Hartmann sensor |  | 2009-07-07 A | 90% → 100% | 139.01d → none |
| 239 | Develop optical design for LGS WFS OSM arms |  | 2009-08-04 A | 90% → 100% | 121.01d → none |
| 240 | Interface LGS WFS design to overall NGAO Optical design |  |  | 70% → 85% | 101.01d → 75.42d |
| 245 | Identify stray light issues (incl. Rayleigh scatter) | 2009-06-24 A |  | 0% → 20% | 93.51d → 69.42d |
| 246 | Simulate/ conceptualize and design solutions to stray light | 2009-09-02 A |  | 0% → 20% | 93.51d → 67.92d |

| ID | Task | Start | Finish | Complete | Total float |
| --- | --- | --- | --- | --- | --- |
| 247 | Identify LGS WFS motion control needs and specify solutions. |  | 2009-07-20 A | 80% → 100% | 92.76d → none |
| 248 | Identify LGS WFS design risks and mitigation |  | 2009-08-10 A | 70% → 100% | 82.26d → none |
| 251 | **NGS Wavefront Sensor Assembly** | 2009-11-05 A |  | 0% → 28% |  |
| 252 | Review concept design for NGS WFS assembly | 2009-11-05 A | 2010-01-20 A | 0% → 100% | 62.76d → none |
| 261 | **Low Order Wavefront Sensor Assembly** |  |  | 39% → 46% | 62.76d → 70.62d |
| 264 | Develop optical design of the TT and TTFA/TWFS sensors |  |  | 55% → 65% | 66.1d → 39d |
| 266 | **Mechanical detail of the LOWFS ass'ly** |  |  | 54% → 73% | 62.76d → 70.62d |
| 267 | Develop TT and TTFA/TWFS OSM |  | 2009-11-09 A | 80% → 100% | 120.68d → none |
| 268 | Design the TT and the TTFA/TWFS sensor mechanics |  |  | 60% → 87% | 63.76d → 0d |
| 269 | Design the LOWFS cryostat |  |  | 23% → 30% | 62.76d → 70.62d |
| 271 | Identify LOWFS WFS motion control needs and specify solutions |  |  | 40% → 60% | 125.68d → 133.54d |
| 272 | Identify LOWFS design risks and mitigation | 2009-11-12 A |  | 0% → 9% | 66.1d → 56.9d |
| 281 | **Atmospheric Dispersion Correctors** |  |  | 54% → 59% |  |
| 283 | Science ADC |  |  | 11% → 22% |  |
| 297 | **Real-time Control** |  |  | 56% → 60% |  |
| 298 | **RTC Processor** |  |  | 57% → 62% |  |
| 299 | RTC Technical Management |  |  | 60% → 75% |  |
| 318 | **RTC Software - Time-critical tasks on Processing Engine (PE)** |  | 2009-09-30 A | 91% → 100% | 167d → none |
| 323 | **Telemetry and Diagnostic Streams Software - RTC side** |  | 2009-09-29 A | 70% → 100% | 168.33d → none |
| 324 | Telemetry Data Streams Software |  | 2009-07-20 A | 70% → 100% | 219.58d → none |
| 325 | **Monitoring and Diagnostics Streams Software** |  | 2009-09-29 A | 70% → 100% | 168.33d → none |
| 326 | Periodic and On-Demand Status Updates Stream to supervisory control |  | 2009-08-31 A | 70% → 100% | 189d → none |
| 327 | Self-monitoring and Alarms |  | 2009-09-29 A | 70% → 100% | 168.33d → none |
| 328 | **RTC Software - non-time-critical tasks on Control Processor** |  | 2009-07-31 A | 85% → 100% | 210d → none |
| 329 | Parameter Loader |  | 2009-07-31 A | 85% → 100% | 210d → none |
| 330 | Real-time Control Sequencer |  | 2009-07-03 A | 85% → 100% | 230d → none |
| 331 | **Software Internal Interfaces** |  |  | 80% → 90% |  |
| 332 | Control Processor (CP) to Processing Engine (PE) |  |  | 80% → 90% |  |
| 333 | **WFS Camera Interfaces** |  |  | 80% → 90% |  |
| 334 | HOWFS Camera Interface |  |  | 80% → 90% |  |
| 335 | LOWFS Camera Interface |  |  | 80% → 90% |  |
| 336 | DM Driver Interfaces |  |  | 80% → 90% |  |
| 337 | **Software External Interfaces** |  | 2009-10-16 A | 90% → 100% | 155d → none |
| 338 | RTC Server on Control Processor (CP) |  | 2009-10-16 A | 90% → 100% | 155d → none |
| 339 | Interface to Data Telemetry Capture System |  | 2009-10-16 A | 90% → 100% | 155d → none |
| 349 | **Documentation** |  |  | 84% → 92% |  |
| 351 | Control Loops and Offloading Paths Diagram |  |  | 90% → 95% |  |
| 352 | Processor Engine (PE) design |  |  | 81% → 91% | 145d → 0d |
| 353 | RTC Algorithms Description |  |  | 90% → 95% |  |
| 354 | Control Processor (CP) design |  |  | 90% → 95% |  |
| 355 | Hardware Interface Documentation |  |  | 82% → 91% | 101d → 0d |
| 356 | Integration and Test Plan |  |  | 69% → 84% | 90d → 0d |
| 365 | **DMs & Tip/Tilt Stages** |  |  | 44% → 48% |  |
| 366 | **Woofer DM/TT** |  |  | 40% → 53% |  |
| 367 | Evaluate Tip/Tilt Mount Options |  |  | 67% → 89% | 205d → 0d |
| 368 | Evaluate Combined DM & Tip/Tilt Performance |  |  | 70% → 90% |  |
| 369 | Select Tip/Tilt Mount |  |  | 40% → 80% | 190d → 0d |
| 370 | Design Mechanical Package |  |  | 70% → 90% |  |
| 385 | **Laser Guide Star Facility (LGSF) Design** |  |  | 56% → 62% |  |
| 390 | **Laser Units** |  |  | 60% → 77% |  |
| 391 | Laser PD Contract Management |  |  | 90% → 95% |  |
| 392 | Laser Preliminary Design Evaluations |  | 2009-12-08 A | 25% → 100% | 118d → none |
| 393 | Laser Detailed Design Definition/Collaborations |  |  | 10% → 25% |  |
| 435 | **Control System Design** |  |  | 14% → 16% |  |
| 436 | **Controls electronics** |  |  | 28% → 33% |  |
| 438 | Camera control | 2009-06-29 A |  | 0% → 25% |  |
| 441 | RTC control | 2009-09-28 A |  | 0% → 50% |  |
| 443 | Laser Safety System Control | 2009-10-26 A |  | 0% → 25% |  |
| 445 | **Controls Software** |  |  | 7% → 9% |  |
| 458 | Laser control |  |  | 19% → 37% |  |

## Version 9 (saved 2010-02-22, file NGAO_Design_B2C_Replan_v8_tracked_Jan10.mpp)

Last finish stays 2010-05-21. Complete tasks 74 → 83.

Changed:

| ID | Task | Start | Finish | Complete | Total float |
| --- | --- | --- | --- | --- | --- |
| 1 | **NGAO Design** |  |  | 31% → 34% |  |
| 4 | **Preliminary Design** |  |  | 31% → 34% |  |
| 6 | **PD Phase Management** |  |  | 52% → 57% |  |
| 12 | **Systems Engineering Management Plan** | 2009-07-15 A |  | 0% → 1% |  |
| 13 | **Project Plan** | 2009-12-07 A |  | 0% → 1% |  |
| 14 | PBS, WBS & Task Definition | 2009-12-07 A |  | 0% → 5% |  |
| 20 | SEMP Document | 2010-02-15 A |  | 0% → 2% |  |
| 21 | **Project Management & Meetings** |  |  | 50% → 55% |  |
| 22 | **Senior Management Committee** |  |  | 65% → 70% |  |
| 23 | Senior Management Activities |  |  | 65% → 70% |  |
| 24 | Senior Management Telecons |  |  | 65% → 70% |  |
| 25 | **Team Meetings** |  |  | 65% → 75% |  |
| 26 | Meeting Participation |  |  | 65% → 75% |  |
| 30 | **Tracking & Reporting** |  |  | 57% → 62% |  |
| 31 | **Monthly Status Reports** |  |  | 65% → 72% |  |
| 32 | Monthly Team Status Reports |  |  | 65% → 75% |  |
| 33 | Monthly Project Reports (TSIP, Directors) |  |  | 65% → 70% |  |
| 34 | TSIP Project Report Telecons |  |  | 65% → 70% |  |
| 48 | MRI 2010 Proposal | 2009-12-01 A |  | 0% → 5% |  |
| 66 | **Project Support** |  |  | 67% → 77% |  |
| 67 | Administrative/Contract Support |  |  | 65% → 75% |  |
| 68 | Shared Infrastructure |  |  | 70% → 80% |  |
| 69 | **Systems Engineering** |  |  | 41% → 44% |  |
| 70 | **Science Case Requirements** |  |  | 38% → 43% |  |
| 71 | **Science Case Requirements** |  |  | 28% → 29% |  |
| 72 | **Science Simulations** |  |  | 28% → 30% |  |
| 73 | High-z Galaxies |  |  | 55% → 61% |  |
| 85 | Science Requirements Summary Matrix |  |  | 96% → 98% |  |
| 86 | Review Science Requirements in Requirements Database |  | 2009-07-15 A | 90% → 100% | 222d → none |
| 90 | **Science Performance Input** |  |  | 41% → 72% |  |
| 91 | Define Specific Science Driver Parameters for Performance Budgets | 2009-06-22 A | 2009-11-20 A | 0% → 100% | 130d → none |
| 94 | **Science Competitiveness** |  |  | 32% → 39% |  |
| 96 | Evaluate NGAO Potential to Compliment Other Facilities |  |  | 30% → 45% |  |
| 107 | **Requirements** |  |  | 44% → 47% |  |
| 111 | **System Requirements (SRD)** |  |  | 83% → 92% |  |
| 113 | SRD PD Release 2 |  |  | 50% → 75% |  |
| 114 | **Functional Requirements (FRD)** |  |  | 42% → 43% |  |
| 116 | FRD PD Release 2 | 2010-02-01 A |  | 0% → 8% |  |
| 120 | **Systems Engineering Analysis** |  |  | 46% → 48% |  |
| 121 | **Performance Budgets** |  |  | 67% → 72% |  |
| 145 | **WFE/EE Budget Tool** |  |  | 47% → 59% |  |
| 146 | Science Cases Performance Analysis |  |  | 18% → 45% |  |
| 147 | Improved Servo Bandwidth Model |  |  | 25% → 45% |  |
| 149 | Other WFE/EE Budget Tool Maintenance |  |  | 55% → 63% |  |
| 228 | **AO System Design** |  |  | 56% → 64% |  |
| 230 | **Opto-Mechanical** |  |  | 59% → 64% |  |
| 235 | **LGS Wavefront Sensor Assembly** |  |  | 69% → 73% | 48.75d → 51d |
| 241 | **Mechanical Detail of the LGS WFS Ass'ly** |  |  | 81% → 94% | 48.75d → 51d |
| 242 | Design PnS LGS WFS sensor assl'y (including OSM) |  | 2009-07-30 A | 90% → 100% | 85.54d → none |
| 243 | Design the science LGS WFS sensor (including tetrahedron pickoff) |  | 2009-08-31 A | 85% → 100% | 67.32d → none |
| 244 | Overall LGS WFS structure mechanical design |  |  | 65% → 80% | 48.75d → 51d |
| 250 | Write LGS WFS Ass'ly Documentation as a KAON |  |  | 50% → 75% | 51.67d → 53.92d |
| 251 | **NGS Wavefront Sensor Assembly** |  |  | 28% → 41% |  |
| 253 | Develop optical design for the NGS WFS | 2010-01-28 A |  | 0% → 50% |  |
| 254 | Interface NGS WFS design to overall NGAO optical design | 2009-11-05 A |  | 0% → 25% |  |
| 255 | Develop mechanical detail for the NGS WFS ass'ly | 2010-01-20 A |  | 0% → 10% |  |
| 257 | Identify NGS WFS motion control needs and specify solutions | 2010-01-20 A |  | 0% → 20% |  |
| 261 | **Low Order Wavefront Sensor Assembly** |  |  | 46% → 48% | 70.62d → 75.98d |
| 264 | Develop optical design of the TT and TTFA/TWFS sensors |  |  | 65% → 80% |  |
| 266 | **Mechanical detail of the LOWFS ass'ly** |  |  | 73% → 76% | 70.62d → 0d |
| 269 | Design the LOWFS cryostat |  |  | 30% → 40% | 70.62d → 0d |
| 275 | Write LOWFS Ass'ly Documentation as a KAON | 2009-12-31 A |  | 0% → 10% | 56.9d → 79.31d |
| 281 | **Atmospheric Dispersion Correctors** |  |  | 59% → 81% |  |
| 283 | Science ADC |  |  | 22% → 63% |  |
| 297 | **Real-time Control** |  |  | 60% → 69% |  |
| 298 | **RTC Processor** |  |  | 62% → 72% |  |
| 299 | RTC Technical Management |  |  | 75% → 80% |  |
| 331 | **Software Internal Interfaces** |  |  | 90% → 95% |  |
| 332 | Control Processor (CP) to Processing Engine (PE) |  |  | 90% → 95% |  |
| 333 | **WFS Camera Interfaces** |  |  | 90% → 95% |  |

| ID | Task | Start | Finish | Complete | Total float |
| --- | --- | --- | --- | --- | --- |
| 334 | HOWFS Camera Interface |  |  | 90% → 95% |  |
| 335 | LOWFS Camera Interface |  |  | 90% → 95% |  |
| 336 | DM Driver Interfaces |  |  | 90% → 95% |  |
| 340 | **RTC Integration and Testing Plan** |  |  | 48% → 90% |  |
| 341 | Hardware Test Plan |  |  | 35% → 87% | 101d → 0d |
| 342 | **Software Test Plan** |  |  | 50% → 90% |  |
| 343 | Centroider / Wavefront Reconstructor test |  |  | 50% → 90% |  |
| 344 | Tomography Test |  |  | 50% → 90% |  |
| 345 | LOWFS processing test |  |  | 50% → 90% |  |
| 346 | DM processing test |  |  | 50% → 90% |  |
| 347 | Hybrid control loop test |  |  | 50% → 90% |  |
| 348 | External interfaces test |  |  | 50% → 90% |  |
| 365 | **DMs & Tip/Tilt Stages** |  |  | 48% → 50% |  |
| 366 | **Woofer DM/TT** |  |  | 53% → 60% |  |
| 367 | Evaluate Tip/Tilt Mount Options |  | 2009-08-07 A | 89% → 100% | 0d → none |
| 368 | Evaluate Combined DM & Tip/Tilt Performance |  | 2009-08-21 A | 90% → 100% | 195d → none |
| 369 | Select Tip/Tilt Mount |  | 2009-08-28 A | 80% → 100% | 0d → none |
| 370 | Design Mechanical Package |  | 2009-09-11 A | 90% → 100% | 180d → none |
| 385 | **Laser Guide Star Facility (LGSF) Design** |  |  | 62% → 66% |  |
| 390 | **Laser Units** |  |  | 77% → 84% |  |
| 391 | Laser PD Contract Management |  | 2009-12-30 A | 95% → 100% | 102d → none |
| 393 | Laser Detailed Design Definition/Collaborations |  |  | 25% → 40% |  |
| 411 | **Laser Launch Facility (LLF)** |  |  | 66% → 73% |  |
| 413 | LLF Optical Design |  |  | 90% → 95% |  |
| 414 | LLF Launch Telescope Preliminary Design Contract (Resue KI?? MRI/NSF) |  |  | 40% → 65% |  |
| 415 | LLF Mechanical Design |  |  | 85% → 95% |  |
| 435 | **Control System Design** |  |  | 16% → 24% |  |
| 436 | **Controls electronics** |  |  | 33% → 49% |  |
| 438 | Camera control |  |  | 25% → 50% | 93.25d → 130.25d |
| 440 | Environmental and power control |  |  | 25% → 50% | 71.25d → 102.75d |
| 442 | Laser control |  |  | 25% → 50% | 68.75d → 92.75d |
| 443 | Laser Safety System Control |  |  | 25% → 50% | 68.75d → 87.75d |
| 444 | Motion control |  |  | 25% → 45% |  |
| 445 | **Controls Software** |  |  | 9% → 13% |  |
| 447 | **Common services** | 2009-09-22 A |  | 0% → 6% | 70.78d → 5d |
| 449 | Health monitoring | 2009-09-25 A |  | 0% → 19% | 70.78d → 6.39d |
| 452 | Alarming | 2009-10-08 A |  | 0% → 19% | 70.78d → 5d |
| 458 | Laser control |  |  | 37% → 67% | 68d → 0d |
| 459 | Laser Safety System Control | 2009-12-25 A |  | 0% → 19% |  |

## Version 10 (saved 2010-03-24, file NGAO_Design_B2C_Replan_v8_tracked_Feb10.mpp)

Last finish stays 2010-05-21. Complete tasks 83 → 92.

Changed:

| ID | Task | Start | Finish | Complete | Total float |
| --- | --- | --- | --- | --- | --- |
| 1 | **NGAO Design** |  |  | 34% → 36% |  |
| 4 | **Preliminary Design** |  |  | 34% → 36% |  |
| 6 | **PD Phase Management** |  |  | 57% → 62% |  |
| 7 | **Planning** |  |  | 25% → 29% |  |
| 12 | **Systems Engineering Management Plan** |  |  | 1% → 6% |  |
| 13 | **Project Plan** |  |  | 1% → 9% |  |
| 14 | PBS, WBS & Task Definition |  |  | 5% → 25% |  |
| 15 | Cost Estimation | 2010-01-04 A |  | 0% → 3% |  |
| 16 | Full Schedule (MS Project Plan) | 2010-02-01 A |  | 0% → 5% |  |
| 20 | SEMP Document |  |  | 2% → 5% |  |
| 21 | **Project Management & Meetings** |  |  | 55% → 62% |  |
| 22 | **Senior Management Committee** |  |  | 70% → 80% |  |
| 23 | Senior Management Activities |  |  | 70% → 80% |  |
| 24 | Senior Management Telecons |  |  | 70% → 80% |  |
| 25 | **Team Meetings** |  |  | 75% → 80% |  |
| 26 | Meeting Participation |  |  | 75% → 80% |  |
| 30 | **Tracking & Reporting** |  |  | 62% → 70% |  |
| 31 | **Monthly Status Reports** |  |  | 72% → 80% |  |
| 32 | Monthly Team Status Reports |  |  | 75% → 80% |  |
| 33 | Monthly Project Reports (TSIP, Directors) |  |  | 70% → 80% |  |
| 34 | TSIP Project Report Telecons |  |  | 70% → 80% |  |
| 35 | **SSC Meetings** |  |  | 38% → 69% |  |
| 38 | SSC Meeting (Keck) | 2010-02-24 A | 2010-02-25 A | 0% → 100% | 61.12d → none |
| 49 | **Programmatic Risk Assessment & Mitigation** |  |  | 45% → 52% |  |
| 50 | **Risk Assessment** | 2009-06-24 A |  | 0% → 75% |  |
| 51 | Programmatic Risk Assessment | 2009-06-24 A |  | 0% → 75% |  |
| 52 | **Risk Mitigation** |  |  | 46% → 52% |  |
| 53 | Science Instruments |  |  | 43% → 54% |  |
| 55 | **Preliminary Design Review** |  |  | 2% → 5% |  |
| 57 | Review Setup (Date, Participants, Charter) |  |  | 25% → 50% |  |
| 66 | **Project Support** |  |  | 77% → 82% |  |
| 67 | Administrative/Contract Support |  |  | 75% → 80% |  |
| 68 | Shared Infrastructure |  |  | 80% → 85% |  |
| 69 | **Systems Engineering** |  |  | 44% → 45% |  |
| 107 | **Requirements** |  |  | 47% → 53% |  |
| 111 | **System Requirements (SRD)** |  |  | 92% → 95% |  |
| 113 | SRD PD Release 2 |  |  | 75% → 85% |  |
| 114 | **Functional Requirements (FRD)** |  |  | 43% → 60% |  |
| 115 | FRD PD Release 1 |  | 2009-07-09 A | 78% → 100% | 0d → none |
| 116 | FRD PD Release 2 |  |  | 8% → 27% |  |
| 120 | **Systems Engineering Analysis** |  |  | 48% → 52% |  |
| 121 | **Performance Budgets** |  |  | 72% → 79% | 90.58d → 103.08d |
| 122 | **Wavefront Error and Ensquared Energy** |  |  | 87% → 92% |  |
| 126 | **Science Wavefront Error Flowdown Budgets** |  | 2009-10-23 A | 92% → 100% | 131.62d → none |
| 129 | Correction Latency Budget Flowdown |  | 2009-10-23 A | 75% → 100% | 129.96d → none |
| 133 | Actuator-Pupil Registration Budget Flowdown |  | 2009-05-14 A | 50% → 100% | 247.25d → none |
| 134 | **LOWFS Wavefront Error Flowdown Budgets** |  | 2009-11-03 A | 88% → 100% | 124.96d → none |
| 136 | LOWFS Servo Latency Budget Flowdown |  | 2009-11-03 A | 75% → 100% | 124.96d → none |
| 137 | **Astrometric Precision** |  |  | 55% → 60% | 131.25d → 143.75d |
| 140 | **Astrometric Precision Flowdown Budgets** |  |  | 15% → 35% | 236.25d → 248.75d |
| 141 | Dimensional Stability Budget Flowdown |  |  | 15% → 35% | 236.25d → 248.75d |
| 145 | **WFE/EE Budget Tool** |  |  | 59% → 70% | 90.58d → 103.08d |
| 146 | Science Cases Performance Analysis |  |  | 45% → 59% | 174.25d → 186.75d |
| 147 | Improved Servo Bandwidth Model |  |  | 45% → 85% | 137.46d → 154.12d |
| 149 | Other WFE/EE Budget Tool Maintenance |  |  | 63% → 70% |  |
| 150 | **Engineering Budgets** |  |  | 80% → 90% |  |
| 153 | **Observing Uptime** |  | 2009-09-17 A | 88% → 100% | 176d → none |
| 155 | Observing Uptime Analysis |  | 2009-09-17 A | 75% → 100% | 176d → none |
| 156 | Electrical Power Usage Budget |  |  | 25% → 40% |  |
| 165 | **Integrated modeling** |  |  | 13% → 15% |  |
| 169 | Keck Pupil Rotation Effects (Analog Keck II PRC system) | 2009-08-12 A |  | 0% → 50% |  |
| 174 | **System Architecture** |  |  | 61% → 66% |  |
| 175 | **System Hardware Architecture** |  |  | 70% → 75% |  |
| 176 | Maintain Hardware Architecture |  |  | 70% → 75% |  |
| 191 | **Control Systems Architecture** |  |  | 64% → 75% |  |
| 194 | Class-Responsibility-Collaborator model |  |  | 50% → 70% |  |
| 195 | Main sequence definition |  |  | 50% → 65% |  |
| 198 | Motion control architecture update 2 | 2010-02-01 A |  | 0% → 50% |  |
| 221 | **Technical Risk Assessment & Mitigation** |  |  | 73% → 90% |  |
| 222 | **Risk Assessment** | 2009-07-27 A |  | 0% → 63% |  |

| ID | Task | Start | Finish | Complete | Total float |
| --- | --- | --- | --- | --- | --- |
| 223 | Risk Assessment | 2009-07-27 A |  | 0% → 63% |  |
| 228 | **AO System Design** |  |  | 64% → 66% |  |
| 230 | **Opto-Mechanical** |  |  | 64% → 73% |  |
| 232 | Rotator |  | 2009-09-30 A | 90% → 100% | 0d → none |
| 235 | **LGS Wavefront Sensor Assembly** |  |  | 73% → 74% | 51d → 158.65d |
| 241 | **Mechanical Detail of the LGS WFS Ass'ly** |  |  | 94% → 97% | 51d → 158.65d |
| 244 | Overall LGS WFS structure mechanical design |  |  | 80% → 90% | 51d → 158.65d |
| 251 | **NGS Wavefront Sensor Assembly** |  |  | 41% → 64% |  |
| 253 | Develop optical design for the NGS WFS |  |  | 50% → 75% |  |
| 254 | Interface NGS WFS design to overall NGAO optical design |  |  | 25% → 75% |  |
| 255 | Develop mechanical detail for the NGS WFS ass'ly |  |  | 10% → 35% |  |
| 256 | Check compliance of design with the design of the field steering mirror assembly | 2010-02-18 A |  | 0% → 27% |  |
| 257 | Identify NGS WFS motion control needs and specify solutions |  |  | 20% → 50% |  |
| 261 | **Low Order Wavefront Sensor Assembly** |  |  | 48% → 64% | 75.98d → 78.65d |
| 263 | Developing optimal dithering strategy |  | 2009-09-08 A | 25% → 100% | 72.67d → none |
| 264 | Develop optical design of the TT and TTFA/TWFS sensors |  | 2009-10-29 A | 80% → 100% | 39d → none |
| 265 | Develop thermal model and work emissivity details of the LOWFS assembly and feed into the overall emissivity budget | 2009-10-29 A |  | 0% → 50% | 82.69d → 87.94d |
| 266 | **Mechanical detail of the LOWFS ass'ly** |  |  | 76% → 84% |  |
| 269 | Design the LOWFS cryostat |  |  | 40% → 67% |  |
| 271 | Identify LOWFS WFS motion control needs and specify solutions |  |  | 60% → 75% | 138.89d → 141.57d |
| 272 | Identify LOWFS design risks and mitigation |  |  | 9% → 21% | 80.98d → 83.66d |
| 275 | Write LOWFS Ass'ly Documentation as a KAON |  |  | 10% → 15% | 79.31d → 81.99d |
| 281 | **Atmospheric Dispersion Correctors** |  |  | 81% → 84% |  |
| 283 | Science ADC |  |  | 63% → 69% |  |
| 297 | **Real-time Control** |  |  | 69% → 70% |  |
| 298 | **RTC Processor** |  |  | 72% → 74% |  |
| 299 | RTC Technical Management |  |  | 80% → 82% |  |
| 304 | **Algorithm Development Support** |  |  | 70% → 75% |  |
| 305 | MPP off-line simulator |  |  | 70% → 75% |  |
| 306 | Split tomography algorithm development |  |  | 70% → 75% |  |
| 307 | Woofer-tweeter algorithm development |  |  | 70% → 75% |  |
| 340 | **RTC Integration and Testing Plan** |  |  | 90% → 95% |  |
| 341 | Hardware Test Plan |  |  | 87% → 94% |  |
| 342 | **Software Test Plan** |  |  | 90% → 95% |  |
| 343 | Centroider / Wavefront Reconstructor test |  |  | 90% → 95% |  |
| 344 | Tomography Test |  |  | 90% → 95% |  |
| 345 | LOWFS processing test |  |  | 90% → 95% |  |
| 346 | DM processing test |  |  | 90% → 95% |  |
| 347 | Hybrid control loop test |  |  | 90% → 95% |  |
| 348 | External interfaces test |  |  | 90% → 95% |  |
| 385 | **Laser Guide Star Facility (LGSF) Design** |  |  | 66% → 75% |  |
| 386 | **Laser Enclosure (LE)** |  |  | 2% → 49% |  |
| 387 | LE Mechanical Design |  |  | 5% → 69% | 155d → 0d |
| 388 | LE Environmental Control Design | 2009-10-19 A |  | 0% → 74% |  |
| 390 | **Laser Units** |  |  | 84% → 92% |  |
| 393 | Laser Detailed Design Definition/Collaborations |  |  | 40% → 70% |  |
| 418 | **Laser Safety Systems** |  |  | 54% → 68% |  |
| 419 | **Personnel & Equipment Safety System** |  |  | 50% → 75% |  |
| 420 | Safety Requirements & Interfaces |  |  | 50% → 75% |  |
| 421 | Safety Algorithms, Diagrams & Dataflow |  |  | 50% → 75% |  |
| 422 | Safety Communication Protocols & Methods |  |  | 50% → 75% |  |
| 423 | Safety Performance Estimate |  |  | 50% → 75% |  |
| 424 | Safety Electronics, Shutter & Interlocks |  |  | 50% → 75% |  |
| 425 | Safety Test Plans |  |  | 50% → 75% |  |
| 435 | **Control System Design** |  |  | 24% → 25% |  |
| 436 | **Controls electronics** |  |  | 49% → 51% |  |
| 444 | Motion control |  |  | 45% → 50% |  |

## Version 11 (saved 2010-04-24, file NGAO_Design_B2C_Replan_v8_tracked_Mar10.mpp)

Last finish stays 2010-05-21. Complete tasks 92 → 99.

Changed:

| ID | Task | Start | Finish | Complete | Total float | Other |
| --- | --- | --- | --- | --- | --- | --- |
| 1 | **NGAO Design** |  |  | 36% → 41% |  |  |
| 4 | **Preliminary Design** |  |  | 36% → 42% |  |  |
| 6 | **PD Phase Management** |  |  | 62% → 67% |  |  |
| 7 | **Planning** |  |  | 29% → 41% |  |  |
| 12 | **Systems Engineering Management Plan** |  |  | 6% → 22% |  |  |
| 13 | **Project Plan** |  |  | 9% → 12% |  |  |
| 16 | Full Schedule (MS Project Plan) |  |  | 5% → 15% |  |  |
| 17 | **Detailed Design Phase Plan** | 2009-07-15 A |  | 0% → 56% |  |  |
| 18 | Detailed Design Plan v1 (TSIP proposal) | 2009-07-15 A | 2009-08-07 A | 0% → 100% | 205d → none |  |
| 19 | Detailed Design Plan Final Version | 2009-11-09 A |  | 0% → 15% |  |  |
| 21 | **Project Management & Meetings** |  |  | 62% → 67% |  |  |
| 22 | **Senior Management Committee** |  |  | 80% → 85% |  |  |
| 23 | Senior Management Activities |  |  | 80% → 85% |  |  |
| 24 | Senior Management Telecons |  |  | 80% → 85% |  |  |
| 25 | **Team Meetings** |  |  | 80% → 90% |  |  |
| 26 | Meeting Participation |  |  | 80% → 90% |  |  |
| 30 | **Tracking & Reporting** |  |  | 70% → 74% |  |  |
| 31 | **Monthly Status Reports** |  |  | 80% → 85% |  |  |
| 32 | Monthly Team Status Reports |  |  | 80% → 85% |  |  |
| 33 | Monthly Project Reports (TSIP, Directors) |  |  | 80% → 85% |  |  |
| 34 | TSIP Project Report Telecons |  |  | 80% → 85% |  |  |
| 39 | SSC Meeting (Caltech) |  |  |  |  | baseline start none → 2010-04-22; baseline finish none → 2010-04-23 |
| 43 | **Proposals** |  |  | 56% → 59% |  |  |
| 45 | MRI-R2 Proposals |  |  |  |  | baseline start none → 2009-05-01; baseline finish none → 2009-08-10 |
| 46 | TSIP Proposal |  |  |  |  | baseline start none → 2009-06-01; baseline finish none → 2009-09-15 |
| 47 | ATI Proposal(s) |  |  |  |  | baseline start none → 2009-09-15; baseline finish none → 2009-11-30 |
| 48 | MRI 2010 Proposal |  |  | 5% → 40% |  |  |
| 55 | **Preliminary Design Review** |  |  | 5% → 6% |  |  |
| 57 | Review Setup (Date, Participants, Charter) |  |  | 50% → 65% |  |  |
| 66 | **Project Support** |  |  | 82% → 87% |  |  |
| 67 | Administrative/Contract Support |  |  | 80% → 85% |  |  |
| 68 | Shared Infrastructure |  |  | 85% → 90% |  |  |
| 69 | **Systems Engineering** |  |  | 45% → 51% |  |  |
| 70 | **Science Case Requirements** |  |  | 43% → 47% |  |  |
| 71 | **Science Case Requirements** |  |  | 29% → 34% |  |  |
| 72 | **Science Simulations** |  |  | 30% → 35% |  |  |
| 73 | High-z Galaxies |  |  | 61% → 84% |  |  |
| 85 | Science Requirements Summary Matrix |  |  | 98% → 99% |  |  |
| 97 | **User Community Liaison** |  |  | 45% → 56% |  |  |
| 98 | **SSC & Keck Science Meeting** |  |  | 31% → 48% |  |  |
| 99 | Prepare & Give Presentations |  |  | 22% → 36% |  |  |
| 100 | Obtain & Document Feedback |  |  | 40% → 60% |  |  |
| 102 | Progress Reporting |  |  | 80% → 90% |  |  |
| 107 | **Requirements** |  |  | 53% → 59% |  |  |
| 111 | **System Requirements (SRD)** |  |  | 95% → 98% |  |  |
| 113 | SRD PD Release 2 |  |  | 85% → 95% |  |  |
| 114 | **Functional Requirements (FRD)** |  |  | 60% → 77% |  |  |
| 116 | FRD PD Release 2 |  |  | 27% → 90% | 60d → 0d |  |
| 117 | Compliance Matrix | 2010-03-01 A |  | 0% → 15% |  |  |
| 120 | **Systems Engineering Analysis** |  |  | 52% → 57% |  |  |
| 121 | **Performance Budgets** |  |  | 79% → 83% | 103.08d → 94.33d |  |
| 137 | **Astrometric Precision** |  |  | 60% → 63% | 143.75d → 135d |  |
| 140 | **Astrometric Precision Flowdown Budgets** |  |  | 35% → 50% | 248.75d → 240d |  |
| 141 | Dimensional Stability Budget Flowdown |  |  | 35% → 50% | 248.75d → 240d |  |
| 142 | **High Contrast** |  | 2009-09-04 A | 98% → 100% | 179.42d → none | baseline start none → 2009-06-15; baseline finish none → 2009-09-04 |
| 143 | High Contrast Error Budget |  |  |  |  | baseline start none → 2009-06-15; baseline finish none → 2009-07-30 |
| 144 | High Contrast Error Flowdown |  | 2009-09-04 A | 95% → 100% | 179.42d → none | baseline start none → 2009-07-30; baseline finish none → 2009-09-04 |
| 145 | **WFE/EE Budget Tool** |  |  | 70% → 78% | 103.08d → 94.33d |  |
| 146 | Science Cases Performance Analysis |  |  | 59% → 68% | 186.75d → 178d |  |
| 147 | Improved Servo Bandwidth Model |  | 2009-10-09 A | 85% → 100% | 154.12d → none |  |
| 149 | Other WFE/EE Budget Tool Maintenance |  |  | 70% → 78% |  |  |
| 150 | **Engineering Budgets** |  |  | 90% → 94% |  |  |
| 156 | Electrical Power Usage Budget |  |  | 40% → 65% |  |  |
| 158 | **Modeling & Analysis** |  |  | 25% → 33% |  |  |
| 159 | Sys Eng Support for Proposal Efforts |  |  | 50% → 70% |  |  |
| 164 | Additional Performance Modeling/Anchoring |  |  | 50% → 60% |  |  |
| 174 | **System Architecture** |  |  | 66% → 70% |  |  |
| 175 | **System Hardware Architecture** |  |  | 75% → 80% |  |  |
| 176 | Maintain Hardware Architecture |  |  | 75% → 80% |  |  |
| 191 | **Control Systems Architecture** |  |  | 75% → 86% |  |  |

| ID | Task | Start | Finish | Complete | Total float | Other |
| --- | --- | --- | --- | --- | --- | --- |
| 192 | Controls hierarchy and philosophy | 2009-08-03 A |  | 0% → 25% |  |  |
| 194 | Class-Responsibility-Collaborator model |  |  | 70% → 85% | 8d → 10.5d |  |
| 195 | Main sequence definition |  |  | 65% → 75% |  |  |
| 198 | Motion control architecture update 2 |  |  | 50% → 75% |  | baseline start none → 2010-02-01; baseline finish none → 2010-02-26 |
| 199 | Document controls architecture |  |  | 50% → 75% |  |  |
| 217 | **Configuration Control** |  |  | 40% → 75% |  |  |
| 218 | Change Control Guidelines & Tools Definition |  |  | 40% → 75% |  |  |
| 219 | **Documentation Control** | 2009-05-01 A |  | 0% → 50% |  |  |
| 220 | Document Control Guidelines & Tools Definition | 2009-05-01 A |  | 0% → 50% |  |  |
| 228 | **AO System Design** |  |  | 66% → 73% |  |  |
| 230 | **Opto-Mechanical** |  |  | 73% → 79% |  |  |
| 238 | Develop optical design for the LGS Shack-Hartmann sensor |  |  |  |  | baseline start none → 2009-06-24; baseline finish none → 2009-07-07 |
| 239 | Develop optical design for LGS WFS OSM arms |  |  |  |  | baseline start none → 2009-07-08; baseline finish none → 2009-08-04 |
| 240 | Interface LGS WFS design to overall NGAO Optical design |  |  |  | 185.32d → 187.46d | baseline start none → 2009-05-20; baseline finish none → 2009-09-01 |
| 246 | Simulate/ conceptualize and design solutions to stray light |  |  |  | 177.82d → 179.96d | baseline start none → 2009-09-02; baseline finish none → 2009-09-11 |
| 251 | **NGS Wavefront Sensor Assembly** |  |  | 64% → 80% |  |  |
| 253 | Develop optical design for the NGS WFS |  |  | 75% → 95% |  | baseline start none → 2010-01-28; baseline finish none → 2010-02-12 |
| 254 | Interface NGS WFS design to overall NGAO optical design |  |  | 75% → 90% |  | baseline start none → 2009-11-05; baseline finish none → 2010-02-08 |
| 255 | Develop mechanical detail for the NGS WFS ass'ly |  |  | 35% → 80% |  |  |
| 257 | Identify NGS WFS motion control needs and specify solutions |  |  | 50% → 75% | 54.76d → 58.65d |  |
| 258 | Identify NGS WFS design risks and mitigation | 2010-01-27 A |  | 0% → 39% |  |  |
| 260 | Write NGS WFS Ass'ly Documentation as a KAON | 2010-02-22 A |  | 0% → 19% |  |  |
| 261 | **Low Order Wavefront Sensor Assembly** |  |  | 64% → 75% | 78.65d → 80.8d |  |
| 264 | Develop optical design of the TT and TTFA/TWFS sensors |  |  |  |  | baseline start none → 2009-10-08; baseline finish none → 2009-10-29 |
| 265 | Develop thermal model and work emissivity details of the LOWFS assembly and feed into the overall emissivity budget |  | 2009-11-12 A | 50% → 100% | 87.94d → none |  |
| 266 | **Mechanical detail of the LOWFS ass'ly** |  |  | 84% → 95% |  | baseline start none → 2009-10-05; baseline finish none → 2010-01-28 |
| 267 | Develop TT and TTFA/TWFS OSM |  |  |  |  | baseline start none → 2009-10-05; baseline finish none → 2009-11-09 |
| 268 | Design the TT and the TTFA/TWFS sensor mechanics |  |  | 87% → 93% |  |  |
| 269 | Design the LOWFS cryostat |  |  | 67% → 93% |  |  |
| 271 | Identify LOWFS WFS motion control needs and specify solutions |  |  | 75% → 85% | 141.57d → 143.71d |  |
| 272 | Identify LOWFS design risks and mitigation |  |  | 21% → 43% | 83.66d → 91.63d |  |
| 273 | Develop preliminary LOWFS ass'ly integration plan | 2009-12-10 A |  | 0% → 50% | 83.66d → 86.63d |  |
| 275 | Write LOWFS Ass'ly Documentation as a KAON |  |  | 15% → 75% | 81.99d → 84.13d |  |
| 284 | **Alignment, Calibration & Diagnostics** |  |  | 9% → 13% |  |  |
| 285 | **Simulator** |  |  | 15% → 23% |  |  |
| 287 | Simulator Optical Design |  |  | 25% → 75% |  |  |
| 297 | **Real-time Control** |  |  | 70% → 78% |  |  |
| 299 | RTC Technical Management |  |  | 82% → 90% |  |  |
| 304 | **Algorithm Development Support** |  |  | 75% → 80% |  |  |
| 305 | MPP off-line simulator |  |  | 75% → 80% |  |  |
| 306 | Split tomography algorithm development |  |  | 75% → 80% |  |  |
| 307 | Woofer-tweeter algorithm development |  |  | 75% → 80% |  |  |
| 365 | **DMs & Tip/Tilt Stages** |  | 2009-09-11 A | 50% → 100% | 180d → none |  |
| 366 | **Woofer DM/TT** |  | 2009-09-11 A | 60% → 100% | 180d → none |  |
| 371 | Obtain Quotes | 2009-05-01 A | 2009-07-31 A | 0% → 100% | 210d → none |  |
| 372 | **Tweeter DM/TT** |  | 2009-08-31 A | 47% → 100% | 189d → none |  |
| 375 | Obtain Quotes | 2009-05-01 A | 2009-08-31 A | 0% → 100% | 189d → none |  |
| 376 | **LOWFS DM/TT** |  | 2009-09-03 A | 44% → 100% | 186d → none |  |
| 379 | Obtain Quotes | 2009-05-01 A | 2009-09-03 A | 0% → 100% | 186d → none |  |
| 385 | **Laser Guide Star Facility (LGSF) Design** |  |  | 75% → 76% |  |  |
| 390 | **Laser Units** |  |  | 92% → 96% |  |  |
| 393 | Laser Detailed Design Definition/Collaborations |  |  | 70% → 85% |  |  |
| 432 | **Space Command Laser Clearing House (LCH)** |  |  |  |  | baseline start none → 2009-08-17; baseline finish none → 2009-09-30 |
| 433 | LCH Requirements & Interfaces |  |  |  |  | baseline start none → 2009-08-17; baseline finish none → 2009-09-30 |
| 435 | **Control System Design** |  |  | 25% → 28% |  |  |
| 445 | **Controls Software** |  |  | 13% → 25% |  |  |
| 454 | Camera control | 2009-11-04 A |  | 0% → 37% | 5d → 12.95d |  |
| 455 | DM & TT Control | 2009-11-13 A |  | 0% → 19% | 5d → 11.56d |  |
| 456 | Environmental and power control | 2009-11-25 A |  | 0% → 37% | 5d → 8.78d |  |
| 457 | RTC control | 2009-12-04 A |  | 0% → 37% | 5d → 6d |  |
| 458 | Laser control |  |  | 67% → 80% |  |  |
| 459 | Laser Safety System Control |  |  | 19% → 67% | 68d → 0d |  |
| 471 | **Science Operations Tools Design** | 2009-07-06 A |  | 0% → 6% |  |  |
| 512 | **User Interfaces** | 2009-07-06 A |  | 0% → 13% |  |  |
| 513 | **User Interface (UI) Infrastructure** | 2009-07-06 A |  | 0% → 11% |  |  |
| 514 | **UI Command Interface (CI) to MCS** | 2009-07-06 A |  | 0% → 10% |  |  |
| 515 | UI to MCS Functional Requirements | 2009-07-06 A |  | 0% → 10% |  |  |
| 516 | UI to MCS Interface Definitions | 2009-07-06 A |  | 0% → 10% |  |  |
| 517 | **UI Command Interface to Pre- & Post-Observing Tools** | 2009-07-06 A |  | 0% → 13% |  |  |
| 518 | UI to Pre/Post Obs Tools Functional Requirements | 2009-07-06 A |  | 0% → 25% |  |  |

| ID | Task | Start | Complete |
| --- | --- | --- | --- |
| 520 | **Setup User Interfaces** | 2009-10-05 A | 0% → 4% |
| 521 | **Setup UI Common Structure** | 2009-10-05 A | 0% → 10% |
| 522 | Setup UI Operations Concept Document | 2009-10-05 A | 0% → 10% |
| 523 | Setup UI Software Requirements | 2009-10-05 A | 0% → 10% |
| 524 | Setup UI Module Definitions | 2009-10-05 A | 0% → 10% |
| 531 | **Observations User Interfaces** | 2009-10-05 A | 0% → 17% |
| 532 | **Observations UI Common Structure** | 2009-10-05 A | 0% → 25% |
| 533 | Observations UI Operations Concept Document | 2009-10-05 A |  |
| 534 | Observations UI Software Requirements | 2009-10-05 A | 0% → 50% |
| 535 | Observations UI Module Definitions | 2009-10-05 A | 0% → 25% |
| 536 | **Acquisition & AO Control UI** | 2009-10-05 A | 0% → 38% |
| 537 | Acq/AO Control UI Functional Requirements | 2009-10-05 A | 0% → 25% |
| 538 | Acq/AO Control UI Interface Definitions | 2009-10-05 A | 0% → 50% |
| 539 | **Observing Sequences UI** | 2009-10-05 A | 0% → 13% |
| 540 | Obs Seq UI Functional Requirements | 2009-10-05 A | 0% → 25% |
| 542 | **Status & Graph UI** | 2009-10-05 A | 0% → 25% |
| 543 | Status & Graph UI Functional Requirements | 2009-10-05 A | 0% → 50% |
| 551 | **Pre- & Post-Observing Science Support Tools** | 2009-09-01 A | 0% → 3% |
| 555 | **Science Observations Planning Tools** | 2009-09-01 A | 0% → 6% |
| 556 | **NGS Star Finder** | 2009-09-01 A | 0% → 19% |
| 557 | NGS Star Finder Operations Concept | 2009-09-01 A | 0% → 50% |
| 558 | NGS Star Finder Functional Requirements & Use Case Definitions | 2009-09-01 A | 0% → 25% |
| 561 | **Performance Prediction Tool** | 2009-09-01 A | 0% → 3% |
| 562 | Performance Prediction Operations Concept | 2009-09-01 A | 0% → 10% |
| 566 | **Observation Planning & Efficiency Tool** | 2009-09-01 A | 0% → 3% |
| 568 | Observing Planning & Efficiency Tool Functional Requirements & Use Case Definitions | 2009-09-01 A | 0% → 10% |
| 602 | **Telescope & Summit Engineering Design** |  | 3% → 7% |
| 604 | **Infrastructure Modifications for AO** |  | 2% → 10% |
| 607 | AO Infrastructure Electrical Modifications | 2009-10-05 A | 0% → 20% |
| 608 | AO Infrastructure Glycol Cooling Modifications | 2009-10-19 A | 0% → 20% |

## Version 12 (saved 2010-05-27, file NGAO_Design_B2C_Replan_v8_tracked_Apr10.mpp)

Last finish stays 2010-05-21. Complete tasks 99 → 128.

Changed:

| ID | Task | Start | Finish | Complete | Total float |
| --- | --- | --- | --- | --- | --- |
| 1 | **NGAO Design** |  |  | 41% → 44% |  |
| 4 | **Preliminary Design** |  |  | 42% → 45% |  |
| 6 | **PD Phase Management** |  |  | 67% → 73% |  |
| 7 | **Planning** |  |  | 41% → 54% |  |
| 12 | **Systems Engineering Management Plan** |  |  | 22% → 39% |  |
| 13 | **Project Plan** |  |  | 12% → 35% |  |
| 14 | PBS, WBS & Task Definition |  |  | 25% → 85% |  |
| 15 | Cost Estimation |  |  | 3% → 10% |  |
| 16 | Full Schedule (MS Project Plan) |  |  | 15% → 25% |  |
| 17 | **Detailed Design Phase Plan** |  |  | 56% → 59% |  |
| 19 | Detailed Design Plan Final Version |  |  | 15% → 20% |  |
| 20 | SEMP Document |  |  | 5% → 25% |  |
| 21 | **Project Management & Meetings** |  |  | 67% → 72% |  |
| 22 | **Senior Management Committee** |  |  | 85% → 93% |  |
| 23 | Senior Management Activities |  |  | 85% → 95% |  |
| 24 | Senior Management Telecons |  |  | 85% → 90% |  |
| 25 | **Team Meetings** |  |  | 90% → 95% |  |
| 26 | Meeting Participation |  |  | 90% → 95% |  |
| 30 | **Tracking & Reporting** |  |  | 74% → 83% |  |
| 31 | **Monthly Status Reports** |  |  | 85% → 95% |  |
| 32 | Monthly Team Status Reports |  |  | 85% → 95% |  |
| 33 | Monthly Project Reports (TSIP, Directors) |  |  | 85% → 95% |  |
| 34 | TSIP Project Report Telecons |  |  | 85% → 95% |  |
| 35 | **SSC Meetings** |  | 2010-04-23 A | 69% → 100% | 20.12d → none |
| 39 | SSC Meeting (Caltech) | 2010-04-22 A | 2010-04-23 A | 0% → 100% | 20.12d → none |
| 43 | **Proposals** |  |  | 59% → 65% |  |
| 48 | MRI 2010 Proposal |  | 2010-01-29 A | 40% → 100% | 80d → none |
| 49 | **Programmatic Risk Assessment & Mitigation** |  |  | 52% → 55% |  |
| 50 | **Risk Assessment** |  |  | 75% → 90% |  |
| 51 | Programmatic Risk Assessment |  |  | 75% → 90% |  |
| 52 | **Risk Mitigation** |  |  | 52% → 54% |  |
| 53 | Science Instruments |  |  | 54% → 60% |  |
| 55 | **Preliminary Design Review** |  |  | 6% → 23% |  |
| 56 | Define Success Criteria for all Reviews | 2009-06-29 A |  | 0% → 23% |  |
| 57 | Review Setup (Date, Participants, Charter) |  |  | 65% → 75% |  |
| 58 | Preliminary Design Report | 2010-03-12 A |  | 0% → 50% |  |
| 66 | **Project Support** |  |  | 87% → 95% |  |
| 67 | Administrative/Contract Support |  |  | 85% → 90% |  |
| 68 | Shared Infrastructure |  | 2010-02-26 A | 90% → 100% | 60d → none |
| 69 | **Systems Engineering** |  |  | 51% → 52% |  |
| 107 | **Requirements** |  |  | 59% → 60% |  |
| 114 | **Functional Requirements (FRD)** |  |  | 77% → 79% |  |
| 117 | Compliance Matrix |  |  | 15% → 25% |  |
| 174 | **System Architecture** |  |  | 70% → 72% |  |
| 191 | **Control Systems Architecture** |  |  | 86% → 93% |  |
| 192 | Controls hierarchy and philosophy |  |  | 25% → 50% |  |
| 194 | Class-Responsibility-Collaborator model |  |  | 85% → 90% | 10.5d → 190d |
| 195 | Main sequence definition |  | 2009-09-11 A | 75% → 100% | 3d → none |
| 198 | Motion control architecture update 2 |  |  | 75% → 85% |  |
| 199 | Document controls architecture |  |  | 75% → 85% |  |
| 203 | **External Interface Control** |  |  | 34% → 40% |  |
| 204 | **Observatory Interfaces** |  |  | 34% → 40% |  |
| 209 | LGSF to Telescope Software ICD |  | 2009-10-21 A | 50% → 100% | 152.33d → none |
| 210 | **Internal Interface Control** |  |  | 19% → 28% |  |
| 212 | AO to LGSF ICD |  | 2009-08-25 A | 44% → 100% | 193.33d → none |
| 221 | **Technical Risk Assessment & Mitigation** |  |  | 90% → 95% | 167d → 0d |
| 222 | **Risk Assessment** |  |  | 63% → 83% | 190d → 0d |
| 223 | Risk Assessment |  |  | 63% → 83% | 190d → 0d |
| 227 | Preliminary Design Manual |  |  | 4% → 30% |  |
| 228 | **AO System Design** |  |  | 73% → 77% |  |
| 229 | AO Enclosure |  |  | 50% → 65% |  |
| 230 | **Opto-Mechanical** |  |  | 79% → 80% |  |
| 276 | **Tip/Tilt Vibration Mitigation** |  | 2009-06-12 A | 95% → 100% | 245d → none |
| 277 | TT Vibration Mitigation Analysis |  | 2009-06-12 A | 95% → 100% | 245d → none |
| 281 | **Atmospheric Dispersion Correctors** |  | 2009-08-28 A | 84% → 100% | 190d → none |
| 283 | Science ADC |  | 2009-07-30 A | 69% → 100% | 211d → none |
| 284 | **Alignment, Calibration & Diagnostics** |  |  | 13% → 72% |  |
| 285 | **Simulator** |  |  | 23% → 70% |  |
| 288 | Simulator Mechanical Design | 2009-08-31 A |  | 0% → 70% |  |
| 289 | Simulator Electrical Design | 2009-08-17 A |  | 0% → 75% |  |

| ID | Task | Start | Finish | Complete | Total float |
| --- | --- | --- | --- | --- | --- |
| 290 | Simulator Assembly, Alignment & Test Plans | 2009-09-28 A |  | 0% → 50% |  |
| 291 | **System Alignment Tools** | 2009-10-12 A |  | 0% → 75% |  |
| 292 | Alignment Requirements & Interfaces | 2009-10-12 A | 2009-10-23 A | 0% → 100% | 150d → none |
| 293 | Alignment Optical Design | 2009-10-26 A | 2009-11-06 A | 0% → 100% | 140d → none |
| 294 | Alignment Mechanical Design | 2009-11-09 A |  | 0% → 50% |  |
| 295 | Alignment Electrical Design | 2009-11-23 A |  | 0% → 25% |  |
| 296 | Alignment Assembly, Alignment & Test Plans | 2009-12-07 A | 2009-12-18 A | 0% → 100% | 110d → none |
| 298 | **RTC Processor** |  |  | 74% → 75% |  |
| 304 | **Algorithm Development Support** |  |  | 80% → 90% |  |
| 305 | MPP off-line simulator |  |  | 80% → 90% |  |
| 306 | Split tomography algorithm development |  |  | 80% → 90% |  |
| 307 | Woofer-tweeter algorithm development |  |  | 80% → 90% |  |
| 331 | **Software Internal Interfaces** |  | 2009-12-31 A | 95% → 100% | 101d → none |
| 332 | Control Processor (CP) to Processing Engine (PE) |  | 2009-09-25 A | 95% → 100% | 170d → none |
| 333 | **WFS Camera Interfaces** |  | 2009-11-20 A | 95% → 100% | 130d → none |
| 334 | HOWFS Camera Interface |  | 2009-11-20 A | 95% → 100% | 130d → none |
| 335 | LOWFS Camera Interface |  | 2009-06-26 A | 95% → 100% | 235d → none |
| 336 | DM Driver Interfaces |  | 2009-12-31 A | 95% → 100% | 101d → none |
| 380 | **AO System Lab I&T** | 2009-11-02 A |  | 0% → 43% |  |
| 381 | AO System Lab I&T Scope Definition | 2009-11-02 A |  | 0% → 75% |  |
| 382 | AO System Lab Facility Plan | 2009-11-16 A |  | 0% → 25% |  |
| 383 | AO System Lab Integration Plan | 2009-11-16 A |  | 0% → 75% |  |
| 384 | AO System Lab Test Plan | 2009-11-16 A |  | 0% → 25% |  |
| 385 | **Laser Guide Star Facility (LGSF) Design** |  |  | 76% → 94% |  |
| 386 | **Laser Enclosure (LE)** |  | 2009-12-04 A | 49% → 100% | 120d → none |
| 387 | LE Mechanical Design |  | 2009-10-16 A | 69% → 100% | 0d → none |
| 388 | LE Environmental Control Design |  | 2009-11-03 A | 74% → 100% | 143d → none |
| 389 | LE Assembly & Test Plans | 2009-11-23 A | 2009-12-04 A | 0% → 100% | 120d → none |
| 390 | **Laser Units** |  |  | 96% → 99% |  |
| 393 | Laser Detailed Design Definition/Collaborations |  | 2010-03-30 A | 85% → 100% | 38d → none |
| 411 | **Laser Launch Facility (LLF)** |  |  | 73% → 86% |  |
| 416 | LLF Electrical Design |  |  | 25% → 85% |  |
| 417 | LLF Assembly, Alignment & Test Plans |  |  | 25% → 70% |  |
| 418 | **Laser Safety Systems** |  |  | 68% → 95% |  |
| 419 | **Personnel & Equipment Safety System** |  |  | 75% → 95% |  |
| 420 | Safety Requirements & Interfaces |  |  | 75% → 95% |  |
| 421 | Safety Algorithms, Diagrams & Dataflow |  |  | 75% → 95% |  |
| 422 | Safety Communication Protocols & Methods |  |  | 75% → 95% |  |
| 423 | Safety Performance Estimate |  |  | 75% → 95% |  |
| 424 | Safety Electronics, Shutter & Interlocks |  |  | 75% → 95% |  |
| 425 | Safety Test Plans |  |  | 75% → 95% |  |
| 426 | **Laser Traffic Control System (LTCS) Modifications (Doug can start earlier per JC)** |  |  | 50% → 95% |  |
| 427 | LTCS Requirements & Interfaces (LTCS mods. independent of other pieces laser facility design) |  |  | 50% → 95% |  |
| 428 | LTCS Algorithms, Diagrams & Dataflow |  |  | 50% → 95% |  |
| 429 | LTCS Communication Protocols & Methods |  |  | 50% → 95% |  |
| 430 | LTCS Performance Estimate |  |  | 50% → 95% |  |
| 431 | LTCS Test Plans |  |  | 50% → 95% |  |
| 432 | **Space Command Laser Clearing House (LCH)** |  |  | 85% → 95% |  |
| 433 | LCH Requirements & Interfaces |  |  | 85% → 95% |  |
| 434 | Laser System Lab I&T Plan | 2009-10-05 A | 2009-10-30 A | 0% → 100% | 145d → none |
| 435 | **Control System Design** |  |  | 28% → 37% |  |
| 445 | **Controls Software** |  |  | 25% → 59% |  |
| 446 | Controls Infrastructure | 2009-09-14 A | 2009-09-21 A | 0% → 100% | 3d → none |
| 447 | **Common services** |  |  | 6% → 14% | 15.73d → 5d |
| 453 | Configuration | 2009-10-19 A |  | 0% → 20% | 15.73d → 5d |
| 454 | Camera control |  |  | 37% → 67% | 12.95d → 0d |
| 455 | DM & TT Control |  |  | 19% → 67% | 11.56d → 0d |
| 456 | Environmental and power control |  |  | 37% → 67% | 8.78d → 0d |
| 458 | Laser control |  | 2009-12-25 A | 80% → 100% | 0d → none |
| 460 | Alignment & calibration source control | 2010-01-06 A | 2010-01-15 A | 0% → 100% | 68d → none |
| 461 | Motion Control |  |  | 25% → 75% |  |
| 602 | **Telescope & Summit Engineering Design** |  |  | 7% → 56% |  |
| 604 | **Infrastructure Modifications for AO** |  |  | 10% → 38% |  |
| 607 | AO Infrastructure Electrical Modifications |  |  | 20% → 90% |  |
| 608 | AO Infrastructure Glycol Cooling Modifications |  |  | 20% → 90% |  |
| 611 | **Infrastructure modifications for LGSF** | 2009-05-04 A | 2010-02-05 A | 0% → 100% | 75d → none |
| 612 | LGSF Infrastructure Requirements & Interfaces | 2009-05-04 A | 2009-05-29 A | 0% → 100% | 255d → none |
| 613 | LGSF Infrastructure Mechanical Modifications | 2009-07-03 A | 2009-08-28 A | 0% → 100% | 190d → none |
| 614 | LGSF Infrastructure Electrical Modifications | 2009-12-07 A | 2010-02-05 A | 0% → 100% | 75d → none |
| 615 | LGSF Infrastructure Glycol Cooling Modifications | 2009-07-13 A | 2009-09-11 A | 0% → 100% | 180d → none |

| ID | Task | Start | Finish | Complete | Total float |
| --- | --- | --- | --- | --- | --- |
| 616 | LGSF Infrastructure Implementation & Test Plans | 2009-09-01 A | 2009-10-02 A | 0% → 100% | 165d → none |
| 620 | **Telescope Integration & Test** |  |  | 8% → 15% |  |
| 621 | **Old AO/Laser Removal** |  |  | 48% → 53% |  |
| 623 | Laser Removal Plan |  | 2009-11-13 A | 90% → 100% | 135d → none |
| 632 | **Laser System Install + I&T** | 2009-10-23 A |  | 0% → 27% |  |
| 633 | LGSF Installation & Integration Plan | 2009-10-23 A |  | 0% → 50% |  |

## Version 13 (saved 2010-06-25, file NGAO_Design_B2C_Replan_v8_tracked_May10.mpp)

Last finish stays 2010-05-21. Complete tasks 128 → 191.

Changed:

| ID | Task | Start | Finish | Complete | Total float |
| --- | --- | --- | --- | --- | --- |
| 1 | **NGAO Design** |  |  | 44% → 47% |  |
| 4 | **Preliminary Design** |  |  | 45% → 48% |  |
| 6 | **PD Phase Management** |  |  | 73% → 75% |  |
| 7 | **Planning** |  | 2010-03-19 A | 54% → 100% | 45d → none |
| 12 | **Systems Engineering Management Plan** |  | 2010-03-19 A | 39% → 100% | 45d → none |
| 13 | **Project Plan** |  | 2010-03-12 A | 35% → 100% | 50d → none |
| 14 | PBS, WBS & Task Definition |  | 2010-01-08 A | 85% → 100% | 95d → none |
| 15 | Cost Estimation |  | 2010-02-26 A | 10% → 100% | 60d → none |
| 16 | Full Schedule (MS Project Plan) |  | 2010-03-12 A | 25% → 100% | 50d → none |
| 17 | **Detailed Design Phase Plan** |  | 2009-12-03 A | 59% → 100% | 121d → none |
| 19 | Detailed Design Plan Final Version |  | 2009-12-03 A | 20% → 100% | 121d → none |
| 20 | SEMP Document |  | 2010-03-19 A | 25% → 100% | 44d → none |
| 21 | **Project Management & Meetings** |  |  | 72% → 71% |  |
| 22 | **Senior Management Committee** |  |  | 93% → 90% |  |
| 23 | Senior Management Activities |  |  | 95% → 90% |  |
| 30 | **Tracking & Reporting** |  |  | 83% → 79% |  |
| 31 | **Monthly Status Reports** |  |  | 95% → 90% |  |
| 32 | Monthly Team Status Reports |  |  | 95% → 90% |  |
| 33 | Monthly Project Reports (TSIP, Directors) |  |  | 95% → 90% |  |
| 34 | TSIP Project Report Telecons |  |  | 95% → 90% |  |
| 49 | **Programmatic Risk Assessment & Mitigation** |  |  | 55% → 61% |  |
| 50 | **Risk Assessment** |  | 2009-06-30 A | 90% → 100% | 233d → none |
| 51 | Programmatic Risk Assessment |  | 2009-06-30 A | 90% → 100% | 233d → none |
| 52 | **Risk Mitigation** |  |  | 54% → 60% |  |
| 53 | Science Instruments |  |  | 60% → 71% |  |
| 55 | **Preliminary Design Review** |  |  | 23% → 43% |  |
| 56 | Define Success Criteria for all Reviews |  |  | 23% → 37% |  |
| 57 | Review Setup (Date, Participants, Charter) |  | 2009-11-12 A | 75% → 100% | 136d → none |
| 58 | Preliminary Design Report |  | 2010-03-29 A | 50% → 100% | 38d → none |
| 59 | Review Package Distributed | 2010-04-02 A |  | 0% → 90% |  |
| 62 | PDR Presentation Preparation | 2010-04-05 A |  | 0% → 10% |  |
| 66 | **Project Support** |  |  | 95% → 90% |  |
| 68 | Shared Infrastructure |  | 2010-02-26 A → 2010-02-26 | 100% → 90% | none → 60d |
| 69 | **Systems Engineering** |  |  | 52% → 56% |  |
| 107 | **Requirements** |  |  | 60% → 67% |  |
| 111 | **System Requirements (SRD)** |  | 2009-12-11 A | 98% → 100% | 115d → none |
| 113 | SRD PD Release 2 |  | 2009-12-11 A | 95% → 100% | 115d → none |
| 114 | **Functional Requirements (FRD)** |  | 2010-03-31 A | 79% → 100% | 37d → none |
| 116 | FRD PD Release 2 |  | 2010-02-26 A | 90% → 100% | 0d → none |
| 117 | Compliance Matrix |  | 2010-03-31 A | 25% → 100% | 37d → none |
| 120 | **Systems Engineering Analysis** |  |  | 57% → 67% |  |
| 121 | **Performance Budgets** |  |  | 83% → 88% | 100.58d → 109.33d |
| 145 | **WFE/EE Budget Tool** |  |  | 78% → 90% | 100.58d → 109.33d |
| 146 | Science Cases Performance Analysis |  | 2009-08-25 A | 68% → 100% | 178d → none |
| 149 | Other WFE/EE Budget Tool Maintenance |  |  | 78% → 85% | 0d → 109.33d |
| 150 | **Engineering Budgets** |  |  | 94% → 99% |  |
| 156 | Electrical Power Usage Budget |  | 2010-01-25 A | 65% → 100% | 84.33d → none |
| 158 | **Modeling & Analysis** |  |  | 33% → 43% |  |
| 159 | Sys Eng Support for Proposal Efforts |  |  | 70% → 90% |  |
| 164 | Additional Performance Modeling/Anchoring |  |  | 60% → 90% |  |
| 173 | PSF Calibration | 2009-07-01 A |  | 0% → 50% |  |
| 174 | **System Architecture** |  |  | 72% → 79% |  |
| 175 | **System Hardware Architecture** |  | 2010-01-08 A | 80% → 100% | 95d → none |
| 176 | Maintain Hardware Architecture |  | 2010-01-08 A | 80% → 100% | 95d → none |
| 191 | **Control Systems Architecture** |  |  | 93% → 90% |  |
| 192 | Controls hierarchy and philosophy |  | 2009-08-07 A | 50% → 100% | 205d → none |
| 194 | Class-Responsibility-Collaborator model |  |  | 90% → 85% | 190d → 16.09d |
| 195 | Main sequence definition |  | 2009-09-11 A → 2009-09-11 | 100% → 90% | none → 7.09d |
| 198 | Motion control architecture update 2 |  |  | 85% → 75% |  |
| 199 | Document controls architecture |  |  | 85% → 75% |  |
| 203 | **External Interface Control** |  |  | 40% → 34% |  |
| 204 | **Observatory Interfaces** |  |  | 40% → 34% |  |
| 209 | LGSF to Telescope Software ICD |  | 2009-10-21 A → 2009-10-21 | 100% → 50% | none → 152.33d |
| 210 | **Internal Interface Control** |  |  | 28% → 25% |  |
| 211 | AO to NIR IFS ICD |  |  | 50% → 75% |  |
| 212 | AO to LGSF ICD |  | 2009-08-25 A → 2009-08-25 | 100% → 44% | none → 193.33d |
| 217 | **Configuration Control** |  | 2009-11-30 A | 75% → 100% | 124d → none |
| 218 | Change Control Guidelines & Tools Definition |  | 2009-11-30 A | 75% → 100% | 124d → none |
| 219 | **Documentation Control** |  | 2009-11-26 A | 50% → 100% | 126.4d → none |
| 220 | Document Control Guidelines & Tools Definition |  | 2009-11-26 A | 50% → 100% | 126.4d → none |

| ID | Task | Start | Finish | Complete | Total float |
| --- | --- | --- | --- | --- | --- |
| 221 | **Technical Risk Assessment & Mitigation** |  | 2009-09-30 A | 95% → 100% | 0d → none |
| 222 | **Risk Assessment** |  | 2009-08-28 A | 83% → 100% | 0d → none |
| 223 | Risk Assessment |  | 2009-08-28 A | 83% → 100% | 0d → none |
| 227 | Preliminary Design Manual |  | 2010-04-01 A | 30% → 100% | 35d → none |
| 228 | **AO System Design** |  |  | 77% → 81% |  |
| 229 | AO Enclosure |  |  | 65% → 75% |  |
| 230 | **Opto-Mechanical** |  |  | 80% → 85% |  |
| 231 | AO Support Structure |  | 2009-07-31 A → 2009-07-31 | 100% → 95% | none → 210d |
| 235 | **LGS Wavefront Sensor Assembly** |  |  | 74% → 78% | 160.8d → 161.33d |
| 240 | Interface LGS WFS design to overall NGAO Optical design |  | 2009-09-01 A | 85% → 100% | 187.46d → none |
| 241 | **Mechanical Detail of the LGS WFS Ass'ly** |  | 2009-10-08 A | 97% → 100% | 160.8d → none |
| 244 | Overall LGS WFS structure mechanical design |  | 2009-10-08 A | 90% → 100% | 160.8d → none |
| 250 | Write LGS WFS Ass'ly Documentation as a KAON |  | 2009-10-05 A | 75% → 100% | 163.71d → none |
| 251 | **NGS Wavefront Sensor Assembly** |  |  | 80% → 94% | 54.76d → 0d |
| 253 | Develop optical design for the NGS WFS |  | 2010-02-12 A | 95% → 100% | 70.62d → none |
| 254 | Interface NGS WFS design to overall NGAO optical design |  | 2010-02-08 A | 90% → 100% | 74.67d → none |
| 255 | Develop mechanical detail for the NGS WFS ass'ly |  | 2010-02-24 A | 80% → 100% | 62.76d → none |
| 256 | Check compliance of design with the design of the field steering mirror assembly |  | 2010-02-24 A | 27% → 100% | 62.76d → none |
| 257 | Identify NGS WFS motion control needs and specify solutions |  | 2010-01-27 A | 75% → 100% | 58.65d → none |
| 258 | Identify NGS WFS design risks and mitigation |  |  | 39% → 58% | 54.76d → 10d |
| 260 | Write NGS WFS Ass'ly Documentation as a KAON |  | 2010-03-08 A | 19% → 100% | 54.76d → none |
| 261 | **Low Order Wavefront Sensor Assembly** |  |  | 75% → 82% | 80.8d → 81.33d |
| 266 | **Mechanical detail of the LOWFS ass'ly** |  | 2010-01-28 A | 95% → 100% | 0d → none |
| 268 | Design the TT and the TTFA/TWFS sensor mechanics |  | 2009-12-31 A | 93% → 100% | 0d → none |
| 269 | Design the LOWFS cryostat |  | 2010-01-28 A | 93% → 100% | 0d → none |
| 271 | Identify LOWFS WFS motion control needs and specify solutions |  | 2009-11-02 A | 85% → 100% | 143.71d → none |
| 272 | Identify LOWFS design risks and mitigation |  | 2009-12-10 A | 43% → 100% | 91.63d → none |
| 275 | Write LOWFS Ass'ly Documentation as a KAON |  | 2010-01-25 A | 75% → 100% | 84.13d → none |
| 284 | **Alignment, Calibration & Diagnostics** |  |  | 72% → 58% |  |
| 285 | **Simulator** |  |  | 70% → 71% |  |
| 286 | Simulator Requirements & Interfaces |  | 2009-08-14 A | 75% → 100% | 200d → none |
| 287 | Simulator Optical Design |  | 2009-08-28 A | 75% → 100% | 190d → none |
| 288 | Simulator Mechanical Design |  |  | 70% → 35% |  |
| 290 | Simulator Assembly, Alignment & Test Plans |  |  | 50% → 40% |  |
| 291 | **System Alignment Tools** |  |  | 75% → 40% |  |
| 293 | Alignment Optical Design | 2009-10-26 A → 2009-10-26 | 2009-11-06 A → 2009-11-06 | 100% → 0% | none → 140d |
| 294 | Alignment Mechanical Design | 2009-11-09 A → 2009-11-09 |  | 50% → 0% |  |
| 295 | Alignment Electrical Design | 2009-11-23 A → 2009-11-23 |  | 25% → 0% |  |
| 297 | **Real-time Control** |  |  | 78% → 85% |  |
| 298 | **RTC Processor** |  |  | 75% → 83% |  |
| 299 | RTC Technical Management |  |  | 90% → 95% |  |
| 304 | **Algorithm Development Support** |  | 2009-07-23 A | 90% → 100% | 216d → none |
| 305 | MPP off-line simulator |  | 2009-07-23 A | 90% → 100% | 216d → none |
| 306 | Split tomography algorithm development |  | 2009-05-20 A | 90% → 100% | 262d → none |
| 307 | Woofer-tweeter algorithm development |  | 2009-05-27 A | 90% → 100% | 257d → none |
| 308 | **RTC Hardware** |  |  | 15% → 35% |  |
| 309 | Number and Function of RTC Processor Boards |  |  | 5% → 12% |  |
| 310 | Layout of Processors on Boards |  |  | 16% → 31% |  |
| 311 | Interconnect of processors on-board |  |  | 15% → 44% |  |
| 312 | Interconnection of boards to each other |  |  | 9% → 28% |  |
| 313 | Clock Distribution and Synchronization |  |  | 25% → 50% |  |
| 314 | Trade chip processing capacity with power dissipation capacity and manage generated heat |  |  | 8% → 30% |  |
| 315 | Hardware Interfaces to HOWFS and LOWFS cameras |  |  | 25% → 50% |  |
| 316 | Hardware Interfaces to DM drivers |  |  | 4% → 20% |  |
| 317 | Hardware Interface to Telemetry Data Capture System |  |  | 25% → 50% |  |
| 340 | **RTC Integration and Testing Plan** |  |  | 95% → 99% |  |
| 342 | **Software Test Plan** |  | 2009-12-14 A | 95% → 100% | 114d → none |
| 343 | Centroider / Wavefront Reconstructor test |  | 2009-12-04 A | 95% → 100% | 120d → none |
| 344 | Tomography Test |  | 2009-12-04 A | 95% → 100% | 120d → none |
| 345 | LOWFS processing test |  | 2009-11-27 A | 95% → 100% | 125d → none |
| 346 | DM processing test |  | 2009-12-07 A | 95% → 100% | 119d → none |
| 347 | Hybrid control loop test |  | 2009-12-14 A | 95% → 100% | 114d → none |
| 348 | External interfaces test |  | 2009-11-13 A | 95% → 100% | 135d → none |
| 349 | **Documentation** |  |  | 92% → 99% |  |
| 351 | Control Loops and Offloading Paths Diagram |  | 2009-06-30 A | 95% → 100% | 233d → none |
| 352 | Processor Engine (PE) design |  | 2009-10-30 A | 91% → 100% | 0d → none |
| 353 | RTC Algorithms Description |  | 2009-10-21 A | 95% → 100% | 152d → none |
| 354 | Control Processor (CP) design |  | 2009-10-27 A | 95% → 100% | 148d → none |
| 355 | Hardware Interface Documentation |  | 2009-12-31 A | 91% → 100% | 0d → none |
| 356 | Integration and Test Plan |  | 2010-01-15 A | 84% → 100% | 0d → none |

| ID | Task | Start | Finish | Complete | Total float |
| --- | --- | --- | --- | --- | --- |
| 380 | **AO System Lab I&T** |  |  | 43% → 10% |  |
| 381 | AO System Lab I&T Scope Definition |  |  | 75% → 50% |  |
| 382 | AO System Lab Facility Plan | 2009-11-16 A → 2009-11-16 |  | 25% → 0% |  |
| 383 | AO System Lab Integration Plan |  |  | 75% → 25% |  |
| 384 | AO System Lab Test Plan | 2009-11-16 A → 2009-11-16 |  | 25% → 0% |  |
| 385 | **Laser Guide Star Facility (LGSF) Design** |  |  | 94% → 96% |  |
| 386 | **Laser Enclosure (LE)** |  | 2009-12-04 A → 2009-12-04 | 100% → 69% | none → 120d |
| 389 | LE Assembly & Test Plans | 2009-11-23 A → 2009-11-23 | 2009-12-04 A → 2009-12-04 | 100% → 0% | none → 120d |
| 411 | **Laser Launch Facility (LLF)** |  |  | 86% → 98% |  |
| 413 | LLF Optical Design |  | 2009-08-28 A | 95% → 100% | 190d → none |
| 414 | LLF Launch Telescope Preliminary Design Contract (Resue KI?? MRI/NSF) |  | 2009-07-31 A | 65% → 100% | 210d → none |
| 416 | LLF Electrical Design |  |  | 85% → 95% |  |
| 417 | LLF Assembly, Alignment & Test Plans |  |  | 70% → 90% |  |
| 418 | **Laser Safety Systems** |  | 2009-09-30 A | 95% → 100% | 167d → none |
| 419 | **Personnel & Equipment Safety System** |  | 2009-09-30 A | 95% → 100% | 167d → none |
| 420 | Safety Requirements & Interfaces |  | 2009-08-14 A | 95% → 100% | 200d → none |
| 421 | Safety Algorithms, Diagrams & Dataflow |  | 2009-09-30 A | 95% → 100% | 167d → none |
| 422 | Safety Communication Protocols & Methods |  | 2009-09-30 A | 95% → 100% | 167d → none |
| 423 | Safety Performance Estimate |  | 2009-09-30 A | 95% → 100% | 167d → none |
| 424 | Safety Electronics, Shutter & Interlocks |  | 2009-09-30 A | 95% → 100% | 167d → none |
| 425 | Safety Test Plans |  | 2009-09-30 A | 95% → 100% | 167d → none |
| 426 | **Laser Traffic Control System (LTCS) Modifications (Doug can start earlier per JC)** |  | 2009-06-26 A | 95% → 100% | 235d → none |
| 427 | LTCS Requirements & Interfaces (LTCS mods. independent of other pieces laser facility design) |  | 2009-06-26 A | 95% → 100% | 235d → none |
| 428 | LTCS Algorithms, Diagrams & Dataflow |  | 2009-06-26 A | 95% → 100% | 235d → none |
| 429 | LTCS Communication Protocols & Methods |  | 2009-06-26 A | 95% → 100% | 235d → none |
| 430 | LTCS Performance Estimate |  | 2009-06-26 A | 95% → 100% | 235d → none |
| 431 | LTCS Test Plans |  | 2009-06-26 A | 95% → 100% | 235d → none |
| 432 | **Space Command Laser Clearing House (LCH)** |  | 2009-09-30 A | 95% → 100% | 167d → none |
| 433 | LCH Requirements & Interfaces |  | 2009-09-30 A | 95% → 100% | 167d → none |
| 434 | Laser System Lab I&T Plan |  | 2009-10-30 A → 2009-10-30 | 100% → 3% | none → 145d |
| 435 | **Control System Design** |  |  | 37% → 60% |  |
| 436 | **Controls electronics** |  | 2010-03-19 A | 51% → 100% | 45d → none |
| 437 | Controls Infrastructure |  | 2009-06-26 A | 75% → 100% | 135.25d → none |
| 438 | Camera control |  | 2009-07-10 A | 50% → 100% | 130.25d → none |
| 439 | DM & TT Control |  | 2009-08-26 A | 50% → 100% | 113.75d → none |
| 440 | Environmental and power control |  | 2009-09-25 A | 50% → 100% | 102.75d → none |
| 441 | RTC control |  | 2009-10-09 A | 50% → 100% | 97.75d → none |
| 442 | Laser control |  | 2009-10-23 A | 50% → 100% | 92.75d → none |
| 443 | Laser Safety System Control |  | 2009-11-06 A | 50% → 100% | 87.75d → none |
| 444 | Motion control |  | 2010-03-19 A | 50% → 100% | 45d → none |
| 445 | **Controls Software** |  |  | 59% → 57% |  |
| 446 | Controls Infrastructure |  | 2009-09-21 A → 2009-09-21 | 100% → 68% | none → 3d |
| 447 | **Common services** |  |  | 14% → 6% | 5d → 122.34d |
| 453 | Configuration | 2009-10-19 A → 2009-10-19 |  | 20% → 0% | 5d → 122.34d |
| 454 | Camera control |  |  | 67% → 37% | 0d → 119.56d |
| 455 | DM & TT Control |  |  | 67% → 37% | 0d → 116.78d |
| 456 | Environmental and power control |  |  | 67% → 37% | 0d → 114d |
| 457 | RTC control |  |  | 37% → 67% | 113d → 109d |
| 458 | Laser control |  | 2009-12-25 A → 2009-12-25 | 100% → 80% | none → 103d |
| 461 | Motion Control |  | 2010-02-26 A | 75% → 100% | 60.5d → none |
| 462 | **Acquisition, Guiding & Offload (AGO) Control** | 2009-10-01 A |  | 0% → 10% |  |
| 463 | Acquisition | 2009-10-01 A |  | 0% → 20% |  |
| 464 | Focus management | 2009-10-01 A |  | 0% → 20% |  |
| 465 | **Offloading** | 2009-11-02 A |  | 0% → 6% |  |
| 466 | Tip-Tilt offloading | 2009-11-02 A |  | 0% → 10% |  |
| 467 | Focus offloading | 2009-11-02 A |  | 0% → 10% |  |
| 469 | Rotation offloading | 2009-11-02 A |  | 0% → 10% |  |
| 602 | **Telescope & Summit Engineering Design** |  |  | 56% → 58% |  |
| 604 | **Infrastructure Modifications for AO** |  |  | 38% → 22% |  |
| 607 | AO Infrastructure Electrical Modifications |  |  | 90% → 50% |  |
| 608 | AO Infrastructure Glycol Cooling Modifications |  |  | 90% → 50% |  |
| 611 | **Infrastructure modifications for LGSF** |  | 2010-02-05 A → 2010-02-05 | 100% → 87% | none → 75d |
| 616 | LGSF Infrastructure Implementation & Test Plans | 2009-09-01 A → 2009-09-01 | 2009-10-02 A → 2009-10-02 | 100% → 0% | none → 165d |
| 617 | **Interferometer Modifications** |  |  | 13% → 95% |  |
| 618 | Optical Design of Post Field Selector Optics |  | 2009-08-25 A | 25% → 100% | 193d → none |
| 619 | Evaluation of Optical Design Impact on Interferometer | 2009-07-01 A |  | 0% → 90% |  |
| 620 | **Telescope Integration & Test** |  |  | 15% → 23% |  |
| 626 | **AO System Install + I&T** | 2009-11-02 A |  | 0% → 4% |  |
| 630 | AO System Integration Plan | 2009-11-02 A |  | 0% → 20% |  |
| 632 | **Laser System Install + I&T** |  |  | 27% → 50% |  |

| ID | Task | Start | Complete |
| --- | --- | --- | --- |
| 634 | LGSF System Test Plan | 2009-11-02 A | 0% → 50% |

## Version 14 (saved 2010-07-22, file NGAO_Design_B2C_Replan_v8_tracked_Jun10.mpp)

Last finish stays 2010-05-21. Complete tasks 191 → 209.

Changed:

| ID | Task | Start | Finish | Complete | Total float | Other |
| --- | --- | --- | --- | --- | --- | --- |
| 1 | **NGAO Design** |  |  | 47% → 54% |  |  |
| 4 | **Preliminary Design** |  |  | 48% → 55% |  |  |
| 6 | **PD Phase Management** |  |  | 75% → 79% |  |  |
| 21 | **Project Management & Meetings** |  |  | 71% → 73% |  |  |
| 22 | **Senior Management Committee** |  |  | 90% → 95% |  |  |
| 23 | Senior Management Activities |  |  | 90% → 95% |  |  |
| 24 | Senior Management Telecons |  |  | 90% → 95% |  |  |
| 30 | **Tracking & Reporting** |  |  | 79% → 83% |  |  |
| 31 | **Monthly Status Reports** |  |  | 90% → 95% |  |  |
| 32 | Monthly Team Status Reports |  |  | 90% → 95% |  |  |
| 33 | Monthly Project Reports (TSIP, Directors) |  |  | 90% → 95% |  |  |
| 34 | TSIP Project Report Telecons |  |  | 90% → 95% |  |  |
| 49 | **Programmatic Risk Assessment & Mitigation** |  |  | 61% → 66% |  |  |
| 52 | **Risk Mitigation** |  |  | 60% → 65% |  |  |
| 54 | Funding |  |  | 49% → 59% |  |  |
| 55 | **Preliminary Design Review** |  |  | 43% → 91% |  |  |
| 56 | Define Success Criteria for all Reviews |  |  | 37% → 47% |  |  |
| 59 | Review Package Distributed |  | 2010-04-02 A | 90% → 100% | 35d → none |  |
| 61 | Reviewer Comments Addressed | 2010-04-19 A | 2010-04-23 A | 0% → 100% | 20d → none |  |
| 62 | PDR Presentation Preparation |  | 2010-04-21 A | 10% → 100% | 22d → none |  |
| 63 | Preliminary Design Review | 2010-04-28 A | 2010-04-29 A | 0% → 100% | 16d → none |  |
| 65 | Response to Reviewer Report | 2010-05-17 A | 2010-05-21 A | 0% → 100% | 0d → none |  |
| 66 | **Project Support** |  |  | 90% → 95% |  |  |
| 67 | Administrative/Contract Support |  |  | 90% → 95% |  |  |
| 68 | Shared Infrastructure |  |  | 90% → 95% |  |  |
| 69 | **Systems Engineering** |  |  | 56% → 73% |  |  |
| 70 | **Science Case Requirements** |  |  | 47% → 77% |  |  |
| 71 | **Science Case Requirements** |  |  | 34% → 57% |  |  |
| 72 | **Science Simulations** |  |  | 35% → 46% |  |  |
| 73 | High-z Galaxies |  | 2010-03-15 A | 84% → 100% | 49d → none |  |
| 74 | BH Measurements in Nearby AGN |  |  | 50% → 80% |  |  |
| 78 | Resolved Stellar Populations |  |  | 25% → 35% |  |  |
| 81 | **Extend SCRD Discussion of Science Drivers** | 2010-01-05 A | 2010-02-26 A | 0% → 100% | 60d → none |  |
| 82 | Nearby AGNs | 2010-01-05 A | 2010-02-26 A | 0% → 100% | 60d → none |  |
| 83 | Gravitational Lensing | 2010-01-11 A | 2010-02-26 A | 0% → 100% | 60d → none |  |
| 84 | Backup Science (changed to other SCRD sections) | 2010-02-01 A | 2010-02-26 A | 0% → 100% | 60d → none | was named Backup Science |
| 85 | Science Requirements Summary Matrix |  | 2010-03-16 A | 99% → 100% | 48d → none |  |
| 87 | SEMP Input | 2009-12-07 A | 2010-03-19 A | 0% → 100% | 45d → none |  |
| 88 | **Science Observing Planning & Execution** |  | 2009-06-30 A | 65% → 100% | 233d → none |  |
| 89 | Develop Observing Scenarios for all Key Science Drivers |  | 2009-06-30 A | 65% → 100% | 233d → none |  |
| 90 | **Science Performance Input** |  |  | 72% → 95% |  |  |
| 92 | Input to User Interfaces, Planning & Observing Tools | 2010-01-05 A |  | 0% → 50% |  |  |
| 93 | Input to Preliminary Operations Concept Document |  | 2010-02-26 A | 70% → 100% | 60d → none |  |
| 94 | **Science Competitiveness** |  | 2010-03-19 A | 39% → 100% | 45d → none |  |
| 95 | Update List of Science Goals for Other Facilities |  | 2010-03-19 A | 33% → 100% | 45d → none |  |
| 96 | Evaluate NGAO Potential to Compliment Other Facilities |  | 2010-03-19 A | 45% → 100% | 45d → none |  |
| 97 | **User Community Liaison** |  |  | 56% → 84% |  |  |
| 98 | **SSC & Keck Science Meeting** |  | 2010-03-30 A | 48% → 100% | 38d → none |  |
| 99 | Prepare & Give Presentations |  | 2010-03-30 A | 36% → 100% | 38d → none |  |
| 100 | Obtain & Document Feedback |  | 2010-03-30 A | 60% → 100% | 38d → none |  |
| 102 | Progress Reporting |  | 2010-04-30 A | 90% → 100% | 15d → none |  |
| 103 | **Science Advisory Team Meetings** |  |  | 47% → 59% |  |  |
| 104 | Prepare Minutes, Presentations & KAONs |  |  | 70% → 75% |  |  |
| 105 | Evaluate Science Impact of Proposed Changes |  |  | 20% → 40% |  |  |
| 106 | Science Postdoc Research Time |  | 2010-04-30 A | 50% → 100% | 15d → none |  |
| 120 | **Systems Engineering Analysis** |  |  | 67% → 69% |  |  |
| 121 | **Performance Budgets** |  |  | 88% → 92% | 109.33d → 100.58d |  |
| 145 | **WFE/EE Budget Tool** |  | 2009-12-21 A | 90% → 100% | 109.33d → none |  |
| 149 | Other WFE/EE Budget Tool Maintenance |  | 2009-12-21 A | 85% → 100% | 109.33d → none |  |
| 228 | **AO System Design** |  |  | 81% → 85% |  |  |
| 230 | **Opto-Mechanical** |  |  | 85% → 86% |  |  |
| 251 | **NGS Wavefront Sensor Assembly** |  |  | 94% → 96% |  |  |
| 258 | Identify NGS WFS design risks and mitigation |  | 2010-02-10 A | 58% → 100% | 10d → none |  |
| 297 | **Real-time Control** |  |  | 85% → 91% |  |  |
| 298 | **RTC Processor** |  |  | 83% → 89% |  |  |
| 308 | **RTC Hardware** |  |  | 35% → 65% |  |  |
| 309 | Number and Function of RTC Processor Boards |  |  | 12% → 40% |  |  |
| 310 | Layout of Processors on Boards |  |  | 31% → 62% |  |  |
| 311 | Interconnect of processors on-board |  |  | 44% → 72% |  |  |
| 312 | Interconnection of boards to each other |  |  | 28% → 64% |  |  |

| ID | Task | Start | Finish | Complete | Total float |
| --- | --- | --- | --- | --- | --- |
| 313 | Clock Distribution and Synchronization |  |  | 50% → 75% |  |
| 314 | Trade chip processing capacity with power dissipation capacity and manage generated heat |  |  | 30% → 65% |  |
| 315 | Hardware Interfaces to HOWFS and LOWFS cameras |  |  | 50% → 75% |  |
| 316 | Hardware Interfaces to DM drivers |  |  | 20% → 60% |  |
| 317 | Hardware Interface to Telemetry Data Capture System |  |  | 50% → 75% |  |
| 340 | **RTC Integration and Testing Plan** |  | 2009-12-31 A | 99% → 100% | 101d → none |
| 341 | Hardware Test Plan |  | 2009-12-31 A | 94% → 100% | 101d → none |
| 349 | **Documentation** |  |  | 99% → 92% |  |
| 350 | Summary of Documents |  | 2009-05-04 A → 2009-05-04 | 100% → 95% | none → 274d |
| 351 | Control Loops and Offloading Paths Diagram |  | 2009-06-30 A → 2009-06-30 | 100% → 95% | none → 233d |
| 352 | Processor Engine (PE) design |  | 2009-10-30 A → 2009-10-30 | 100% → 91% | none → 145d |
| 353 | RTC Algorithms Description |  | 2009-10-21 A → 2009-10-21 | 100% → 95% | none → 152d |
| 354 | Control Processor (CP) design |  | 2009-10-27 A → 2009-10-27 | 100% → 95% | none → 148d |
| 355 | Hardware Interface Documentation |  | 2009-12-31 A → 2009-12-31 | 100% → 91% | none → 101d |
| 356 | Integration and Test Plan |  | 2010-01-15 A → 2010-01-15 | 100% → 84% | none → 90d |
| 435 | **Control System Design** |  |  | 60% → 78% |  |
| 462 | **Acquisition, Guiding & Offload (AGO) Control** |  |  | 10% → 64% |  |
| 463 | Acquisition |  |  | 20% → 75% |  |
| 464 | Focus management |  |  | 20% → 75% |  |
| 465 | **Offloading** |  |  | 6% → 60% |  |
| 466 | Tip-Tilt offloading |  |  | 10% → 75% |  |
| 467 | Focus offloading |  |  | 10% → 75% |  |
| 468 | Coma offloading | 2009-11-02 A |  | 0% → 75% |  |
| 469 | Rotation offloading |  |  | 10% → 75% |  |
| 471 | **Science Operations Tools Design** |  |  | 6% → 9% |  |
| 595 | **Data Server** | 2009-10-01 A |  | 0% → 99% |  |
| 596 | Data Server: Architecture | 2009-10-01 A | 2010-02-26 A | 0% → 100% | 60d → none |
| 597 | Data Server: HW & SW Specification & Selection | 2009-10-01 A | 2010-02-26 A | 0% → 100% | 60d → none |
| 601 | Data Server: Summary Report | 2009-10-01 A | 2010-02-26 A | 0% → 100% | 60d → none |

## Version 15 (saved 2010-08-09, file NGAO_Design_B2C_Replan_v8_tracked_Jul10.mpp)

Last finish stays 2010-05-21. Complete tasks 209 → 212.

Changed:

| ID | Task | Finish | Complete | Total float |
| --- | --- | --- | --- | --- |
| 1 | **NGAO Design** |  | 54% → 55% |  |
| 4 | **Preliminary Design** |  | 55% → 56% |  |
| 6 | **PD Phase Management** |  | 79% → 81% |  |
| 21 | **Project Management & Meetings** |  | 73% → 75% |  |
| 22 | **Senior Management Committee** |  | 95% → 98% |  |
| 23 | Senior Management Activities | 2010-04-30 A | 95% → 100% | 15d → none |
| 25 | **Team Meetings** |  | 95% → 98% |  |
| 26 | Meeting Participation |  | 95% → 98% |  |
| 30 | **Tracking & Reporting** |  | 83% → 86% |  |
| 31 | **Monthly Status Reports** |  | 95% → 98% |  |
| 32 | Monthly Team Status Reports |  | 95% → 98% |  |
| 33 | Monthly Project Reports (TSIP, Directors) |  | 95% → 98% |  |
| 34 | TSIP Project Report Telecons |  | 95% → 98% |  |
| 49 | **Programmatic Risk Assessment & Mitigation** |  | 66% → 68% |  |
| 52 | **Risk Mitigation** |  | 65% → 68% |  |
| 54 | Funding |  | 59% → 64% |  |
| 66 | **Project Support** |  | 95% → 98% |  |
| 67 | Administrative/Contract Support |  | 95% → 98% |  |
| 68 | Shared Infrastructure |  | 95% → 98% |  |
| 69 | **Systems Engineering** |  | 73% → 77% |  |
| 70 | **Science Case Requirements** |  | 77% → 82% |  |
| 71 | **Science Case Requirements** |  | 57% → 60% |  |
| 72 | **Science Simulations** |  | 46% → 51% |  |
| 74 | BH Measurements in Nearby AGN | 2010-02-15 A | 80% → 100% | 69d → none |
| 97 | **User Community Liaison** | 2010-04-30 A | 84% → 100% | 15d → none |
| 101 | Proposal Writing | 2010-03-30 A | 33% → 100% | 38d → none |
| 103 | **Science Advisory Team Meetings** |  | 59% → 61% |  |
| 105 | Evaluate Science Impact of Proposed Changes |  | 40% → 45% |  |
| 120 | **Systems Engineering Analysis** |  | 69% → 71% |  |
| 158 | **Modeling & Analysis** |  | 43% → 45% |  |
| 159 | Sys Eng Support for Proposal Efforts |  | 90% → 95% |  |
| 173 | PSF Calibration |  | 50% → 70% |  |
