# NGAO Design v7

How a schedule from MS Project changed from version to version. A marks actual dates.

## Version 1 (saved 2008-06-18, file NGAO_Design_v14_tracked_May08.mpp)

| ID | WBS | Task | Duration | Start | Finish | Complete | Total float | Constraint |
| --- | --- | --- | --- | --- | --- | --- | --- | --- |
| 1 | 1 | **NGAO Design** | 1166d? | 2005-10-03 A | 2010-03-22 | 1% | 0d |  |
| 2 |  | Proposal | 195d? | 2005-10-03 | 2006-06-30 |  | 971d | finish no earlier than 2006-06-30 |
| 3 |  | System Design | 413d? | 2006-10-02 | 2008-04-30 |  | 493d | finish no earlier than 2008-04-30 |
| 4 | 1.3 | **Preliminary Design** | 494d? | 2008-04-30 A | 2010-03-22 | 1% | 0d |  |
| 5 |  | Reserved | 1d? | 2008-05-01 | 2008-05-01 |  | 492d | start no earlier than 2008-05-01 |
| 6 | 1.3.2 | **PD Phase Management** | 494d? | 2008-04-30 A | 2010-03-22 | 3% | 0d |  |
| 7 | 1.3.2.1 | **Planning** | 456d? | 2008-05-02 A | 2010-01-29 | 8% | 36d |  |
| 8 | 1.3.2.1.1 | **Replans (PD phase)** | 286d? | 2008-05-02 A | 2009-06-05 | 12% | 206d |  |
| 9 |  | Replan based on SDR | 6d? | 2008-05-02 A | 2008-05-09 | 50% | 486d | start no earlier than 2008-05-02 |
| 10 |  | Replan 1 | 10d? | 2008-10-27 | 2008-11-07 |  | 356d | finish no earlier than 2008-11-07 |
| 11 |  | Replan 2 | 10d? | 2009-05-25 | 2009-06-05 |  | 206d | finish no earlier than 2009-06-05 |
| 12 | 1.3.2.1.2 | **WMKO FY Plans** | 280d? | 2008-05-05 A | 2009-05-29 | 19% | 211d |  |
| 13 |  | Support WMKO FY09 Planning | 20d? | 2008-05-05 A | 2008-05-30 A | 100% |  | start no earlier than 2008-05-05 |
| 14 |  | Support WMKO FY10 Planning | 85d? | 2009-02-02 | 2009-05-29 |  | 211d | start no earlier than 2009-02-02 |
| 15 | 1.3.2.1.3 | **Systems Engineering Management Plan** | 218d? | 2009-04-01 | 2010-01-29 |  | 36d |  |
| 16 | 1.3.2.1.3.1 | **Project Plan** | 50d? | 2009-11-02 | 2010-01-08 |  | 51d |  |
| 17 |  | PBS, WBS & Task Definition | 15d? | 2009-11-02 | 2009-11-20 |  | 86d | start no earlier than 2009-11-02 |
| 18 |  | Cost Estimation | 20d? | 2009-11-23 | 2009-12-18 |  | 66d | start no earlier than 2009-11-23 |
| 19 |  | Full Schedule (MS Project Plan) | 25d? | 2009-12-07 | 2010-01-08 |  | 51d | start no earlier than 2009-12-07 |
| 20 | 1.3.2.1.3.2 | **Detailed Design Phase Plan** | 177d? | 2009-04-01 | 2009-12-03 |  | 77d |  |
| 21 |  | Detailed Design Plan v1 (FY10 planning) | 33d? | 2009-04-01 | 2009-05-15 |  | 221d | finish no earlier than 2009-05-15 |
| 22 |  | Detailed Design Plan v2 (TSIP proposal) | 18d? | 2009-07-15 | 2009-08-07 |  | 161d | start no earlier than 2009-07-15 |
| 23 |  | Detailed Design Plan Final Version | 19d? | 2009-11-09 | 2009-12-03 |  | 77d | start no earlier than 2009-11-09 |
| 24 |  | SEMP Document | 15d? | 2010-01-11 | 2010-01-29 |  | 36d | start no earlier than 2010-01-11 |
| 25 | 1.3.2.2 | **Project Management & Meetings** | 477d? | 2008-05-01 A | 2010-02-26 | 3% | 16d |  |
| 26 | 1.3.2.2.1 | **Executive Committee** | 477d? | 2008-05-01 A | 2010-02-26 | 5% | 16d |  |
| 27 |  | Executive Committee Management Activities | 477d? | 2008-05-01 A | 2010-02-26 | 5% | 16d | finish no earlier than 2010-02-26 |
| 28 |  | Executive Committee Telecons | 477d? | 2008-05-01 A | 2010-02-26 | 5% | 16d | finish no earlier than 2010-02-26 |
| 29 | 1.3.2.2.2 | **Team Meetings** | 477d? | 2008-05-01 | 2010-02-26 |  | 16d |  |
| 30 |  | Meeting Participation | 477d? | 2008-05-01 | 2010-02-26 |  | 16d | start no earlier than 2008-05-01 |
| 31 |  | Team Meeting #1 (CIT - 1 day) | 0d | 2008-05-01 | 2008-05-01 |  | 493d | start no earlier than 2008-05-01 |
| 32 |  | Team Meeting #2 (telecon) | 0d | 2008-06-13 | 2008-06-13 |  | 462d | start no earlier than 2008-06-13 |
| 33 |  | Team Meeting #3 (telecon) | 0d? | 2008-07-11 | 2008-07-11 |  | 442d | start no earlier than 2008-07-11 |
| 34 |  | Team Meeting #4 (telecon) | 0d | 2008-08-15 | 2008-08-15 |  | 417d | start no earlier than 2008-08-15 |
| 35 |  | Team Meeting #5 (UC - 3 days) | 0d? | 2008-09-18 | 2008-09-18 |  | 392d | finish no earlier than 2008-09-18 |
| 36 |  | Team Meeting #6 (telecon) | 0d | 2008-10-17 | 2008-10-17 |  | 372d | start no earlier than 2008-10-17 |
| 37 |  | Team Meeting #7 (telecon) | 0d | 2008-11-14 | 2008-11-14 |  | 352d | start no earlier than 2008-11-14 |
| 38 |  | Team Meeting #8 (telecon) | 0d | 2008-12-12 | 2008-12-12 |  | 332d | start no earlier than 2008-12-12 |
| 39 |  | Team Meeting #9 (telecon) | 0d | 2009-01-16 | 2009-01-16 |  | 306d | finish no earlier than 2009-01-16 |
| 40 |  | Team Meeting #10 (WMKO - 4 days) | 0d | 2009-02-10 | 2009-02-10 |  | 290d | start no earlier than 2009-02-10 |
| 41 |  | Team Meeting #11 (telecon) | 0d | 2009-03-13 | 2009-03-13 |  | 267d | start no earlier than 2009-03-13 |
| 42 |  | Team Meeting #12 (telecon) | 0d | 2009-04-17 | 2009-04-17 |  | 242d | start no earlier than 2009-04-17 |
| 43 |  | Team Meeting #13 (telecon) | 0d | 2009-05-15 | 2009-05-15 |  | 221d | finish no earlier than 2009-05-15 |
| 44 |  | Team Meeting #14 (telecon) | 0d | 2009-06-12 | 2009-06-12 |  | 201d | finish no earlier than 2009-06-12 |
| 45 |  | Team Meeting #15 (telecon) | 0d | 2009-07-17 | 2009-07-17 |  | 177d | start no earlier than 2009-07-17 |
| 46 |  | Team Meeting #16 (CIT - 3 days)) | 0d | 2009-08-20 | 2009-08-20 |  | 152d | finish no earlier than 2009-08-20 |
| 47 |  | Team Meeting #17 (telecon) | 0d | 2009-09-18 | 2009-09-18 |  | 132d | start no earlier than 2009-09-18 |
| 48 |  | Team Meeting #18 (telecon) | 0d | 2009-10-16 | 2009-10-16 |  | 112d | start no earlier than 2009-10-16 |
| 49 |  | Team Meeting #19 (telecon) | 0d | 2009-11-13 | 2009-11-13 |  | 92d | start no earlier than 2009-11-13 |
| 50 |  | Team Meeting #20 (telecon) | 0d | 2009-12-11 | 2009-12-11 |  | 72d | start no earlier than 2009-12-11 |
| 51 |  | Team Meeting #21 (telecon) | 0d | 2010-01-15 | 2010-01-15 |  | 47d | start no earlier than 2010-01-15 |
| 52 | 1.3.2.2.3 | **Director Telecons** | 390d | 2008-05-09 | 2009-11-06 |  | 97d |  |
| 53 |  | Director Telecon #1 | 0d | 2008-05-09 | 2008-05-09 |  | 487d | start no earlier than 2008-05-09 |
| 54 |  | Director Telecon #2 | 0d | 2008-11-07 | 2008-11-07 |  | 357d | start no earlier than 2008-11-07 |
| 55 |  | Director Telecon #3 | 0d | 2009-05-08 | 2009-05-08 |  | 227d | start no earlier than 2009-05-08 |
| 56 |  | Director Telecon #4 | 0d | 2009-11-06 | 2009-11-06 |  | 97d | start no earlier than 2009-11-06 |
| 57 | 1.3.2.3 | **Tracking & Reporting** | 478d? | 2008-04-30 A | 2010-02-26 |  | 16d |  |
| 58 | 1.3.2.3.1 | **Monthly Status Reports** | 477d? | 2008-05-01 | 2010-02-26 |  | 16d |  |
| 59 |  | Monthly Team Status Reports | 477d? | 2008-05-01 | 2010-02-26 |  | 16d | start no earlier than 2008-05-01 |
| 60 |  | Monthly Project Reports (TSIP, Directors) | 467d? | 2008-05-15 | 2010-02-26 |  | 16d | start no earlier than 2008-05-15 |
| 61 |  | TSIP Project Report Telecons | 464d? | 2008-05-20 | 2010-02-26 |  | 16d | start no earlier than 2008-05-20 |
| 62 | 1.3.2.3.2 | **SSC Meetings** | 459.88d? | 2008-04-30 | 2010-02-02 |  | 34.12d |  |
| 63 |  | SSC Meeting (CIT) - SDR report | 0d | 2008-04-30 | 2008-04-30 |  | 494d | start no earlier than 2008-04-30 |
| 64 |  | SSC Meeting (Keck) | 1.12d | 2008-06-18 | 2008-06-19 |  | 457.88d | start no earlier than 2008-06-18 |
| 65 |  | SSC Meeting (UCSC) | 1.12d | 2008-11-03 | 2008-11-04 |  | 359.88d | start no earlier than 2008-11-03 |
| 66 |  | SSC Meeting (Keck) | 1.12d | 2009-02-19 | 2009-02-20 |  | 281.88d | start no earlier than 2009-02-19 |
| 67 |  | SSC Meeting (CIT) | 1.12d | 2009-04-29 | 2009-04-30 |  | 232.88d | start no earlier than 2009-04-29 |
| 68 |  | SSC Meeting (Keck) | 1.12d | 2009-06-17 | 2009-06-18 |  | 197.88d | start no earlier than 2009-06-17 |
| 69 |  | SSC Meeting (UCSC) | 1.12d | 2009-11-03 | 2009-11-04 |  | 98.88d | start no earlier than 2009-11-03 |
| 70 |  | SSC Meeting (Keck) | 1.88d? | 2010-02-01 | 2010-02-02 |  | 34.12d | start no earlier than 2010-02-01 |

| ID | WBS | Task | Duration | Start | Finish | Complete | Total float | Constraint |
| --- | --- | --- | --- | --- | --- | --- | --- | --- |
| 71 | 1.3.2.3.3 | **Other Presentations** | 350d? | 2008-06-02 A | 2009-10-02 | 3% | 121d |  |
| 72 |  | SPIE AO Conference Presentations/Papers | 15d? | 2008-06-02 A | 2008-06-20 | 50% | 456d | start no earlier than 2008-06-02 |
| 73 |  | SPIE AO Conference (Marseille) | 5d? | 2008-06-23 | 2008-06-28 |  | 451d | finish no earlier than 2008-06-28 |
| 74 |  | Keck Science Meeting 08 | 3d | 2008-09-18 | 2008-09-22 |  | 390d | start no earlier than 2008-09-18 |
| 75 |  | Keck Science Meeting 09 | 3d | 2009-09-17 | 2009-09-21 |  | 130d | start no earlier than 2009-09-17 |
| 76 |  | Other | 195d? | 2009-01-05 | 2009-10-02 |  | 121d | finish no earlier than 2009-10-02 |
| 77 | 1.3.2.4 | **Proposals** | 348d? | 2008-06-02 | 2009-09-30 |  | 123d |  |
| 78 |  | Advancement Support | 348d? | 2008-06-02 | 2009-09-30 |  | 123d | start no earlier than 2008-06-02 |
| 79 |  | TSIP Proposal for DDR | 25d? | 2009-07-28 | 2009-08-31 |  | 145d | finish no earlier than 2009-08-31 |
| 80 |  | Other Proposal | 20d? | 2009-09-03 | 2009-09-30 |  | 123d | finish no earlier than 2009-09-30 |
| 81 | 1.3.2.5 | **Programmatic Risk Assessment & Mitigation** | 355d? | 2008-05-19 A | 2009-09-25 | 4% | 126d |  |
| 82 | 1.3.2.5.1 | **Risk Assessment** | 213.25d? | 2008-09-04 | 2009-06-30 |  | 189d |  |
| 83 |  | Programmatic Risk Assessment v1 | 6.25d? | 2008-09-04 | 2008-09-12 |  | 396d | finish no earlier than 2008-09-12 |
| 84 |  | Programmatic Risk Assessment v2 | 2d? | 2009-06-29 | 2009-06-30 |  | 189d | finish no earlier than 2009-06-30 |
| 85 | 1.3.2.5.2 | **Risk Mitigation** | 355d? | 2008-05-19 A | 2009-09-25 | 4% | 126d |  |
| 86 |  | Laser Procurement | 350d? | 2008-05-26 A | 2009-09-25 | 5% | 126d | finish no earlier than 2009-09-25 |
| 87 |  | Science Instruments | 35d? | 2008-10-06 | 2008-11-21 |  | 346d | finish no earlier than 2008-11-21 |
| 88 |  | Funding | 95d? | 2008-05-19 | 2008-09-26 |  | 386d | finish no earlier than 2008-09-26 |
| 89 | 1.3.2.6 | **Preliminary Design Review** | 404.33d? | 2008-09-02 | 2010-03-22 |  | 0d |  |
| 90 |  | Define Success Criteria for all Reviews | 8.33d? | 2008-09-02 | 2008-09-12 |  | 396d | finish no earlier than 2008-09-12 |
| 91 |  | Review Setup (Date, Participants, Charter) | 5d? | 2009-09-07 | 2009-09-11 |  | 136d | start no earlier than 2009-09-07 |
| 92 |  | Preliminary Design Report | 12d? | 2010-01-11 | 2010-01-26 |  | 39d | start no earlier than 2010-01-11 |
| 93 |  | Review Package Distributed | 1d? | 2010-01-27 | 2010-01-27 |  | 38d | start no earlier than 2010-01-27 |
| 94 |  | Reviewer Comments Received | 0d | 2010-02-10 | 2010-02-10 |  | 29d | start no earlier than 2010-02-10 |
| 95 |  | Reviewer Comments Addressed | 5d? | 2010-02-11 | 2010-02-17 |  | 23d | start no earlier than 2010-02-11 |
| 96 |  | PDR Presentation Preparation | 15d? | 2010-02-01 | 2010-02-19 |  | 21d | start no earlier than 2010-02-01 |
| 97 |  | Preliminary Design Review | 1d? | 2010-02-22 | 2010-02-22 |  | 20d | start no earlier than 2010-02-22 |
| 98 |  | Reviewer Report Received | 0d | 2010-03-15 | 2010-03-15 |  | 6d | start no earlier than 2010-03-15 |
| 99 |  | Response to Reviewer Report | 5d? | 2010-03-16 | 2010-03-22 |  | 0d | start no earlier than 2010-03-16 |
| 100 | 1.3.2.7 | **Project Support** | 477d? | 2008-05-01 A | 2010-02-26 | 4% | 16d |  |
| 101 |  | Administrative/Contract Support | 477d? | 2008-05-01 A | 2010-02-26 | 7% | 0d | start no earlier than 2008-05-01 |
| 102 |  | Shared Infrastructure | 430d? | 2008-07-07 | 2010-02-26 |  | 16d | finish no earlier than 2010-02-26 |
| 103 |  | Research Time | 477d? | 2008-05-01 A | 2010-02-26 | 5% | 16d | start no earlier than 2008-05-01 |
| 104 | 1.3.3 | **Systems Engineering** | 457d? | 2008-05-01 A | 2010-01-29 |  | 36d |  |
| 105 | 1.3.3.1 | **Science Case Requirements** | 457d? | 2008-05-01 | 2010-01-29 |  | 36d |  |
| 106 | 1.3.3.1.1 | **Science Case Requirements** | 447d? | 2008-05-01 | 2010-01-15 |  | 46d |  |
| 107 | 1.3.3.1.1.1 | **Requirements for new Science Drivers** | 183d? | 2008-05-01 | 2009-01-12 |  | 310d |  |
| 108 |  | Astrometry Science in Sparse Fields | 71d? | 2008-10-06 | 2009-01-12 |  | 310d | finish no earlier than 2009-01-12 |
| 109 |  | Resolved Stellar Populations in Crowded Fields | 61d? | 2008-07-14 | 2008-10-06 |  | 380d | finish no earlier than 2008-10-06 |
| 110 |  | Debris Disks & Young Stellar Objects | 61d? | 2008-07-14 | 2008-10-06 |  | 380d | finish no earlier than 2008-10-06 |
| 111 |  | QSO Host Galaxies | 52d? | 2008-05-01 | 2008-07-11 |  | 441d | finish no earlier than 2008-07-11 |
| 112 | 1.3.3.1.1.2 | **Extend SCRD Discussion of Science Drivers** | 168d? | 2008-05-01 | 2008-12-22 |  | 325d |  |
| 113 |  | Nearby AGNs | 52d? | 2008-05-01 | 2008-07-11 |  | 441d | finish no earlier than 2008-07-11 |
| 114 |  | Gravitational Lensing | 52d? | 2008-05-01 | 2008-07-11 |  | 441d | finish no earlier than 2008-07-11 |
| 115 |  | Backup Science | 52d? | 2008-05-01 | 2008-07-11 |  | 441d | finish no earlier than 2008-07-11 |
| 116 |  | Ice Giant Planets | 61d? | 2008-07-14 | 2008-10-06 |  | 380d | finish no earlier than 2008-10-06 |
| 117 |  | GR at Galactic Center | 61d? | 2008-07-14 | 2008-10-06 |  | 380d | finish no earlier than 2008-10-06 |
| 118 |  | Extrasolar Planets | 52d? | 2008-10-06 | 2008-12-16 |  | 329d | start no earlier than 2008-10-06 |
| 119 |  | Asteroids | 52d? | 2008-05-01 | 2008-07-11 |  | 441d | finish no earlier than 2008-07-11 |
| 120 |  | QSO Host Galaxies | 116d? | 2008-07-14 | 2008-12-22 |  | 325d | finish no earlier than 2008-12-22 |
| 121 |  | Backup Science - NGS & Acquisition Camera | 61d? | 2008-07-14 | 2008-10-06 |  | 380d | finish no earlier than 2008-10-06 |
| 122 | 1.3.3.1.1.3 | **Characterize PSF Stability, Knowledge & Subtraction Requirements** | 226d? | 2008-10-06 | 2009-08-17 |  | 155d |  |
| 123 |  | Nearby AGNs | 226d? | 2008-10-06 | 2009-08-17 |  | 155d | finish no earlier than 2009-08-17 |
| 124 |  | Galactic Center Astrometry | 97d? | 2008-10-06 | 2009-02-17 |  | 284d | start no earlier than 2008-10-06 |
| 125 |  | Extrasolar Planets | 96d? | 2009-01-12 | 2009-05-25 |  | 215d | start no earlier than 2009-01-12 |
| 126 |  | Minor Planet Multiplicity | 36d? | 2008-10-20 | 2008-12-08 |  | 335d | start no earlier than 2008-10-20 |
| 127 |  | QSO Host Galaxies | 81d? | 2008-10-06 | 2009-01-26 |  | 300d | finish no earlier than 2009-01-26 |
| 128 |  | Characterize Sensitivity & Background Requirements | 96d? | 2009-01-12 | 2009-05-25 |  | 215d | finish no earlier than 2009-05-25 |
| 129 |  | Science Requirements Summary Matrix | 165d? | 2009-05-25 | 2010-01-08 |  | 51d | finish no earlier than 2010-01-08 |
| 130 |  | SEMP Input | 75d? | 2009-10-05 | 2010-01-15 |  | 46d | start no earlier than 2009-10-05 |
| 131 | 1.3.3.1.2 | **Science Observing Planning & Execution** | 379d? | 2008-08-04 | 2010-01-14 |  | 47d |  |
| 132 |  | Key Science Driver Observing Scenarios | 120d? | 2008-08-04 | 2009-01-16 |  | 306d | start no earlier than 2008-08-04 |
| 133 |  | Design Reference Missions | 119d? | 2009-08-03 | 2010-01-14 |  | 47d | start no earlier than 2009-08-03 |
| 134 | 1.3.3.1.3 | **Science Performance Input** | 315d? | 2008-10-06 | 2009-12-18 |  | 66d |  |
| 135 |  | Define Science Driver Parameters for Performance Budgets | 12d? | 2008-10-13 | 2008-10-28 |  | 364d | start no earlier than 2008-10-13 |
| 136 |  | Input to User Interfaces, Planning & Observing Tools | 300d? | 2008-10-06 | 2009-11-27 |  | 81d | finish no earlier than 2009-11-27 |
| 137 |  | Input to Preliminary Operations Concept Document | 275d? | 2008-12-01 | 2009-12-18 |  | 66d | finish no earlier than 2009-12-18 |
| 138 | 1.3.3.1.4 | **Science Competitiveness** | 380d? | 2008-07-07 | 2009-12-18 |  | 66d |  |
| 139 |  | Update List of Science Goals for Other Facilities | 380d? | 2008-07-07 | 2009-12-18 |  | 66d | finish no earlier than 2009-12-18 |
| 140 |  | Evaluate NGAO Potential to Compliment Other Facilities | 380d? | 2008-07-07 | 2009-12-18 |  | 66d | finish no earlier than 2009-12-18 |

| ID | WBS | Task | Duration | Start | Finish | Predecessors | Complete | Total float | Constraint |
| --- | --- | --- | --- | --- | --- | --- | --- | --- | --- |
| 141 |  | Define NGAO Uniqueness Space | 380d? | 2008-07-07 | 2009-12-18 |  |  | 66d | finish no earlier than 2009-12-18 |
| 142 | 1.3.3.1.5 | **User Community Liaison** | 445d? | 2008-05-19 | 2010-01-29 |  |  | 36d |  |
| 143 |  | Enlist People to work on new NGAO Science Aspects | 358d? | 2008-05-19 | 2009-09-30 |  |  | 123d | finish no earlier than 2009-09-30 |
| 144 | 1.3.3.1.5.2 | **SSC & Keck Science Meeting** | 435d? | 2008-06-02 | 2010-01-29 |  |  | 36d |  |
| 145 |  | Prepare & Give Presentations | 435d? | 2008-06-02 | 2010-01-29 |  |  | 36d | finish no earlier than 2010-01-29 |
| 146 |  | Obtain & Document Feedback | 435d? | 2008-06-02 | 2010-01-29 |  |  | 36d | finish no earlier than 2010-01-29 |
| 147 | 1.3.3.1.6 | **Science Advisory Team Meetings** | 385d? | 2008-06-09 | 2009-11-27 |  |  | 81d |  |
| 148 |  | Prepare Minutes, Presentations & KAONs | 385d? | 2008-06-09 | 2009-11-27 |  |  | 81d | finish no earlier than 2009-11-27 |
| 149 |  | Refine Science Requirements | 355d? | 2008-07-21 | 2009-11-27 |  |  | 81d | finish no earlier than 2009-11-27 |
| 150 |  | Evaluate Science Impact of Proposed Changes | 355d? | 2008-07-21 | 2009-11-27 |  |  | 81d | finish no earlier than 2009-11-27 |
| 151 | 1.3.3.2 | **Requirements** | 410d? | 2008-05-26 A | 2009-12-18 |  | 1% | 66d |  |
| 152 | 1.3.3.2.1 | **Operations Concept Document (OCD)** | 410d? | 2008-05-26 A | 2009-12-18 |  | 2% | 66d |  |
| 153 |  | OCD Outline | 10d? | 2008-05-26 A | 2008-06-06 |  | 25% | 466d | start no earlier than 2008-05-26 |
| 154 |  | OCD Release 1 | 45d? | 2008-12-01 | 2009-01-30 |  |  | 296d | start no earlier than 2008-12-01 |
| 155 |  | OCD Release 2 | 55d? | 2009-10-05 | 2009-12-18 |  |  | 66d | start no earlier than 2009-10-05 |
| 156 | 1.3.3.2.2 | **System Requirements (SRD)** | 270d? | 2008-12-01 | 2009-12-11 |  |  | 71d |  |
| 157 |  | SRD Release I | 10d? | 2008-12-01 | 2008-12-12 |  |  | 331d | finish no earlier than 2008-12-12 |
| 158 |  | SRD Release 2 | 10d? | 2009-11-30 | 2009-12-11 |  |  | 71d | finish no earlier than 2009-12-11 |
| 159 | 1.3.3.2.3 | **Functional Requirements (FRD)** | 375d? | 2008-07-14 | 2009-12-18 |  |  | 66d |  |
| 160 |  | FRD Release 1 | 35d? | 2008-07-14 | 2008-08-29 |  |  | 406d | start no earlier than 2008-07-14 |
| 161 |  | FRD Release 2 | 35d? | 2009-11-02 | 2009-12-18 |  |  | 66d | start no earlier than 2009-11-02 |
| 162 |  | Compliance Matrix | 20d? | 2008-10-06 | 2008-10-31 |  |  | 361d | finish no earlier than 2008-10-31 |
| 163 |  | Software Standards (Define & Document) | 31d? | 2008-10-06 | 2008-11-17 |  |  | 350d | start no earlier than 2008-10-06 |
| 164 |  | Component Standards (Define & Document) | 25d? | 2008-11-03 | 2008-12-05 |  |  | 336d | finish no earlier than 2008-12-05 |
| 165 | 1.3.3.3 | **Systems Engineering Analysis** | 427d? | 2008-05-01 A | 2009-12-18 |  | 2% | 66d |  |
| 166 | 1.3.3.3.1 | **Performance Budgets** | 389d? | 2008-06-24 | 2009-12-18 |  |  | 66d |  |
| 167 |  | Requirements Flowdown Report | 15d? | 2009-11-30 | 2009-12-18 |  |  | 66d | start no earlier than 2009-11-30 |
| 168 | 1.3.3.3.1.2 | **Throughput & Background Budget** | 30d? | 2008-11-03 | 2008-12-12 |  |  | 331d |  |
| 169 |  | Thermal Background Analysis Software with Documentation | 15d? | 2008-11-03 | 2008-11-21 |  |  | 346d | finish no earlier than 2008-11-21 |
| 170 |  | Thermal Analysis | 10d? | 2008-12-01 | 2008-12-12 |  |  | 331d | finish no earlier than 2008-12-12 |
| 171 | 1.3.3.3.1.3 | **Wavefront & Encircled Energy** | 260d? | 2008-09-01 | 2009-08-28 |  |  | 146d |  |
| 172 | 1.3.3.3.1.3.1 | **WFE/EE Budget Tool** | 213d? | 2008-09-01 | 2009-06-24 |  |  | 193d |  |
| 173 |  | NGS TT & TTFA Sharpening Budgets | 31.5d? | 2008-10-06 | 2008-11-18 |  |  | 349.5d | start no earlier than 2008-10-06 |
| 174 |  | Improved Bandwidth Model | 25d? | 2008-12-01 | 2009-01-02 |  |  | 316d | start no earlier than 2008-12-01 |
| 175 |  | Improved Atmospheric Dispersion Model | 15d? | 2008-09-01 | 2008-09-19 |  |  | 391d | start no earlier than 2008-09-01 |
| 176 |  | Other | 38d? | 2009-05-04 | 2009-06-24 |  |  | 193d | start no earlier than 2009-05-04 |
| 177 | 1.3.3.3.1.3.2 | **WFE/EE Performance Analysis** | 65d? | 2009-06-01 | 2009-08-28 |  |  | 146d |  |
| 178 |  | Key Science Cases Analysis | 20d? | 2009-06-01 | 2009-06-26 |  |  | 191d | start no earlier than 2009-06-01 |
| 179 |  | Additional Science Case Analysis | 20d? | 2009-08-03 | 2009-08-28 |  |  | 146d | start no earlier than 2009-08-03 |
| 180 | 1.3.3.3.1.4 | **Astrometric Precision** | 105d? | 2008-10-06 | 2009-02-27 |  |  | 276d |  |
| 181 |  | Develop Astrometric Budget Tool | 55d? | 2008-10-06 | 2008-12-19 |  |  | 326d | start no earlier than 2008-10-06 |
| 182 |  | Galactic Center Astrometric Analysis | 40d? | 2009-01-05 | 2009-02-27 |  |  | 276d | start no earlier than 2009-01-05 |
| 183 | 1.3.3.3.1.5 | **Observing Efficiency** | 266d? | 2008-06-24 | 2009-06-30 |  |  | 189d |  |
| 184 |  | Observing Efficiency Tool | 5d? | 2008-06-24 | 2008-06-30 |  |  | 450d | finish no earlier than 2008-06-30 |
| 185 |  | Observing Efficiency Analysis | 5d? | 2009-06-24 | 2009-06-30 |  |  | 189d | finish no earlier than 2009-06-30 |
| 186 | 1.3.3.3.1.6 | **Observing Uptime** | 250d? | 2008-12-01 | 2009-11-13 |  |  | 91d |  |
| 187 |  | Observing Uptime Tool | 10d? | 2008-12-01 | 2008-12-12 |  |  | 331d | start no earlier than 2008-12-01 |
| 188 |  | Observing Uptime Analysis | 10d? | 2009-11-02 | 2009-11-13 |  |  | 91d | start no earlier than 2009-11-02 |
| 189 | 1.3.3.3.2 | **Modeling & Analysis** | 247d? | 2008-05-01 A | 2009-04-10 |  | 8% | 246d |  |
| 190 |  | T/T Sharpening Study Report | 42d? | 2008-05-01 A | 2008-06-27 |  | 25% | 451d | start no earlier than 2008-05-01 |
| 191 |  | Performance vs T/T NGS Report | 32d? | 2008-09-01 | 2008-10-14 |  |  | 374d | start no earlier than 2008-09-01 |
| 192 |  | Galactic Center Performance Report | 30d? | 2009-03-02 | 2009-04-10 |  |  | 246d | start no earlier than 2009-03-02 |
| 193 |  | PSF Libraries | 35d? | 2008-11-03 | 2008-12-19 |  |  | 326d | finish no earlier than 2008-12-19 |
| 194 |  | PSF Calibration | 125d? | 2009-05-04 | 2009-10-23 |  |  | 106d | start no earlier than 2009-05-04 |
| 195 | 1.3.3.4 | **System Architecture** | 411d? | 2008-05-05 | 2009-11-30 |  |  | 80d |  |
| 196 | 1.3.3.4.1 | **System Hardware Architecture** | 391d? | 2008-06-02 | 2009-11-30 |  |  | 80d |  |
| 197 |  | Hybrid Rayleigh / Sodium Trade Study | 65d? | 2008-06-30 | 2008-09-26 |  |  | 386d | start no earlier than 2008-06-30 |
| 198 |  | Degraded Laser Power Trade Study | 10d? | 2008-08-04 | 2008-08-15 |  |  | 416d | start no earlier than 2008-08-04 |
| 199 |  | System Architecture: Evaluate & Document Changes | 391d? | 2008-06-02 | 2009-11-30 |  |  | 80d | start no earlier than 2008-06-02 |
| 200 | 1.3.3.4.2 | **Software Architecture** | 308d? | 2008-07-28 | 2009-09-30 |  |  | 123d |  |
| 201 |  | Evaluate Software Architecture Options | 20d? | 2008-07-28 | 2008-08-22 |  |  | 391d | start no earlier than 2008-07-28 |
| 202 |  | Determine/Document Software Arch Approach | 20d? | 2008-08-25 | 2008-09-19 | 201 |  | 391d | finish no earlier than 2008-09-19 |
| 203 |  | Software Architecture: Evaluate & Document Changes | 268d? | 2008-09-22 | 2009-09-30 |  |  | 123d | start no earlier than 2008-09-22 |
| 204 | 1.3.3.4.3 | **Control Systems Architecture** | 261d? | 2008-10-01 | 2009-09-30 |  |  | 123d |  |
| 205 |  | Evaluate Control Systems Arch Options | 33d? | 2008-10-01 | 2008-11-14 |  |  | 315d | finish no earlier than 2008-11-14 |
| 206 |  | Determine/Document Control Systems Arch | 36d? | 2008-11-17 | 2009-01-05 | 205 |  | 315d | start no earlier than 2008-11-17 |
| 207 |  | Evaluate Motion Control Arch Options | 37d? | 2009-01-08 | 2009-02-27 |  |  | 256d | finish no earlier than 2009-02-27 |
| 208 |  | Determine/Document Motion Control Arch | 20d? | 2009-03-02 | 2009-03-27 | 207 |  | 256d | finish no earlier than 2009-03-27 |
| 209 |  | Control Systems Architecture: Evaluate & Document Changes | 190d? | 2009-01-08 | 2009-09-30 |  |  | 123d | start no earlier than 2009-01-08 |
| 210 | 1.3.3.4.4 | **Operations Sequences Architecture** | 330d? | 2008-05-05 | 2009-08-07 |  |  | 161d |  |

| ID | WBS | Task | Duration | Start | Finish | Predecessors | Complete | Total float | Constraint |
| --- | --- | --- | --- | --- | --- | --- | --- | --- | --- |
| 211 |  | Define Required System Level Sequences | 10d? | 2008-05-05 | 2008-05-16 |  |  | 481d | start no earlier than 2008-05-05 |
| 212 |  | Develop System Level Sequences Approach | 15d? | 2008-05-19 | 2008-06-06 |  |  | 466d | finish no earlier than 2008-06-06 |
| 213 |  | Sequences Definition Document | 15d? | 2008-06-09 | 2008-06-27 |  |  | 451d | start no earlier than 2008-06-09 |
| 214 |  | Sequences: Evaluate & Document Changes | 285d? | 2008-07-07 | 2009-08-07 |  |  | 161d | start no earlier than 2008-07-07 |
| 215 | 1.3.3.5 | **External Interface Control** | 100d? | 2008-10-06 | 2009-02-20 |  |  | 281d |  |
| 216 | 1.3.3.5.1 | **Observatory Interfaces** | 100d? | 2008-10-06 | 2009-02-20 |  |  | 281d |  |
| 217 |  | AO System ICD | 15d? | 2009-02-02 | 2009-02-20 |  |  | 281d | finish no earlier than 2009-02-20 |
| 218 |  | Laser System ICD | 10d? | 2008-10-06 | 2008-10-17 |  |  | 371d | finish no earlier than 2008-10-17 |
| 219 |  | Science Tools ICD | 20d? | 2008-10-06 | 2008-10-31 |  |  | 361d | finish no earlier than 2008-10-31 |
| 220 | 1.3.3.5.2 | **Science Instrument Interfaces to NGAO** | 40d? | 2008-10-06 | 2008-11-28 |  |  | 341d |  |
| 221 |  | Generic Science Instrument ICD to AO | 20d? | 2008-10-06 | 2008-10-31 |  |  | 361d | finish no earlier than 2008-10-31 |
| 222 |  | Generic Science Instrument ICD to NGAO Science Tools | 20d? | 2008-10-06 | 2008-10-31 |  |  | 361d | finish no earlier than 2008-10-31 |
| 223 |  | Interferometer Specific ICD | 20d? | 2008-11-03 | 2008-11-28 |  |  | 341d | finish no earlier than 2008-11-28 |
| 224 |  | OSIRIS Specific ICD | 20d? | 2008-11-03 | 2008-11-28 |  |  | 341d | start no earlier than 2008-11-03 |
| 225 |  | NIR Camera Specific ICD | 20d? | 2008-11-03 | 2008-11-28 |  |  | 341d | start no earlier than 2008-11-03 |
| 226 |  | Visible Camera Specific ICD | 20d? | 2008-11-03 | 2008-11-28 |  |  | 341d | start no earlier than 2008-11-03 |
| 227 |  | d-IFS Specific ICD | 20d? | 2008-11-03 | 2008-11-28 |  |  | 341d | start no earlier than 2008-11-03 |
| 228 | 1.3.3.6 | **Internal Interface Control** | 100d? | 2008-08-04 | 2008-12-19 |  |  | 326d |  |
| 229 |  | Diagram & Document Draft Outline | 40d? | 2008-08-04 | 2008-09-26 |  |  | 386d | finish no earlier than 2008-09-26 |
| 230 |  | Interface N-Squared Diagram | 25d? | 2008-10-06 | 2008-11-07 |  |  | 356d | start no earlier than 2008-10-06 |
| 231 |  | Interface Definition Document | 40d? | 2008-10-27 | 2008-12-19 |  |  | 326d | start no earlier than 2008-10-27 |
| 232 | 1.3.3.7 | **Configuration Control** | 15d? | 2009-10-05 | 2009-10-23 |  |  | 106d |  |
| 233 |  | Change Control Guidelines & Tools Definition | 15d? | 2009-10-05 | 2009-10-23 |  |  | 106d | finish no earlier than 2009-10-23 |
| 234 | 1.3.3.8 | **Documentation Control** | 5d? | 2009-01-12 | 2009-01-16 |  |  | 306d |  |
| 235 |  | Document Control Guidelines & Tools Definition | 5d? | 2009-01-12 | 2009-01-16 |  |  | 306d | finish no earlier than 2009-01-16 |
| 236 | 1.3.3.9 | **Technical Risk Assessment & Mitigation** | 250d? | 2008-09-15 | 2009-08-28 |  |  | 146d |  |
| 237 | 1.3.3.9.1 | **Risk Assessment** | 229.2d? | 2008-10-13 | 2009-08-28 |  |  | 146d |  |
| 238 |  | Risk Assessment v1 | 13.2d? | 2008-10-13 | 2008-10-30 |  |  | 362d | finish no earlier than 2008-10-30 |
| 239 |  | Risk Assessment v2 | 12d? | 2009-08-13 | 2009-08-28 |  |  | 146d | finish no earlier than 2009-08-28 |
| 240 | 1.3.3.9.2 | **Risk Mitigation Efforts** | 150d? | 2008-09-15 | 2009-04-10 |  |  | 246d |  |
| 241 | 1.3.3.9.2.1 | **PSF Calibration** | 100d? | 2008-09-15 | 2009-01-30 |  |  | 296d |  |
| 242 |  | Support/Monitor Profiler Implementation | 100d? | 2008-09-15 | 2009-01-30 |  |  | 296d | start no earlier than 2008-09-15 |
| 243 | 1.3.3.9.2.2 | **Sky Coverage** | 135d? | 2008-10-06 | 2009-04-10 |  |  | 246d |  |
| 244 |  | Prototype NIR Tip/tilt Sensor | 135d? | 2008-10-06 | 2009-04-10 |  |  | 246d | start no earlier than 2008-10-06 |
| 245 |  | Preliminary Design Manual | 101.67d? | 2009-08-03 | 2009-12-22 |  |  | 64.33d | start no earlier than 2009-08-03 |
| 246 | 1.3.4 | **AO System Design** | 425d? | 2008-05-12 A | 2009-12-25 |  | 1% | 61d |  |
| 247 |  | AO Enclosure | 130d? | 2008-10-01 | 2009-03-31 |  |  | 254d | finish no earlier than 2009-03-31 |
| 248 | 1.3.4.2 | **Opto-Mechanical** | 371d? | 2008-06-02 A | 2009-11-02 |  | 2% | 100d |  |
| 249 |  | AO Support Structure | 50d? | 2008-11-03 | 2009-01-09 |  |  | 311d | start no earlier than 2008-11-03 |
| 250 |  | Rotator | 13d? | 2009-03-12 | 2009-03-30 |  |  | 255d | start no earlier than 2009-03-12 |
| 251 |  | Optical Relays | 80d? | 2008-12-29 | 2009-04-17 |  |  | 241d | start no earlier than 2008-12-28 |
| 252 |  | Optical Switchyard | 70d? | 2008-08-04 | 2008-11-07 |  |  | 356d | start no earlier than 2008-08-04 |
| 253 | 1.3.4.2.5 | **LGS Wavefront Sensor Assembly** | 202d? | 2008-06-02 A | 2009-03-10 |  | 2% | 269d |  |
| 254 |  | Review concept design for LGS WFS assembly (includes OSM) | 20d? | 2008-06-02 A | 2008-06-27 |  | 20% | 269d | start no earlier than 2008-06-02 |
| 255 |  | Develop to preliminary design level the opto-mechanical design for the LGS wavefront sensor unit. | 70d? | 2008-06-30 | 2008-10-03 | 254 |  | 269d |  |
| 256 |  | Identify the issues with uplink TTM, asterism generation and OSM concepts to ensure it conforms to the dithering requirements. This is important when the LGSs have to move with the source | 19.25d? | 2008-10-06 | 2008-10-31 | 255 |  | 269d |  |
| 257 |  | Develop to preliminary design level the opto-mechanical design for the LGS OSM. (overlaps with TT(FA) OSMs; hence costed there) | 10d? | 2008-11-03 | 2008-11-14 | 256 |  | 269d | start no earlier than 2008-09-15 |
| 258 |  | Package and model the assembly. | 20d? | 2008-11-17 | 2008-12-25 | 257 |  | 269d |  |
| 259 |  | Develop background model and work out stray LGS light problems. | 13.33d? | 2008-12-25 | 2009-01-13 | 258 |  | 309.33d |  |
| 260 |  | Identify the motion control needs and specify solutions. | 20d? | 2008-12-25 | 2009-01-22 | 258 |  | 269d |  |
| 261 |  | Identify design risks and mitigation of the identified risks. | 4.5d? | 2009-01-22 | 2009-01-28 | 260 |  | 269d |  |
| 262 |  | Develop a preliminary integration plan for the assembly. | 9.17d? | 2009-01-28 | 2009-02-10 | 261 |  | 269d |  |
| 263 |  | LGS WFS Assembly Documentation | 20d? | 2009-02-11 | 2009-03-10 | 262 |  | 269d |  |
| 264 | 1.3.4.2.6 | **NGS WFS/TWFS Assembly** | 143d? | 2009-04-16 | 2009-11-02 |  |  | 100d |  |
| 265 |  | Review concept design for NGS WFS and TWFS; jointly called NGS WFS assembly. | 10d? | 2009-04-16 | 2009-04-29 |  |  | 128.5d |  |
| 266 |  | Develop to preliminary design level the opto-mechanical design for the NGS wavefront sensor assembly. | 28d? | 2009-04-30 | 2009-06-08 | 265 |  | 128.5d | start no earlier than 2009-01-19 |
| 267 |  | Check compliance of design with the design of the field steering mirror assembly. | 14d? | 2009-06-09 | 2009-06-26 | 266 |  | 128.5d |  |
| 268 |  | Package and model the NGS WFS assembly. | 18d? | 2009-06-29 | 2009-08-20 | 267 |  | 128.5d |  |
| 269 |  | Identify the motion control needs and specify solutions. | 7d? | 2009-08-21 | 2009-08-31 | 268 |  | 128.5d |  |
| 270 |  | Identify design risks and mitigation of the identified risks. | 4.67d? | 2009-09-01 | 2009-09-07 | 269 |  | 128.5d |  |
| 271 |  | Check compliance with alignment plan for the NGS OSM (written as part of opto-mechanical relay sub-system design effort). | 4.83d? | 2009-09-07 | 2009-09-14 | 270 |  | 128.5d |  |
| 272 |  | NGS WFS Assembly Documentation | 7d? | 2009-10-23 | 2009-11-02 | 271 |  | 100d | finish no earlier than 2009-11-02 |
| 273 | 1.3.4.2.7 | **Low Order Wavefront Sensor Assembly** | 321d? | 2008-08-11 A | 2009-11-02 |  | 6% | 100d |  |
| 274 |  | Review concept design for LOWFS assembly. | 26.67d? | 2008-08-11 A | 2008-09-16 |  | 50% | 148d | start no earlier than 2008-08-11 |
| 275 |  | Investigate optimum method of dithering based on requirements. | 25.33d? | 2008-09-16 | 2008-10-21 | 274 |  | 148d |  |
| 276 |  | Develop to preliminary design level the opto-mechanical design for the tip-tilt and the TTFA-TWFS wavefront sensor units | 24d? | 2009-01-12 | 2009-02-12 | 275 |  | 147d |  |
| 277 |  | Develop to preliminary design level the opto-mechanical design for the LOWFS OSM | 13.33d? | 2009-02-13 | 2009-03-04 | 276 |  | 147d |  |
| 278 |  | Make sure that the design doesn't preclude the inclusion of a PSF monitor later | 3.33d? | 2009-03-04 | 2009-03-09 | 277 |  | 147d |  |
| 279 |  | Package and model the assembly. | 13.33d? | 2009-03-09 | 2009-03-26 | 278 |  | 147d |  |
| 280 |  | Develop thermal model and work emissivity details of the LOWFS assembly and feed into the overall emissivity budget | 10d? | 2009-03-27 | 2009-04-09 | 279 |  | 147d |  |

| ID | WBS | Task | Duration | Start | Finish | Predecessors | Total float | Constraint |
| --- | --- | --- | --- | --- | --- | --- | --- | --- |
| 281 |  | Identify the motion control needs and specify solutions. | 60d? | 2009-04-10 | 2009-07-02 | 280 | 147d |  |
| 282 |  | Identify design risks and mitigation of the identified risks. | 10d? | 2009-07-03 | 2009-07-16 | 281 | 147d |  |
| 283 |  | Develop a preliminary integration plan for the assembly. | 13.33d? | 2009-07-17 | 2009-08-05 | 282 | 147d |  |
| 284 |  | Develop a test plan based on the design to test performance | 10d? | 2009-08-05 | 2009-08-19 | 283 | 147d |  |
| 285 |  | LOWFS Assembly Documentation | 6.67d? | 2009-10-23 | 2009-11-02 | 284 | 100d | finish no earlier than 2009-11-02 |
| 286 | 1.3.4.2.8 | **Tip/Tilt Vibration Mitigation** | 40d? | 2008-07-07 | 2008-08-29 |  | 406d |  |
| 287 |  | TT Vibration Mitigation Analysis | 40d? | 2008-07-07 | 2008-08-29 |  | 406d | start no earlier than 2008-07-07 |
| 288 | 1.3.4.2.9 | **Acquisition Cameras** | 305d? | 2008-09-01 | 2009-10-30 |  | 101d |  |
| 289 |  | Implementation Issues | 20d? | 2008-09-01 | 2008-09-26 |  | 386d | start no earlier than 2008-09-01 |
| 290 |  | Opto-Mechanical Design | 20d? | 2009-10-01 | 2009-10-30 |  | 101d | start no earlier than 2009-10-01 |
| 291 | 1.3.4.2.10 | **Atmospheric Dispersion Correctors** | 96d? | 2008-10-17 | 2009-02-27 |  | 276d |  |
| 292 |  | LOWFS ADCs | 10d? | 2008-10-17 | 2008-10-30 |  | 362d | finish no earlier than 2008-10-30 |
| 293 |  | NIR Science ADC | 5d? | 2008-12-24 | 2008-12-30 |  | 319d | finish no earlier than 2008-12-30 |
| 294 |  | Visible Science & NGS WFS ADC | 5d? | 2009-02-23 | 2009-02-27 |  | 276d | finish no earlier than 2009-02-27 |
| 295 | 1.3.4.3 | **Alignment, Calibration & Diagnostics** | 90d? | 2009-02-02 | 2009-06-05 |  | 206d |  |
| 296 | 1.3.4.3.1 | **Simulator** | 45d? | 2009-02-02 | 2009-04-03 |  | 251d |  |
| 297 |  | Simulator Requirements & Interfaces | 10d? | 2009-02-02 | 2009-02-13 |  | 286d | finish no earlier than 2009-02-13 |
| 298 |  | Simulator Optical Design | 10d? | 2009-02-16 | 2009-02-27 |  | 276d | finish no earlier than 2009-02-27 |
| 299 |  | Simulator Mechanical Design | 10d? | 2009-03-02 | 2009-03-13 |  | 266d | finish no earlier than 2009-03-13 |
| 300 |  | Simulator Electrical Design | 10d? | 2009-03-09 | 2009-03-20 |  | 261d | finish no earlier than 2009-03-20 |
| 301 |  | Simulator Assembly, Alignment & Test Plans | 10d? | 2009-03-23 | 2009-04-03 |  | 251d | start no earlier than 2009-03-23 |
| 302 | 1.3.4.3.2 | **System Alignment Tools** | 45d? | 2009-04-06 | 2009-06-05 |  | 206d |  |
| 303 |  | Alignment Requirements & Interfaces | 10d? | 2009-04-06 | 2009-04-17 |  | 241d | finish no earlier than 2009-04-17 |
| 304 |  | Alignment Optical Design | 10d? | 2009-04-20 | 2009-05-01 |  | 231d | finish no earlier than 2009-05-01 |
| 305 |  | Alignment Mechanical Design | 10d? | 2009-05-04 | 2009-05-15 |  | 221d | finish no earlier than 2009-05-15 |
| 306 |  | Alignment Electrical Design | 10d? | 2009-05-11 | 2009-05-22 |  | 216d | finish no earlier than 2009-05-22 |
| 307 |  | Alignment Assembly, Alignment & Test Plans | 10d? | 2009-05-25 | 2009-06-05 |  | 206d | finish no earlier than 2009-06-05 |
| 308 | 1.3.4.4 | **Non-real-time Control** | 130d? | 2009-01-19 | 2009-07-17 |  | 176d |  |
| 309 |  | AO Controls Infrastructure | 1d? | 2009-02-02 | 2009-02-02 |  | 295d | start no earlier than 2009-02-02 |
| 310 | 1.3.4.4.2 | **AO Sequencer** | 20d? | 2009-02-02 | 2009-02-27 |  | 276d |  |
| 311 |  | AO Sequencer: Architecture | 20d? | 2009-02-02 | 2009-02-27 |  | 276d | finish no earlier than 2009-02-27 |
| 312 |  | AO Sequencer: Interface Control Document | 20d? | 2009-02-02 | 2009-02-27 |  | 276d | finish no earlier than 2009-02-27 |
| 313 |  | AO Sequencer: Software Module Design | 20d? | 2009-02-02 | 2009-02-27 |  | 276d | finish no earlier than 2009-02-27 |
| 314 |  | AO Sequencer: User Interface Design | 0d? | 2009-02-02 | 2009-02-02 |  | 296d | start no earlier than 2009-02-02 |
| 315 |  | AO Sequencer: Technical Specifications | 0d? | 2009-02-02 | 2009-02-02 |  | 296d | start no earlier than 2009-02-02 |
| 316 |  | AO Sequencer: Compliance Matrix | 0d? | 2009-02-02 | 2009-02-02 |  | 296d | start no earlier than 2009-02-02 |
| 317 |  | AO Sequencer: Test Plan | 0d? | 2009-02-02 | 2009-02-02 |  | 296d | start no earlier than 2009-02-02 |
| 318 |  | AO Sequencer: Summary Report | 20d? | 2009-02-02 | 2009-02-27 |  | 276d | finish no earlier than 2009-02-27 |
| 319 | 1.3.4.4.3 | **AO Motion Control Software** | 40d? | 2009-03-02 | 2009-04-24 |  | 236d |  |
| 320 |  | Motion Control SW: Architecture | 40d? | 2009-03-02 | 2009-04-24 |  | 236d | start no earlier than 2009-03-02 |
| 321 |  | Motion Control SW: ICD | 40d? | 2009-03-02 | 2009-04-24 |  | 236d | start no earlier than 2009-03-02 |
| 322 |  | Motion Control SW: Module Design | 40d? | 2009-03-02 | 2009-04-24 |  | 236d | start no earlier than 2009-03-02 |
| 323 |  | Motion Control SW: User Interface Design | 0d? | 2009-03-02 | 2009-03-02 |  | 276d | start no earlier than 2009-03-02 |
| 324 |  | Motion Control SW: Technical Specifications | 0d? | 2009-03-02 | 2009-03-02 |  | 276d | start no earlier than 2009-03-02 |
| 325 |  | Motion Control SW: Compliance Matrix | 0d? | 2009-03-02 | 2009-03-02 |  | 276d | start no earlier than 2009-03-02 |
| 326 |  | Motion Control SW: Test Plan | 0d? | 2009-03-02 | 2009-03-02 |  | 276d | start no earlier than 2009-03-02 |
| 327 |  | Motion Control SW: Summary Report | 40d? | 2009-03-02 | 2009-04-24 |  | 236d | finish no earlier than 2009-04-24 |
| 328 | 1.3.4.4.4 | **AO Device Control Software** | 55d? | 2009-05-04 | 2009-07-17 |  | 176d |  |
| 329 |  | Device Control: Software Architecture | 20d? | 2009-05-04 | 2009-05-29 |  | 211d | finish no earlier than 2009-05-29 |
| 330 |  | Device Control: Interface Control Document | 15d? | 2009-05-25 | 2009-06-12 |  | 201d | finish no earlier than 2009-06-12 |
| 331 |  | Device Control: Software Module Design | 25d? | 2009-06-15 | 2009-07-17 |  | 176d | finish no earlier than 2009-07-17 |
| 332 |  | Device Control: User Interface Design | 0d? | 2009-06-15 | 2009-06-15 |  | 201d | start no earlier than 2009-06-15 |
| 333 |  | Device Control: Technical Specifications | 0d? | 2009-06-15 | 2009-06-15 |  | 201d | start no earlier than 2009-06-15 |
| 334 |  | Device Control: Compliance Matrix | 0d? | 2009-06-15 | 2009-06-15 |  | 201d | start no earlier than 2009-06-15 |
| 335 |  | Device Control: Test Plan | 0d? | 2009-06-15 | 2009-06-15 |  | 201d | start no earlier than 2009-06-15 |
| 336 |  | Device Control: Summary Report | 25d? | 2009-06-15 | 2009-07-17 |  | 176d | finish no earlier than 2009-07-17 |
| 337 | 1.3.4.4.5 | **AO Motion Control Electronics** | 30d? | 2009-01-19 | 2009-02-27 |  | 276d |  |
| 338 |  | Motion Control HW: Spreadsheet | 30d? | 2009-01-19 | 2009-02-27 |  | 276d | finish no earlier than 2009-02-27 |
| 339 | 1.3.4.4.6 | **Non-RTC Electronics** | 40d? | 2009-04-06 | 2009-05-29 |  | 211d |  |
| 340 |  | Non-RTC Electronics: Architecture | 40d? | 2009-04-06 | 2009-05-29 |  | 211d | finish no earlier than 2009-05-29 |
| 341 |  | Non-RTC Electronics: Selection/Specification | 40d? | 2009-04-06 | 2009-05-29 |  | 211d | start no earlier than 2009-04-06 |
| 342 |  | Non-RTC Electronics: Compliance Matrix | 1d? | 2009-04-06 | 2009-04-06 |  | 250d | start no earlier than 2009-04-06 |
| 343 |  | Non-RTC Electronics: Test Plan | 1d? | 2009-04-06 | 2009-04-06 |  | 250d | start no earlier than 2009-04-06 |
| 344 |  | Non-RTC Electronics: Documentation | 40d? | 2009-04-06 | 2009-05-29 |  | 211d | start no earlier than 2009-04-06 |
| 345 | 1.3.4.4.7 | **Non-RTC Lab System Integration & Test** | 0d? | 2009-02-02 | 2009-02-02 |  | 296d |  |
| 346 |  | Non-RTC I&T: Architecture | 0d? | 2009-02-02 | 2009-02-02 |  | 296d | start no earlier than 2009-02-02 |
| 347 |  | Non-RTC I&T: Electronics Specification & Selection | 0d? | 2009-02-02 | 2009-02-02 |  | 296d | start no earlier than 2009-02-02 |
| 348 |  | Non-RTC I&T: Test Plan | 0d? | 2009-02-02 | 2009-02-02 |  | 296d | start no earlier than 2009-02-02 |
| 349 |  | Non-RTC I&T: Summary Report | 0d? | 2009-02-02 | 2009-02-02 |  | 296d | start no earlier than 2009-02-02 |
| 350 | 1.3.4.4.8 | **Acquisition, Guiding & Offload (AGO) Control** | 47d? | 2009-04-27 | 2009-06-30 |  | 189d |  |

| ID | WBS | Task | Duration | Start | Finish | Predecessors | Total float | Constraint |
| --- | --- | --- | --- | --- | --- | --- | --- | --- |
| 351 |  | AGO: Architecture | 47d? | 2009-04-27 | 2009-06-30 |  | 189d | finish no earlier than 2009-06-30 |
| 352 |  | AGO: ICD | 47d? | 2009-04-27 | 2009-06-30 |  | 189d | start no earlier than 2009-04-27 |
| 353 |  | AGO: Software Module Design | 47d? | 2009-04-27 | 2009-06-30 |  | 189d | start no earlier than 2009-04-27 |
| 354 |  | AGO: User Interface | 0d? | 2009-04-27 | 2009-04-27 |  | 236d | start no earlier than 2009-04-27 |
| 355 |  | AGO: Technical Specification | 0d? | 2009-04-27 | 2009-04-27 |  | 236d | start no earlier than 2009-04-27 |
| 356 |  | AGO: Compliance Matrix | 0d? | 2009-04-27 | 2009-04-27 |  | 236d | start no earlier than 2009-04-27 |
| 357 |  | AGO: Test Plan | 0d? | 2009-04-27 | 2009-04-27 |  | 236d | start no earlier than 2009-04-27 |
| 358 |  | AGO: Summary Report | 47d? | 2009-04-27 | 2009-06-30 |  | 189d | finish no earlier than 2009-06-30 |
| 359 | 1.3.4.5 | **Real-time Control** | 425d? | 2008-05-12 | 2009-12-25 |  | 61d |  |
| 360 | 1.3.4.5.1 | **RTC Processor** | 425d? | 2008-05-12 | 2009-12-25 |  | 61d |  |
| 361 |  | RTC Technical Management | 3400h? | 2008-05-12 | 2009-12-25 |  | 61d | start no earlier than 2008-05-12 |
| 362 |  | Centroid/Wavefront Reconstruction Processing Requirements | 105d? | 2008-05-12 | 2008-10-03 |  | 381d | start no earlier than 2008-05-12 |
| 363 |  | Centroid/Wavefront Reconstruction Test Definition | 47d? | 2008-09-08 | 2008-11-11 |  | 354d | start no earlier than 2008-09-08 |
| 364 |  | Preconditioning & Scaling Processing Requirements | 75d? | 2008-10-06 | 2009-01-16 |  | 306d | start no earlier than 2008-10-06 |
| 365 |  | Preconditioning & Scaling Processing Test Definition | 30d? | 2008-12-29 | 2009-02-06 |  | 291d | start no earlier than 2008-12-28 |
| 366 |  | Low Order WFS Processing Requirements | 65d? | 2009-02-09 | 2009-05-08 |  | 226d | start no earlier than 2009-02-08 |
| 367 |  | Low Order WFS Processing Test Definition | 11.25d? | 2009-05-18 | 2009-06-02 |  | 209.75d | start no earlier than 2009-05-17 |
| 368 |  | Layer Combining & DM Processing Requirements | 41d? | 2009-06-01 | 2009-07-27 |  | 170d | start no earlier than 2009-05-31 |
| 369 |  | Camera Data Transfer Issues | 24.19d? | 2009-07-27 | 2009-08-28 |  | 146.81d | start no earlier than 2009-07-26 |
| 370 |  | Radial versus Rectilinear Voxels Trade Study | 73d? | 2008-11-03 | 2009-02-11 |  | 288d | start no earlier than 2008-11-03 |
| 371 |  | Define Required Bit Resolution | 22d? | 2008-05-19 | 2008-06-17 |  | 459d | start no earlier than 2008-05-18 |
| 372 |  | Characterize Single Event Upset | 30d? | 2009-08-24 | 2009-10-02 |  | 121d | start no earlier than 2009-08-23 |
| 373 |  | Power Characterization and Parameter Estimation | 11.25d? | 2009-10-05 | 2009-10-20 |  | 109.75d | start no earlier than 2009-10-04 |
| 374 |  | Voxel Communication Parameters | 11.25d? | 2009-11-30 | 2009-12-15 |  | 69.75d | start no earlier than 2009-11-30 |
| 375 |  | Diagnostic Control & I/O Requirements | 30d? | 2009-02-02 | 2009-03-13 |  | 266d | start no earlier than 2009-02-02 |
| 376 |  | Monitoring Control & I/O Requirements | 40d? | 2009-10-12 | 2009-12-04 |  | 76d | start no earlier than 2009-10-11 |
| 377 |  | Define Testing Procedures | 45d? | 2008-09-29 | 2008-11-28 |  | 341d | start no earlier than 2008-09-28 |
| 378 |  | Documentation | 140d? | 2009-06-08 | 2009-12-18 |  | 66d | start no earlier than 2009-06-08 |
| 379 | 1.3.4.5.2 | **DMs & Tip/Tilt Stages** | 105d? | 2008-10-06 | 2009-02-27 |  | 276d |  |
| 380 | 1.3.4.5.2.1 | **Woofer DM/TT** | 105d? | 2008-10-06 | 2009-02-27 |  | 276d |  |
| 381 |  | Define Requirements | 20d? | 2008-10-06 | 2008-10-31 |  | 361d | start no earlier than 2008-10-06 |
| 382 |  | Evaluate Tip/Tilt Mount Options | 30d? | 2008-12-01 | 2009-01-09 |  | 311d | finish no earlier than 2009-01-09 |
| 383 |  | Evaluate Combined DM & Tip/Tilt Performance | 10d? | 2009-01-12 | 2009-01-23 |  | 301d | finish no earlier than 2009-01-23 |
| 384 |  | Select Tip/Tilt Mount | 5d? | 2009-01-26 | 2009-01-30 |  | 296d | finish no earlier than 2009-01-30 |
| 385 |  | Design Mechanical Package | 10d? | 2009-02-16 | 2009-02-27 |  | 276d | finish no earlier than 2009-02-27 |
| 386 |  | Obtain Quotes | 20d? | 2009-01-05 | 2009-01-30 |  | 296d | finish no earlier than 2009-01-30 |
| 387 | 1.3.4.5.2.2 | **Tweeter DM/TT** | 95d? | 2008-10-06 | 2009-02-13 |  | 286d |  |
| 388 |  | Define Requirements | 20d? | 2008-10-06 | 2008-10-31 |  | 361d | finish no earlier than 2008-10-31 |
| 389 |  | Evaluate Options & Select Tip/Tilt Mount | 20d? | 2008-11-03 | 2008-11-28 |  | 341d | finish no earlier than 2008-11-28 |
| 390 |  | Design Mechanical Package | 10d? | 2009-02-02 | 2009-02-13 |  | 286d | finish no earlier than 2009-02-13 |
| 391 |  | Obtain Quotes | 20d? | 2008-11-03 | 2008-11-28 |  | 341d | finish no earlier than 2008-11-28 |
| 392 | 1.3.4.5.2.3 | **LOWFS DM/TT** | 95d? | 2008-10-06 | 2009-02-13 |  | 286d |  |
| 393 |  | Define Requirements including LOWFS Interface | 20d? | 2008-10-06 | 2008-10-31 |  | 361d | finish no earlier than 2008-10-31 |
| 394 |  | Evaluate Options & Select Tip/Tilt Mount | 20d? | 2008-11-03 | 2008-11-28 |  | 341d | finish no earlier than 2008-11-28 |
| 395 |  | Design Mechanical Package | 25d? | 2009-01-12 | 2009-02-13 |  | 286d | finish no earlier than 2009-02-13 |
| 396 |  | Obtain Quotes | 20d? | 2008-11-03 | 2008-11-28 |  | 341d | finish no earlier than 2008-11-28 |
| 397 | 1.3.4.6 | **AO System Lab I&T** | 40d? | 2009-07-06 | 2009-08-28 |  | 146d |  |
| 398 |  | AO System Lab I&T Scope Definition | 10d? | 2009-07-06 | 2009-07-17 |  | 176d | finish no earlier than 2009-07-17 |
| 399 |  | AO System Lab Facility Plan | 30d? | 2009-07-20 | 2009-08-28 |  | 146d | finish no earlier than 2009-08-28 |
| 400 |  | AO System Lab Integration Plan | 30d? | 2009-07-20 | 2009-08-28 |  | 146d | finish no earlier than 2009-08-28 |
| 401 |  | AO System Lab Test Plan | 25d? | 2009-07-27 | 2009-08-28 |  | 146d | finish no earlier than 2009-08-28 |
| 402 | 1.3.5 | **Laser System Design** | 390d? | 2008-05-05 | 2009-10-30 |  | 101d |  |
| 403 | 1.3.5.1 | **Laser Enclosure (LE)** | 40d? | 2009-01-19 | 2009-03-13 |  | 266d |  |
| 404 |  | LE Requirements & Interfaces | 20d? | 2009-01-19 | 2009-02-13 |  | 286d | finish no earlier than 2009-02-13 |
| 405 |  | LE Mechanical Design | 10d? | 2009-02-16 | 2009-02-27 |  | 276d | finish no earlier than 2009-02-27 |
| 406 |  | LE Environmental Control Design | 10d? | 2009-02-16 | 2009-02-27 |  | 276d | finish no earlier than 2009-02-27 |
| 407 |  | LE Assembly & Test Plans | 10d? | 2009-03-02 | 2009-03-13 |  | 266d | finish no earlier than 2009-03-13 |
| 408 | 1.3.5.2 | **Laser** | 280d? | 2008-05-05 | 2009-05-29 |  | 211d |  |
| 409 |  | Laser Project Management | 280d? | 2008-05-05 | 2009-05-29 |  | 211d | finish no earlier than 2009-05-29 |
| 410 | 5.2.3.1 | **Laser Requirements** | 110d | 2008-05-05 | 2008-10-03 |  | 211d |  |
| 411 |  | Laser Performance Analysis | 20d | 2008-05-05 | 2008-05-30 |  | 211d | start no earlier than 2008-05-05 |
| 412 |  | Laser Requirements Analysis | 20d | 2008-06-02 | 2008-06-27 | 411 | 211d |  |
| 413 |  | Laser Requirements Development | 20d | 2008-06-30 | 2008-07-25 | 412 | 211d |  |
| 414 |  | Laser Requirements Drafting and Revisions | 50d | 2008-07-28 | 2008-10-03 | 413 | 211d |  |
| 415 | 5.2.3.2 | **Laser Preliminary ICD** | 20d | 2008-07-28 | 2008-08-22 |  | 411d |  |
| 416 |  | Laser ICD Drafting and Revisions | 20d | 2008-07-28 | 2008-08-22 | 413 | 411d |  |
| 417 | 5.2.3.3 | **Laser Request for Proposals (RFP)** | 90d | 2008-10-06 | 2009-02-06 |  | 211d |  |
| 418 |  | Laser Proposal Drafting | 20d | 2008-10-06 | 2008-10-31 | 414 | 211d |  |
| 419 |  | Laser Proposal Release | 10d | 2008-11-03 | 2008-11-14 | 418 | 211d |  |
| 420 |  | Laser Proposal Response Period | 3mo | 2008-11-17 | 2009-02-06 | 419 | 211d |  |

| ID | WBS | Task | Duration | Start | Finish | Predecessors | Total float | Constraint |
| --- | --- | --- | --- | --- | --- | --- | --- | --- |
| 421 | 5.2.3.4 | **Laser RFP Response Report** | 40d | 2009-02-09 | 2009-04-03 |  | 211d |  |
| 422 |  | Laser Proposal Evaluation | 20d | 2009-02-09 | 2009-03-06 | 420 | 211d |  |
| 423 |  | Laser Response Discussions | 20d | 2009-03-09 | 2009-04-03 | 422 | 251d |  |
| 424 |  | Laser Report Drafting and Revisions | 20d | 2009-03-09 | 2009-04-03 | 422 | 211d |  |
| 425 | 5.2.3.5 | **Laser Contract** | 40d | 2009-04-06 | 2009-05-29 |  | 211d |  |
| 426 |  | Laser Contract Drafting and Revisions | 20d | 2009-04-06 | 2009-05-01 | 424 | 211d |  |
| 427 |  | Laser Contract Negotiations | 20d | 2009-05-04 | 2009-05-29 | 426 | 211d |  |
| 428 | 1.3.5.3 | **Laser Launch Facility (LLF)** | 170d? | 2009-01-19 | 2009-09-11 |  | 136d |  |
| 429 |  | LLF Requirements & Interfaces | 20d? | 2009-01-19 | 2009-02-13 |  | 286d | finish no earlier than 2009-02-13 |
| 430 |  | LLF Optical Design | 53d? | 2009-04-01 | 2009-06-12 |  | 201d | finish no earlier than 2009-06-12 |
| 431 |  | LLF Launch Telescope Preliminary Design Contract | 100d? | 2009-03-16 | 2009-07-31 |  | 166d | start no earlier than 2009-03-16 |
| 432 |  | LLF Mechanical Design | 45d? | 2009-06-01 | 2009-07-31 |  | 166d | finish no earlier than 2009-07-31 |
| 433 |  | LLF Electrical Design | 30d? | 2009-07-20 | 2009-08-28 |  | 146d | finish no earlier than 2009-08-28 |
| 434 |  | LLF Assembly, Alignment & Test Plans | 10d? | 2009-08-31 | 2009-09-11 |  | 136d | finish no earlier than 2009-09-11 |
| 435 | 1.3.5.4 | **Laser Safety Systems** | 65d? | 2009-08-03 | 2009-10-30 |  | 101d |  |
| 436 | 1.3.5.4.1 | **Personnel & Equipment Safety System** | 43d? | 2009-08-03 | 2009-09-30 |  | 123d |  |
| 437 |  | Safety Requirements & Interfaces | 10d? | 2009-08-03 | 2009-08-14 |  | 156d | start no earlier than 2009-08-03 |
| 438 |  | Safety Algorithms, Diagrams & Dataflow | 33d? | 2009-08-17 | 2009-09-30 |  | 123d | start no earlier than 2009-08-17 |
| 439 |  | Safety Communication Protocols & Methods | 33d? | 2009-08-17 | 2009-09-30 |  | 123d | start no earlier than 2009-08-17 |
| 440 |  | Safety Performance Estimate | 33d? | 2009-08-17 | 2009-09-30 |  | 123d | start no earlier than 2009-08-17 |
| 441 |  | Safety Electronics, Shutter & Interlocks | 33d? | 2009-08-17 | 2009-09-30 |  | 123d | start no earlier than 2009-08-17 |
| 442 |  | Safety Test Plans | 33d? | 2009-08-17 | 2009-09-30 |  | 123d | start no earlier than 2009-08-17 |
| 443 | 1.3.5.4.2 | **Laser Traffic Control System (LTCS) Modifications** | 20d? | 2009-10-05 | 2009-10-30 |  | 101d |  |
| 444 |  | LTCS Requirements & Interfaces | 20d? | 2009-10-05 | 2009-10-30 |  | 101d | start no earlier than 2009-10-05 |
| 445 |  | LTCS Algorithms, Diagrams & Dataflow | 20d? | 2009-10-05 | 2009-10-30 |  | 101d | start no earlier than 2009-10-05 |
| 446 |  | LTCS Communication Protocols & Methods | 20d? | 2009-10-05 | 2009-10-30 |  | 101d | start no earlier than 2009-10-05 |
| 447 |  | LTCS Performance Estimate | 20d? | 2009-10-05 | 2009-10-30 |  | 101d | start no earlier than 2009-10-05 |
| 448 |  | LTCS Test Plans | 20d? | 2009-10-05 | 2009-10-30 |  | 101d | start no earlier than 2009-10-05 |
| 449 | 1.3.5.5 | **Laser System Control (LSC)** | 98.33d? | 2009-04-28 | 2009-09-11 |  | 136d |  |
| 450 | 1.3.5.5.1 | **LSC Software** | 53d? | 2009-07-01 | 2009-09-11 |  | 136d |  |
| 451 |  | LSC Software Requirements & Interfaces | 8d? | 2009-07-01 | 2009-07-10 |  | 181d | start no earlier than 2009-07-01 |
| 452 |  | LSC Sequencer Software | 40d? | 2009-07-13 | 2009-09-04 |  | 141d | finish no earlier than 2009-09-04 |
| 453 |  | LSC Motion Control Software | 30d? | 2009-07-20 | 2009-08-28 |  | 146d | finish no earlier than 2009-08-28 |
| 454 |  | LSC Device Control Software | 30d? | 2009-08-03 | 2009-09-11 |  | 136d | finish no earlier than 2009-09-11 |
| 455 | 1.3.5.5.2 | **LSC Hardware** | 33.33d? | 2009-04-28 | 2009-06-12 |  | 201d |  |
| 456 |  | LSC Hardware Requirements & Interfaces | 13.33d? | 2009-04-28 | 2009-05-15 |  | 221d | finish no earlier than 2009-05-15 |
| 457 |  | LSC Motion Control Hardware | 15d? | 2009-05-18 | 2009-06-05 |  | 206d | start no earlier than 2009-05-18 |
| 458 |  | LSC Device Control Hardware | 14.29d? | 2009-05-25 | 2009-06-12 |  | 201d | finish no earlier than 2009-06-12 |
| 459 |  | Laser System Lab I&T Plan | 20d? | 2009-10-05 | 2009-10-30 |  | 101d | finish no earlier than 2009-10-30 |
| 460 | 1.3.6 | **Science Operations Tools Design** | 349d? | 2008-07-01 | 2009-10-30 |  | 101d |  |
| 461 | 1.3.6.1 | **Multi-Systems Command Sequencer (MCS)** | 155d? | 2008-07-01 | 2009-02-02 |  | 295d |  |
| 462 | 1.3.6.1.1 | **MCS Infrastructure** | 80d? | 2008-07-07 | 2008-10-24 |  | 366d |  |
| 463 | 1.3.6.1.1.1 | **MCS Infrastructure Architecture** | 80d? | 2008-07-07 | 2008-10-24 |  | 366d |  |
| 464 |  | MCS Architecture | 80d? | 2008-07-07 | 2008-10-24 |  | 366d | finish no earlier than 2008-10-24 |
| 465 |  | MCS Operations Concept Document | 80d? | 2008-07-07 | 2008-10-24 |  | 366d | start no earlier than 2008-07-07 |
| 466 |  | MCS Software Requirements | 80d? | 2008-07-07 | 2008-10-24 |  | 366d | start no earlier than 2008-07-07 |
| 467 |  | MCS Module Definitions | 80d? | 2008-07-07 | 2008-10-24 |  | 366d | start no earlier than 2008-07-07 |
| 468 | 1.3.6.1.1.2 | **Coordination Sequence Support Library** | 80d? | 2008-07-07 | 2008-10-24 |  | 366d |  |
| 469 |  | Functional Requirements | 80d? | 2008-07-07 | 2008-10-24 |  | 366d | start no earlier than 2008-07-07 |
| 470 |  | Interface Definitions | 1d? | 2008-07-07 | 2008-07-07 |  | 445d | start no earlier than 2008-07-07 |
| 471 | 1.3.6.1.1.3 | **Command Interface** | 80d? | 2008-07-07 | 2008-10-24 |  | 366d |  |
| 472 |  | Functional Requirements | 80d? | 2008-07-07 | 2008-10-24 |  | 366d | start no earlier than 2008-07-07 |
| 473 |  | Interface Definitions | 1d? | 2008-07-07 | 2008-07-07 |  | 445d | finish no earlier than 2008-07-07 |
| 474 | 1.3.6.1.1.4 | **System Health** | 80d? | 2008-07-07 | 2008-10-24 |  | 366d |  |
| 475 |  | Functional Requirements | 80d? | 2008-07-07 | 2008-10-24 |  | 366d | start no earlier than 2008-07-07 |
| 476 |  | Interface Definitions | 1d? | 2008-07-07 | 2008-07-07 |  | 445d | start no earlier than 2008-07-07 |
| 477 | 1.3.6.1.2 | **Setup Sequences: Configuration & Calibration** | 89d? | 2008-07-01 | 2008-10-31 |  | 361d |  |
| 478 | 1.3.6.1.2.1 | **Setup Sequences Common Structure** | 89d? | 2008-07-01 | 2008-10-31 |  | 361d |  |
| 479 |  | Setup Sequences Operations Concept Document | 89d? | 2008-07-01 | 2008-10-31 |  | 361d | finish no earlier than 2008-10-31 |
| 480 |  | Setup Sequences Software Requirements | 89d? | 2008-07-01 | 2008-10-31 |  | 361d | finish no earlier than 2008-10-31 |
| 481 |  | Setup Sequences Module Definitions | 89d? | 2008-07-01 | 2008-10-31 |  | 361d | finish no earlier than 2008-10-31 |
| 482 | 1.3.6.1.2.2 | **Configuration Sequences** | 89d? | 2008-07-01 | 2008-10-31 |  | 361d |  |
| 483 |  | Functional Requirements | 89d? | 2008-07-01 | 2008-10-31 |  | 361d | finish no earlier than 2008-10-31 |
| 484 |  | Interface Definitions | 1d? | 2008-07-01 | 2008-07-01 |  | 449d | start no earlier than 2008-07-01 |
| 485 | 1.3.6.1.2.3 | **Calibration Sequences** | 89d? | 2008-07-01 | 2008-10-31 |  | 361d |  |
| 486 |  | Functional Requirements | 89d? | 2008-07-01 | 2008-10-31 |  | 361d | finish no earlier than 2008-10-31 |
| 487 |  | Interface Definitions | 1d? | 2008-07-01 | 2008-07-01 |  | 449d | start no earlier than 2008-07-01 |
| 488 | 1.3.6.1.3 | **Observing Sequences** | 89d? | 2008-10-01 | 2009-02-02 |  | 295d |  |
| 489 | 1.3.6.1.3.1 | **Observing Sequences Common Structure** | 89d? | 2008-10-01 | 2009-02-02 |  | 295d |  |
| 490 |  | Observing Sequences Operations Concept Document | 89d? | 2008-10-01 | 2009-02-02 |  | 295d | finish no earlier than 2009-02-02 |

| ID | WBS | Task | Duration | Start | Finish | Total float | Constraint |
| --- | --- | --- | --- | --- | --- | --- | --- |
| 491 |  | Observing Sequences Software Requirements | 89d? | 2008-10-01 | 2009-02-02 | 295d | start no earlier than 2008-10-01 |
| 492 |  | Observing Sequences Module Definitions | 89d? | 2008-10-01 | 2009-02-02 | 295d | finish no earlier than 2009-02-02 |
| 493 | 1.3.6.1.3.2 | **Acquisition Sequences** | 89d? | 2008-10-01 | 2009-02-02 | 295d |  |
| 494 |  | Functional Requirements | 89d? | 2008-10-01 | 2009-02-02 | 295d | finish no earlier than 2009-02-02 |
| 495 |  | Interface Definitions | 89d? | 2008-10-01 | 2009-02-02 | 295d | finish no earlier than 2009-02-02 |
| 496 | 1.3.6.1.3.3 | **Observing Sequences** | 89d? | 2008-10-01 | 2009-02-02 | 295d |  |
| 497 |  | Functional Requirements | 89d? | 2008-10-01 | 2009-02-02 | 295d | finish no earlier than 2009-02-02 |
| 498 |  | Interface Definitions | 1d? | 2008-10-01 | 2008-10-01 | 383d | start no earlier than 2008-10-01 |
| 499 | 1.3.6.1.3.4 | **Quality Monitoring Sequences** | 89d? | 2008-10-01 | 2009-02-02 | 295d |  |
| 500 |  | Functional Requirements | 89d? | 2008-10-01 | 2009-02-02 | 295d | finish no earlier than 2009-02-02 |
| 501 |  | Interface Definitions | 1d? | 2008-10-01 | 2008-10-01 | 383d | start no earlier than 2008-10-01 |
| 502 | 1.3.6.1.3.5 | **Optimization Sequences** | 89d? | 2008-10-01 | 2009-02-02 | 295d |  |
| 503 |  | Functional Requirements | 89d? | 2008-10-01 | 2009-02-02 | 295d | finish no earlier than 2009-02-02 |
| 504 |  | Interface Definitions | 1d? | 2008-10-01 | 2008-10-01 | 383d | start no earlier than 2008-10-01 |
| 505 | 1.3.6.1.4 | **Alarm Handler & Troubleshooting Sequences** | 89d? | 2008-10-01 | 2009-02-02 | 295d |  |
| 506 | 1.3.6.1.4.1 | **Alarm Handler & Troubleshooting Common Structure** | 89d? | 2008-10-01 | 2009-02-02 | 295d |  |
| 507 |  | Alarm & Troubleshooting Operations Concept Document | 89d? | 2008-10-01 | 2009-02-02 | 295d | finish no earlier than 2009-02-02 |
| 508 |  | Alarm & Troubleshooting Software Requirements | 89d? | 2008-10-01 | 2009-02-02 | 295d | finish no earlier than 2009-02-02 |
| 509 |  | Alarm & Troubleshooting Module Definitions | 89d? | 2008-10-01 | 2009-02-02 | 295d | finish no earlier than 2009-02-02 |
| 510 | 1.3.6.1.4.2 | **Alarm Handler Sequences** | 1d? | 2008-10-01 | 2008-10-01 | 383d |  |
| 511 |  | Functional Requirements | 1d? | 2008-10-01 | 2008-10-01 | 383d | start no earlier than 2008-10-01 |
| 512 |  | Interface Definitions | 1d? | 2008-10-01 | 2008-10-01 | 383d | start no earlier than 2008-10-01 |
| 513 | 1.3.6.1.4.3 | **Troubleshooting Sequences** | 1d? | 2008-10-01 | 2008-10-01 | 383d |  |
| 514 |  | Functional Requirements | 1d? | 2008-10-01 | 2008-10-01 | 383d | start no earlier than 2008-10-01 |
| 515 |  | Interface Definitions | 1d? | 2008-10-01 | 2008-10-01 | 383d | start no earlier than 2008-10-01 |
| 516 | 1.3.6.2 | **User Interfaces** | 239d? | 2008-07-01 | 2009-05-29 | 211d |  |
| 517 | 1.3.6.2.1 | **User Interface (UI) Infrastructure** | 89d? | 2008-07-01 | 2008-10-31 | 361d |  |
| 518 | 1.3.6.2.1.1 | **UI Infrastructure Architecture** | 89d? | 2008-07-01 | 2008-10-31 | 361d |  |
| 519 |  | UI Architecture | 89d? | 2008-07-01 | 2008-10-31 | 361d | finish no earlier than 2008-10-31 |
| 520 |  | UI Operations Concept Document | 89d? | 2008-07-01 | 2008-10-31 | 361d | finish no earlier than 2008-10-31 |
| 521 |  | UI Software Requirements | 89d? | 2008-07-01 | 2008-10-31 | 361d | finish no earlier than 2008-10-31 |
| 522 |  | UI Module Definitions | 89d? | 2008-07-01 | 2008-10-31 | 361d | finish no earlier than 2008-10-31 |
| 523 | 1.3.6.2.1.2 | **UI Command Interface to MCS** | 89d? | 2008-07-01 | 2008-10-31 | 361d |  |
| 524 |  | Functional Requirements | 89d? | 2008-07-01 | 2008-10-31 | 361d | finish no earlier than 2008-10-31 |
| 525 |  | Interface Definitions | 89d? | 2008-07-01 | 2008-10-31 | 361d | finish no earlier than 2008-10-31 |
| 526 | 1.3.6.2.1.3 | **UI Command Interface to Pre- & Post-Observing Tools** | 89d? | 2008-07-01 | 2008-10-31 | 361d |  |
| 527 |  | Functional Requirements | 89d? | 2008-07-01 | 2008-10-31 | 361d | finish no earlier than 2008-10-31 |
| 528 |  | Interface Definitions | 89d? | 2008-07-01 | 2008-10-31 | 361d | finish no earlier than 2008-10-31 |
| 529 | 1.3.6.2.2 | **Setup User Interfaces** | 130d? | 2008-10-01 | 2009-03-31 | 254d |  |
| 530 | 1.3.6.2.2.1 | **Setup UI Common Structure** | 130d? | 2008-10-01 | 2009-03-31 | 254d |  |
| 531 |  | Setup UI Operations Concept Document | 130d? | 2008-10-01 | 2009-03-31 | 254d | start no earlier than 2008-10-01 |
| 532 |  | Setup UI Software Requirements | 130d? | 2008-10-01 | 2009-03-31 | 254d | finish no earlier than 2009-03-31 |
| 533 |  | Setup UI Module Definitions | 130d? | 2008-10-01 | 2009-03-31 | 254d | finish no earlier than 2009-03-31 |
| 534 | 1.3.6.2.2.2 | **Setup UI Configurations** | 130d? | 2008-10-01 | 2009-03-31 | 254d |  |
| 535 |  | Functional Requirements | 130d? | 2008-10-01 | 2009-03-31 | 254d | finish no earlier than 2009-03-31 |
| 536 |  | Interface Definitions | 130d? | 2008-10-01 | 2009-03-31 | 254d | finish no earlier than 2009-03-31 |
| 537 | 1.3.6.2.2.3 | **Setup UI Calibrations** | 130d? | 2008-10-01 | 2009-03-31 | 254d |  |
| 538 |  | Functional Requirements | 130d? | 2008-10-01 | 2009-03-31 | 254d | finish no earlier than 2009-03-31 |
| 539 |  | Interface Definitions | 130d? | 2008-10-01 | 2009-03-31 | 254d | finish no earlier than 2009-03-31 |
| 540 | 1.3.6.2.3 | **Observations User Interfaces** | 173d? | 2008-10-01 | 2009-05-29 | 211d |  |
| 541 | 1.3.6.2.3.1 | **Observations UI Common Structure** | 173d? | 2008-10-01 | 2009-05-29 | 211d |  |
| 542 |  | Observations UI Operations Concept Document | 173d? | 2008-10-01 | 2009-05-29 | 211d | finish no earlier than 2009-05-29 |
| 543 |  | Observations UI Software Requirements | 173d? | 2008-10-01 | 2009-05-29 | 211d | finish no earlier than 2009-05-29 |
| 544 |  | Observations UI Module Definitions | 173d? | 2008-10-01 | 2009-05-29 | 211d | finish no earlier than 2009-05-29 |
| 545 | 1.3.6.2.3.2 | **Acquisition & AO Control UI** | 173d? | 2008-10-01 | 2009-05-29 | 211d |  |
| 546 |  | Functional Requirements | 173d? | 2008-10-01 | 2009-05-29 | 211d | finish no earlier than 2009-05-29 |
| 547 |  | Interface Definitions | 173d? | 2008-10-01 | 2009-05-29 | 211d | finish no earlier than 2009-05-29 |
| 548 | 1.3.6.2.3.3 | **Observing Sequences UI** | 173d? | 2008-10-01 | 2009-05-29 | 211d |  |
| 549 |  | Functional Requirements | 173d? | 2008-10-01 | 2009-05-29 | 211d | finish no earlier than 2009-05-29 |
| 550 |  | Interface Definitions | 173d? | 2008-10-01 | 2009-05-29 | 211d | finish no earlier than 2009-05-29 |
| 551 | 1.3.6.2.3.4 | **Status & Graph UI** | 173d? | 2008-10-01 | 2009-05-29 | 211d |  |
| 552 |  | Functional Requirements | 173d? | 2008-10-01 | 2009-05-29 | 211d | finish no earlier than 2009-05-29 |
| 553 |  | Interface Definitions | 173d? | 2008-10-01 | 2009-05-29 | 211d | finish no earlier than 2009-05-29 |
| 554 | 1.3.6.2.3.5 | **Advanced Monitoring UI** | 173d? | 2008-10-01 | 2009-05-29 | 211d |  |
| 555 |  | Functional Requirements | 173d? | 2008-10-01 | 2009-05-29 | 211d | finish no earlier than 2009-05-29 |
| 556 |  | Interface Definitions | 173d? | 2008-10-01 | 2009-05-29 | 211d | finish no earlier than 2009-05-29 |
| 557 | 1.3.6.2.3.6 | **Optimization & Troubleshooting UI** | 173d? | 2008-10-01 | 2009-05-29 | 211d |  |
| 558 |  | Functional Requirements | 173d? | 2008-10-01 | 2009-05-29 | 211d | finish no earlier than 2009-05-29 |
| 559 |  | Interface Definitions | 173d? | 2008-10-01 | 2009-05-29 | 211d | finish no earlier than 2009-05-29 |
| 560 | 1.3.6.3 | **Pre- & Post-Observing Science Support Tools** | 217d? | 2009-01-01 | 2009-10-30 | 101d |  |

| ID | WBS | Task | Duration | Start | Finish | Total float | Constraint |
| --- | --- | --- | --- | --- | --- | --- | --- |
| 561 | 1.3.6.3.1 | **User Documentation** | 174d? | 2009-01-01 | 2009-09-01 | 144d |  |
| 562 |  | User Documentation Operations Concept | 174d? | 2009-01-01 | 2009-09-01 | 144d | finish no earlier than 2009-09-01 |
| 563 |  | User Documentation Functional Requirements | 174d? | 2009-01-01 | 2009-09-01 | 144d | finish no earlier than 2009-09-01 |
| 564 | 1.3.6.3.2 | **Science Observations Planning Tools** | 148d? | 2009-01-07 | 2009-07-31 | 166d |  |
| 565 | 1.3.6.3.2.1 | **NGS Star Finder** | 148d? | 2009-01-07 | 2009-07-31 | 166d |  |
| 566 |  | Operations Concept | 148d? | 2009-01-07 | 2009-07-31 | 166d | finish no earlier than 2009-07-31 |
| 567 |  | Functional Requirements & Use Case Definitions | 148d? | 2009-01-07 | 2009-07-31 | 166d | finish no earlier than 2009-07-31 |
| 568 |  | Interface Definitions | 148d? | 2009-01-07 | 2009-07-31 | 166d | finish no earlier than 2009-07-31 |
| 569 |  | Module Definitions | 148d? | 2009-01-07 | 2009-07-31 | 166d | finish no earlier than 2009-07-31 |
| 570 | 1.3.6.3.2.2 | **Performance Prediction Tool** | 148d? | 2009-01-07 | 2009-07-31 | 166d |  |
| 571 |  | Operations Concept | 148d? | 2009-01-07 | 2009-07-31 | 166d | finish no earlier than 2009-07-31 |
| 572 |  | Functional Requirements & Use Case Definitions | 148d? | 2009-01-07 | 2009-07-31 | 166d | finish no earlier than 2009-07-31 |
| 573 |  | Interface Definitions | 148d? | 2009-01-07 | 2009-07-31 | 166d | finish no earlier than 2009-07-31 |
| 574 |  | Module Definitions | 148d? | 2009-01-07 | 2009-07-31 | 166d | finish no earlier than 2009-07-31 |
| 575 | 1.3.6.3.2.3 | **Observation Planning & Efficiency Tool** | 148d? | 2009-01-07 | 2009-07-31 | 166d |  |
| 576 |  | Operations Concept | 148d? | 2009-01-07 | 2009-07-31 | 166d | finish no earlier than 2009-07-31 |
| 577 |  | Functional Requirements & Use Case Definitions | 148d? | 2009-01-07 | 2009-07-31 | 166d | finish no earlier than 2009-07-31 |
| 578 |  | Interface Definitions | 148d? | 2009-01-07 | 2009-07-31 | 166d | finish no earlier than 2009-07-31 |
| 579 |  | Module Definitions | 148d? | 2009-01-07 | 2009-07-31 | 166d | finish no earlier than 2009-07-31 |
| 580 | 1.3.6.3.2.4 | **Laser Clearinghouse Coordination Tool** | 148d? | 2009-01-07 | 2009-07-31 | 166d |  |
| 581 |  | Operations Concept | 148d? | 2009-01-07 | 2009-07-31 | 166d | finish no earlier than 2009-07-31 |
| 582 |  | Functional Requirements & Use Case Definitions | 148d? | 2009-01-07 | 2009-07-31 | 166d | finish no earlier than 2009-07-31 |
| 583 |  | Interface Definitions | 148d? | 2009-01-07 | 2009-07-31 | 166d | finish no earlier than 2009-07-31 |
| 584 |  | Module Definitions | 148d? | 2009-01-07 | 2009-07-31 | 166d | finish no earlier than 2009-07-31 |
| 585 | 1.3.6.3.3 | **Data Products** | 195d? | 2009-02-02 | 2009-10-30 | 101d |  |
| 586 | 1.3.6.3.3.1 | **Generic Data Products** | 152d? | 2009-02-02 | 2009-09-01 | 144d |  |
| 587 |  | Operations Concept | 152d? | 2009-02-02 | 2009-09-01 | 144d | finish no earlier than 2009-09-01 |
| 588 |  | Functional Requirements & Use Case Definitions | 152d? | 2009-02-02 | 2009-09-01 | 144d | finish no earlier than 2009-09-01 |
| 589 |  | Interface Definitions | 152d? | 2009-02-02 | 2009-09-01 | 144d | finish no earlier than 2009-09-01 |
| 590 | 1.3.6.3.3.2 | **Science Data Quality Assessment** | 195d? | 2009-02-02 | 2009-10-30 | 101d |  |
| 591 | 1.3.6.3.3.2.1 | **Quality Metrics & Logged Information** | 152d? | 2009-02-02 | 2009-09-01 | 144d |  |
| 592 |  | Operations Concept | 152d? | 2009-02-02 | 2009-09-01 | 144d | finish no earlier than 2009-09-01 |
| 593 |  | Functional Requirements & Use Case Definitions | 152d? | 2009-02-02 | 2009-09-01 | 144d | finish no earlier than 2009-09-01 |
| 594 |  | Interface Definitions | 152d? | 2009-02-02 | 2009-09-01 | 144d | finish no earlier than 2009-09-01 |
| 595 | 1.3.6.3.3.2.2 | **PSF Calibration** | 195d? | 2009-02-02 | 2009-10-30 | 101d |  |
| 596 |  | Operations Concept | 195d? | 2009-02-02 | 2009-10-30 | 101d | finish no earlier than 2009-10-30 |
| 597 |  | Functional Requirements & Use Case Definitions | 195d? | 2009-02-02 | 2009-10-30 | 101d | finish no earlier than 2009-10-30 |
| 598 |  | Interface Definitions | 195d? | 2009-02-02 | 2009-10-30 | 101d | finish no earlier than 2009-10-30 |
| 599 |  | Module Definitions | 195d? | 2009-02-02 | 2009-10-30 | 101d | finish no earlier than 2009-10-30 |
| 600 | 1.3.6.3.3.3 | **Science Data Archiving** | 195d? | 2009-02-02 | 2009-10-30 | 101d |  |
| 601 |  | Operations Concept | 195d? | 2009-02-02 | 2009-10-30 | 101d | finish no earlier than 2009-10-30 |
| 602 |  | Functional Requirements & Use Case Definitions | 195d? | 2009-02-02 | 2009-10-30 | 101d | finish no earlier than 2009-10-30 |
| 603 |  | Interface Definitions | 195d? | 2009-02-02 | 2009-10-30 | 101d | finish no earlier than 2009-10-30 |
| 604 | 1.3.6.4 | **Data Server** | 195d? | 2009-02-02 | 2009-10-30 | 101d |  |
| 605 |  | Data Server: Architecture | 195d? | 2009-02-02 | 2009-10-30 | 101d | finish no earlier than 2009-10-30 |
| 606 |  | Data Server: HW & SW Specification & Selection | 195d? | 2009-02-02 | 2009-10-30 | 101d | finish no earlier than 2009-10-30 |
| 607 |  | Data Server: Software Design | 0d? | 2009-02-02 | 2009-02-02 | 296d | start no earlier than 2009-02-02 |
| 608 |  | Data Server: Compliance Matrix | 0d? | 2009-02-02 | 2009-02-02 | 296d | start no earlier than 2009-02-02 |
| 609 |  | Data Server: Test Plan | 0d? | 2009-02-02 | 2009-02-02 | 296d | start no earlier than 2009-02-02 |
| 610 |  | Data Server: Summary Report | 195d? | 2009-02-02 | 2009-10-30 | 101d | finish no earlier than 2009-10-30 |
| 611 | 1.3.7 | **Telescope & Summit Engineering Design** | 215d? | 2008-12-08 | 2009-10-02 | 121d |  |
| 612 |  | Telescope Performance | 1d? | 2009-05-04 | 2009-05-04 | 230d | start no earlier than 2009-05-04 |
| 613 | 1.3.7.2 | **Infrastructure Modifications for AO** | 110d? | 2009-05-04 | 2009-10-02 | 121d |  |
| 614 |  | Infrastructure Requirements & Interfaces | 20d? | 2009-05-04 | 2009-05-29 | 211d | finish no earlier than 2009-05-29 |
| 615 |  | Infrastructure Mechanical Modifications | 45d? | 2009-06-01 | 2009-07-31 | 166d | finish no earlier than 2009-07-31 |
| 616 |  | Infrastructure Electrical Modifications | 45d? | 2009-07-06 | 2009-09-04 | 141d | finish no earlier than 2009-09-04 |
| 617 |  | Infrastructure Glycol Cooling Modifications | 45d? | 2009-07-13 | 2009-09-11 | 136d | finish no earlier than 2009-09-11 |
| 618 |  | Infrastructure CCR Modifications | 45d? | 2009-07-13 | 2009-09-11 | 136d | finish no earlier than 2009-09-11 |
| 619 |  | Infrastructure Implementation & Test Plans | 25d? | 2009-08-31 | 2009-10-02 | 121d | finish no earlier than 2009-10-02 |
| 620 | 1.3.7.3 | **Infrastructure modifications for Laser System** | 110d? | 2009-05-04 | 2009-10-02 | 121d |  |
| 621 |  | Infrastructure Requirements & Interfaces | 20d? | 2009-05-04 | 2009-05-29 | 211d | finish no earlier than 2009-05-29 |
| 622 |  | Infrastructure Mechanical Modifications | 45d? | 2009-06-29 | 2009-08-28 | 146d | finish no earlier than 2009-08-28 |
| 623 |  | Infrastructure Electrical Modifications | 45d? | 2009-07-06 | 2009-09-04 | 141d | finish no earlier than 2009-09-04 |
| 624 |  | Infrastructure Glycol Cooling Modifications | 45d? | 2009-07-13 | 2009-09-11 | 136d | finish no earlier than 2009-09-11 |
| 625 |  | Infrastructure Implementation & Test Plans | 25d? | 2009-08-31 | 2009-10-02 | 121d | finish no earlier than 2009-10-02 |
| 626 |  | OSIRIS Modifications | 15d? | 2009-01-12 | 2009-01-30 | 296d | start no earlier than 2009-01-12 |
| 627 | 1.3.7.5 | **Interferometer Modifications** | 40d? | 2008-12-08 | 2009-01-30 | 296d |  |
| 628 |  | Optical Design of Post Field Selector Optics | 40d? | 2008-12-08 | 2009-01-30 | 296d | finish no earlier than 2009-01-30 |
| 629 |  | Evaluation of Optical Design Impact on Interferometer | 40d? | 2008-12-08 | 2009-01-30 | 296d | start no earlier than 2008-12-08 |
| 630 | 1.3.8 | **Telescope Integration & Test** | 55d? | 2009-10-05 | 2009-12-18 | 66d |  |

| ID | WBS | Task | Duration | Start | Finish | Total float | Constraint |
| --- | --- | --- | --- | --- | --- | --- | --- |
| 631 | 1.3.8.1 | **Old AO/Laser Removal** | 20d? | 2009-10-05 | 2009-10-30 | 101d |  |
| 632 |  | AO Removal Plan | 20d? | 2009-10-05 | 2009-10-30 | 101d | start no earlier than 2009-10-05 |
| 633 |  | Laser Removal Plan | 20d? | 2009-10-05 | 2009-10-30 | 101d | start no earlier than 2009-10-05 |
| 634 |  | Laser Enclosure Integration | 1d? | 2009-10-05 | 2009-10-05 | 120d | start no earlier than 2009-10-05 |
| 635 |  | AO Enclosure Integration | 1d? | 2009-10-05 | 2009-10-05 | 120d | start no earlier than 2009-10-05 |
| 636 | 1.3.8.4 | **AO System Install + I&T** | 35d? | 2009-11-02 | 2009-12-18 | 66d |  |
| 637 |  | Opto-Mechanical Integration Plan | 27d? | 2009-11-02 | 2009-12-08 | 74d | start no earlier than 2009-11-02 |
| 638 |  | Electronics Integration Plan | 35d? | 2009-11-02 | 2009-12-18 | 66d | start no earlier than 2009-11-02 |
| 639 |  | Computer Integration Plan | 35d? | 2009-11-02 | 2009-12-18 | 66d | start no earlier than 2009-11-02 |
| 640 |  | AO System Integration Plan | 35d? | 2009-11-02 | 2009-12-18 | 66d | start no earlier than 2009-11-02 |
| 641 |  | AO System Test Plan | 35d? | 2009-11-02 | 2009-12-18 | 66d | start no earlier than 2009-11-02 |
| 642 | 1.3.8.5 | **Laser System Install + I&T** | 35d? | 2009-11-02 | 2009-12-18 | 66d |  |
| 643 |  | Laser System Installation & Integration Plan | 35d? | 2009-11-02 | 2009-12-18 | 66d | finish no earlier than 2009-12-18 |
| 644 |  | Laser System Test Plan | 35d? | 2009-11-02 | 2009-12-18 | 66d | start no earlier than 2009-11-02 |
| 645 |  | LGS AO System On-sky I&T Plan | 10d? | 2009-11-02 | 2009-11-13 | 91d | finish no earlier than 2009-11-13 |
| 646 |  | Performance Characterization | 1d? | 2009-11-02 | 2009-11-02 | 100d | start no earlier than 2009-11-02 |
| 647 |  | Science Verification Plan | 20d? | 2009-11-02 | 2009-11-27 | 81d | finish no earlier than 2009-11-27 |
| 648 | 1.3.9 | **Operations Transition** | 232d? | 2009-01-09 | 2009-11-30 | 80d |  |
| 649 | 1.3.9.1 | **Operations Plans** | 65d? | 2009-09-01 | 2009-11-30 | 80d |  |
| 650 |  | Operations Support Plan | 65d? | 2009-09-01 | 2009-11-30 | 80d | finish no earlier than 2009-11-30 |
| 651 |  | Operations Maintenance & Spares Plan Template | 65d? | 2009-09-01 | 2009-11-30 | 80d | start no earlier than 2009-09-01 |
| 652 | 1.3.9.2 | **Operations Handover** | 232d? | 2009-01-09 | 2009-11-30 | 80d |  |
| 653 |  | Operations Personnel Training Plan | 65d? | 2009-09-01 | 2009-11-30 | 80d | finish no earlier than 2009-11-30 |
| 654 |  | Documentation Transition Plan | 232d? | 2009-01-09 | 2009-11-30 | 80d | finish no earlier than 2009-11-30 |

## Version 2 (saved 2008-07-16, file NGAO_Design_v14_tracked_Jun08.mpp)

Last finish stays 2010-03-22. Complete tasks 1 → 3.

Changed:

| ID | Task | Start | Finish | Complete | Total float |
| --- | --- | --- | --- | --- | --- |
| 1 | **NGAO Design** |  |  | 1% → 2% |  |
| 4 | **Preliminary Design** |  |  | 1% → 2% |  |
| 6 | **PD Phase Management** |  |  | 3% → 6% |  |
| 25 | **Project Management & Meetings** |  |  | 3% → 9% |  |
| 26 | **Executive Committee** |  |  | 5% → 8% |  |
| 27 | Executive Committee Management Activities |  |  | 5% → 8% |  |
| 28 | Executive Committee Telecons |  |  | 5% → 8% |  |
| 29 | **Team Meetings** | 2008-05-01 A |  | 0% → 10% |  |
| 30 | Meeting Participation | 2008-05-01 A |  | 0% → 10% | 16d → 0d |
| 57 | **Tracking & Reporting** |  |  | 0% → 6% |  |
| 58 | **Monthly Status Reports** | 2008-05-01 A |  | 0% → 6% |  |
| 59 | Monthly Team Status Reports | 2008-05-01 A |  | 0% → 7% | 16d → 0d |
| 60 | Monthly Project Reports (TSIP, Directors) | 2008-05-15 A |  | 0% → 5% |  |
| 61 | TSIP Project Report Telecons | 2008-05-20 A |  | 0% → 5% |  |
| 62 | **SSC Meetings** | 2008-04-30 A |  | 0% → 13% |  |
| 64 | SSC Meeting (Keck) | 2008-06-18 A | 2008-06-19 A | 0% → 100% | 457.88d → none |
| 71 | **Other Presentations** |  |  | 3% → 7% |  |
| 72 | SPIE AO Conference Presentations/Papers |  | 2008-06-20 A | 50% → 100% | 456d → none |
| 81 | **Programmatic Risk Assessment & Mitigation** |  |  | 4% → 7% |  |
| 85 | **Risk Mitigation** |  |  | 4% → 7% |  |
| 86 | Laser Procurement |  |  | 5% → 10% |  |
| 100 | **Project Support** |  |  | 4% → 5% |  |
| 103 | Research Time |  |  | 5% → 7% |  |
| 104 | **Systems Engineering** |  |  | 0% → 3% |  |
| 105 | **Science Case Requirements** | 2008-05-01 A |  | 0% → 4% |  |
| 106 | **Science Case Requirements** | 2008-05-01 A |  | 0% → 8% |  |
| 107 | **Requirements for new Science Drivers** | 2008-05-01 A |  | 0% → 32% |  |
| 108 | Astrometry Science in Sparse Fields | 2008-10-06 A |  | 0% → 50% |  |
| 109 | Resolved Stellar Populations in Crowded Fields | 2008-07-14 A |  | 0% → 50% |  |
| 110 | Debris Disks & Young Stellar Objects | 2008-07-14 A |  | 0% → 10% |  |
| 111 | QSO Host Galaxies | 2008-05-01 A |  | 0% → 13% |  |
| 112 | **Extend SCRD Discussion of Science Drivers** | 2008-05-01 A |  | 0% → 6% |  |
| 113 | Nearby AGNs | 2008-05-01 A |  | 0% → 13% |  |
| 114 | Gravitational Lensing | 2008-05-01 A |  | 0% → 36% |  |
| 118 | Extrasolar Planets | 2008-10-06 A |  | 0% → 14% |  |
| 122 | **Characterize PSF Stability, Knowledge & Subtraction Requirements** | 2008-10-06 A |  | 0% → 1% |  |
| 123 | Nearby AGNs | 2008-10-06 A |  | 0% → 3% |  |
| 128 | Characterize Sensitivity & Background Requirements | 2009-01-12 A |  | 0% → 25% |  |
| 134 | **Science Performance Input** | 2008-10-06 A |  | 0% → 1% |  |
| 135 | Define Science Driver Parameters for Performance Budgets | 2008-10-13 A |  | 0% → 50% |  |
| 142 | **User Community Liaison** | 2008-05-19 A |  | 0% → 6% |  |
| 143 | Enlist People to work on new NGAO Science Aspects | 2008-05-19 A |  | 0% → 7% |  |
| 144 | **SSC & Keck Science Meeting** | 2008-06-02 A |  | 0% → 5% |  |
| 145 | Prepare & Give Presentations | 2008-06-02 A |  | 0% → 10% |  |
| 165 | **Systems Engineering Analysis** |  |  | 2% → 5% |  |
| 189 | **Modeling & Analysis** |  |  | 8% → 23% |  |
| 190 | T/T Sharpening Study Report |  |  | 25% → 75% |  |
| 402 | **Laser System Design** | 2008-05-05 A |  | 0% → 2% |  |
| 408 | **Laser** | 2008-05-05 A |  | 0% → 5% |  |
| 409 | Laser Project Management | 2008-05-05 A |  | 0% → 10% |  |

## Version 3 (saved 2008-08-20, file NGAO_Design_v14_tracked_Jul08.mpp)

Last finish stays 2010-03-22.

Changed:

| ID | Task | Start | Complete |
| --- | --- | --- | --- |
| 1 | **NGAO Design** |  | 2% → 3% |
| 4 | **Preliminary Design** |  | 2% → 3% |
| 6 | **PD Phase Management** |  | 6% → 10% |
| 7 | **Planning** |  | 8% → 9% |
| 8 | **Replans (PD phase)** |  | 12% → 17% |
| 9 | Replan based on SDR |  | 50% → 75% |
| 25 | **Project Management & Meetings** |  | 9% → 14% |
| 26 | **Executive Committee** |  | 8% → 15% |
| 27 | Executive Committee Management Activities |  | 8% → 15% |
| 28 | Executive Committee Telecons |  | 8% → 15% |
| 29 | **Team Meetings** |  | 10% → 13% |
| 30 | Meeting Participation |  | 10% → 13% |
| 57 | **Tracking & Reporting** |  | 6% → 11% |
| 58 | **Monthly Status Reports** |  | 6% → 11% |
| 59 | Monthly Team Status Reports |  | 7% → 14% |
| 60 | Monthly Project Reports (TSIP, Directors) |  | 5% → 10% |
| 61 | TSIP Project Report Telecons |  | 5% → 10% |
| 81 | **Programmatic Risk Assessment & Mitigation** |  | 7% → 11% |
| 85 | **Risk Mitigation** |  | 7% → 11% |
| 86 | Laser Procurement |  | 10% → 15% |
| 100 | **Project Support** |  | 5% → 9% |
| 101 | Administrative/Contract Support |  | 7% → 14% |
| 102 | Shared Infrastructure | 2008-07-07 A | 0% → 2% |
| 103 | Research Time |  | 7% → 10% |
| 104 | **Systems Engineering** |  | 3% → 5% |
| 105 | **Science Case Requirements** |  | 4% → 7% |
| 131 | **Science Observing Planning & Execution** | 2008-08-04 A | 0% → 2% |
| 132 | Key Science Driver Observing Scenarios | 2008-08-04 A | 0% → 3% |
| 134 | **Science Performance Input** |  | 1% → 3% |
| 137 | Input to Preliminary Operations Concept Document | 2008-12-01 A | 0% → 5% |
| 138 | **Science Competitiveness** | 2008-07-07 A | 0% → 15% |
| 139 | Update List of Science Goals for Other Facilities | 2008-07-07 A | 0% → 25% |
| 140 | Evaluate NGAO Potential to Compliment Other Facilities | 2008-07-07 A | 0% → 8% |
| 141 | Define NGAO Uniqueness Space | 2008-07-07 A | 0% → 13% |
| 151 | **Requirements** |  | 1% → 3% |
| 152 | **Operations Concept Document (OCD)** |  | 2% → 7% |
| 153 | OCD Outline |  | 25% → 70% |
| 154 | OCD Release 1 | 2008-12-01 A | 0% → 2% |
| 165 | **Systems Engineering Analysis** |  | 5% → 6% |
| 189 | **Modeling & Analysis** |  | 23% → 26% |
| 190 | T/T Sharpening Study Report |  | 75% → 85% |
| 195 | **System Architecture** | 2008-05-05 A | 0% → 1% |
| 196 | **System Hardware Architecture** | 2008-06-02 A | 0% → 3% |
| 197 | Hybrid Rayleigh / Sodium Trade Study | 2008-06-30 A | 0% → 25% |
| 236 | **Technical Risk Assessment & Mitigation** | 2008-09-15 A | 0% → 2% |
| 240 | **Risk Mitigation Efforts** | 2008-09-15 A | 0% → 2% |
| 241 | **PSF Calibration** | 2008-09-15 A | 0% → 5% |
| 242 | Support/Monitor Profiler Implementation | 2008-09-15 A | 0% → 5% |
| 248 | **Opto-Mechanical** |  | 2% → 3% |
| 286 | **Tip/Tilt Vibration Mitigation** | 2008-07-07 A | 0% → 10% |
| 287 | TT Vibration Mitigation Analysis | 2008-07-07 A | 0% → 10% |

## Version 4 (saved 2008-09-26, file NGAO_Design_v14_tracked_Aug08.mpp)

Last finish stays 2010-03-22. Complete tasks 3 → 4.

Changed:

| ID | Task | Start | Finish | Complete | Total float |
| --- | --- | --- | --- | --- | --- |
| 1 | **NGAO Design** |  |  | 3% → 4% |  |
| 4 | **Preliminary Design** |  |  | 3% → 5% |  |
| 6 | **PD Phase Management** |  |  | 10% → 13% |  |
| 8 | **Replans (PD phase)** |  |  | 17% → 20% |  |
| 9 | Replan based on SDR |  |  | 75% → 85% |  |
| 25 | **Project Management & Meetings** |  |  | 14% → 20% |  |
| 26 | **Executive Committee** |  |  | 15% → 20% |  |
| 27 | Executive Committee Management Activities |  |  | 15% → 20% |  |
| 28 | Executive Committee Telecons |  |  | 15% → 20% |  |
| 29 | **Team Meetings** |  |  | 13% → 19% |  |
| 30 | Meeting Participation |  |  | 13% → 19% |  |
| 34 | Team Meeting #4 (telecon) | 2008-08-15 A | 2008-08-15 A | 0% → 100% | 417d → none |
| 57 | **Tracking & Reporting** |  |  | 11% → 15% |  |
| 58 | **Monthly Status Reports** |  |  | 11% → 17% |  |
| 59 | Monthly Team Status Reports |  |  | 14% → 19% |  |
| 60 | Monthly Project Reports (TSIP, Directors) |  |  | 10% → 15% |  |
| 61 | TSIP Project Report Telecons |  |  | 10% → 15% |  |
| 81 | **Programmatic Risk Assessment & Mitigation** |  |  | 11% → 12% |  |
| 85 | **Risk Mitigation** |  |  | 11% → 12% |  |
| 88 | Funding | 2008-05-19 A |  | 0% → 5% |  |
| 104 | **Systems Engineering** |  |  | 5% → 7% |  |
| 105 | **Science Case Requirements** |  |  | 7% → 9% |  |
| 106 | **Science Case Requirements** |  |  | 8% → 10% |  |
| 128 | Characterize Sensitivity & Background Requirements |  |  | 25% → 44% |  |
| 138 | **Science Competitiveness** |  |  | 15% → 27% |  |
| 139 | Update List of Science Goals for Other Facilities |  |  | 25% → 40% |  |
| 140 | Evaluate NGAO Potential to Compliment Other Facilities |  |  | 8% → 28% |  |
| 151 | **Requirements** |  |  | 3% → 4% |  |
| 152 | **Operations Concept Document (OCD)** |  |  | 7% → 10% |  |
| 153 | OCD Outline |  |  | 70% → 90% |  |
| 154 | OCD Release 1 |  |  | 2% → 5% |  |
| 200 | **Software Architecture** | 2008-07-28 A |  |  |  |
| 201 | Evaluate Software Architecture Options | 2008-07-28 A |  | 0% → 2% |  |
| 204 | **Control Systems Architecture** | 2008-10-01 A |  |  |  |
| 205 | Evaluate Control Systems Arch Options | 2008-10-01 A |  | 0% → 2% |  |
| 359 | **Real-time Control** | 2008-05-12 A |  | 0% → 2% |  |
| 360 | **RTC Processor** | 2008-05-12 A |  | 0% → 2% |  |
| 361 | RTC Technical Management | 2008-05-12 A |  | 0% → 5% |  |
| 362 | Centroid/Wavefront Reconstruction Processing Requirements | 2008-05-12 A |  | 0% → 5% |  |

## Version 5 (saved 2008-10-14, file NGAO_Design_v14_tracked_Sept08.mpp)

Last finish stays 2010-03-22. Complete tasks 4 → 5.

Changed:

| ID | Task | Start | Finish | Complete | Total float |
| --- | --- | --- | --- | --- | --- |
| 1 | **NGAO Design** |  |  | 4% → 6% |  |
| 4 | **Preliminary Design** |  |  | 5% → 6% |  |
| 6 | **PD Phase Management** |  |  | 13% → 17% |  |
| 25 | **Project Management & Meetings** |  |  | 20% → 21% |  |
| 26 | **Executive Committee** |  |  | 20% → 22% |  |
| 27 | Executive Committee Management Activities |  |  | 20% → 22% |  |
| 28 | Executive Committee Telecons |  |  | 20% → 22% |  |
| 35 | Team Meeting #5 (UC - 3 days) | 2008-09-18 A | 2008-09-18 A | 0% → 100% | 392d → none |
| 57 | **Tracking & Reporting** |  |  | 15% → 19% |  |
| 58 | **Monthly Status Reports** |  |  | 17% → 21% |  |
| 59 | Monthly Team Status Reports |  |  | 19% → 23% |  |
| 60 | Monthly Project Reports (TSIP, Directors) |  |  | 15% → 20% |  |
| 61 | TSIP Project Report Telecons |  |  | 15% → 20% |  |
| 77 | **Proposals** | 2008-06-02 A |  |  |  |
| 80 | Other Proposal | 2009-09-03 A |  | 0% → 5% |  |
| 81 | **Programmatic Risk Assessment & Mitigation** |  |  | 12% → 19% |  |
| 85 | **Risk Mitigation** |  |  | 12% → 20% |  |
| 86 | Laser Procurement |  |  | 15% → 25% |  |
| 87 | Science Instruments | 2008-10-06 A |  | 0% → 5% |  |
| 100 | **Project Support** |  |  | 9% → 17% |  |
| 101 | Administrative/Contract Support |  |  | 14% → 20% |  |
| 102 | Shared Infrastructure |  |  | 2% → 10% |  |
| 103 | Research Time |  |  | 10% → 20% |  |
| 104 | **Systems Engineering** |  |  | 7% → 8% |  |
| 105 | **Science Case Requirements** |  |  | 9% → 10% |  |
| 106 | **Science Case Requirements** |  |  | 10% → 11% |  |
| 112 | **Extend SCRD Discussion of Science Drivers** |  |  | 6% → 8% |  |
| 113 | Nearby AGNs |  |  | 13% → 40% |  |
| 128 | Characterize Sensitivity & Background Requirements |  |  | 44% → 55% |  |
| 142 | **User Community Liaison** |  |  | 6% → 7% |  |
| 144 | **SSC & Keck Science Meeting** |  |  | 5% → 7% |  |
| 146 | Obtain & Document Feedback | 2008-06-02 A |  | 0% → 4% |  |
| 151 | **Requirements** |  |  | 4% → 6% |  |
| 152 | **Operations Concept Document (OCD)** |  |  | 10% → 14% |  |
| 154 | OCD Release 1 |  |  | 5% → 15% |  |
| 236 | **Technical Risk Assessment & Mitigation** |  |  | 2% → 8% |  |
| 240 | **Risk Mitigation Efforts** |  |  | 2% → 9% |  |
| 241 | **PSF Calibration** |  |  | 5% → 20% |  |
| 242 | Support/Monitor Profiler Implementation |  |  | 5% → 20% |  |
| 246 | **AO System Design** |  |  | 1% → 3% |  |
| 248 | **Opto-Mechanical** |  |  | 3% → 4% |  |
| 251 | Optical Relays | 2008-12-29 A |  | 0% → 10% |  |
| 359 | **Real-time Control** |  |  | 2% → 6% |  |
| 360 | **RTC Processor** |  |  | 2% → 7% |  |
| 361 | RTC Technical Management |  |  | 5% → 10% |  |
| 362 | Centroid/Wavefront Reconstruction Processing Requirements |  |  | 5% → 30% |  |
| 363 | Centroid/Wavefront Reconstruction Test Definition | 2008-09-08 A |  | 0% → 10% |  |
| 371 | Define Required Bit Resolution | 2008-05-19 A |  | 0% → 30% |  |

## Version 6 (saved 2008-11-20, file NGAO_Design_v14_tracked_Oct08.mpp)

Last finish stays 2010-03-22. Complete tasks 5 → 6.

Changed:

| ID | Task | Start | Finish | Complete | Total float |
| --- | --- | --- | --- | --- | --- |
| 1 | **NGAO Design** |  |  | 6% → 7% |  |
| 4 | **Preliminary Design** |  |  | 6% → 7% |  |
| 6 | **PD Phase Management** |  |  | 17% → 21% |  |
| 25 | **Project Management & Meetings** |  |  | 21% → 23% |  |
| 26 | **Executive Committee** |  |  | 22% → 25% |  |
| 27 | Executive Committee Management Activities |  |  | 22% → 25% |  |
| 28 | Executive Committee Telecons |  |  | 22% → 25% |  |
| 57 | **Tracking & Reporting** |  |  | 19% → 24% |  |
| 58 | **Monthly Status Reports** |  |  | 21% → 26% |  |
| 59 | Monthly Team Status Reports |  |  | 23% → 29% |  |
| 60 | Monthly Project Reports (TSIP, Directors) |  |  | 20% → 25% |  |
| 61 | TSIP Project Report Telecons |  |  | 20% → 25% |  |
| 77 | **Proposals** |  |  | 0% → 2% |  |
| 80 | Other Proposal |  |  | 5% → 40% |  |
| 81 | **Programmatic Risk Assessment & Mitigation** |  |  | 19% → 23% |  |
| 85 | **Risk Mitigation** |  |  | 20% → 23% |  |
| 86 | Laser Procurement |  |  | 25% → 30% |  |
| 100 | **Project Support** |  |  | 17% → 23% |  |
| 101 | Administrative/Contract Support |  |  | 20% → 25% |  |
| 102 | Shared Infrastructure |  |  | 10% → 20% |  |
| 103 | Research Time |  |  | 20% → 25% |  |
| 104 | **Systems Engineering** |  |  | 8% → 10% |  |
| 105 | **Science Case Requirements** |  |  | 10% → 13% |  |
| 106 | **Science Case Requirements** |  |  | 11% → 14% |  |
| 112 | **Extend SCRD Discussion of Science Drivers** |  |  | 8% → 11% |  |
| 113 | Nearby AGNs |  |  | 40% → 50% |  |
| 114 | Gravitational Lensing |  |  | 36% → 45% |  |
| 117 | GR at Galactic Center | 2008-07-14 A |  | 0% → 4% |  |
| 128 | Characterize Sensitivity & Background Requirements |  |  | 55% → 90% |  |
| 134 | **Science Performance Input** |  |  | 3% → 10% |  |
| 137 | Input to Preliminary Operations Concept Document |  |  | 5% → 20% |  |
| 142 | **User Community Liaison** |  |  | 7% → 12% |  |
| 144 | **SSC & Keck Science Meeting** |  |  | 7% → 15% |  |
| 145 | Prepare & Give Presentations |  |  | 10% → 25% |  |
| 151 | **Requirements** |  |  | 6% → 11% |  |
| 159 | **Functional Requirements (FRD)** | 2008-07-14 A |  | 0% → 12% |  |
| 160 | FRD Release 1 | 2008-07-14 A |  | 0% → 30% |  |
| 163 | Software Standards (Define & Document) | 2008-10-06 A |  | 0% → 15% |  |
| 165 | **Systems Engineering Analysis** |  |  | 6% → 8% |  |
| 166 | **Performance Budgets** | 2008-06-24 A |  | 0% → 3% |  |
| 171 | **Wavefront & Encircled Energy** | 2008-09-01 A |  | 0% → 6% |  |
| 172 | **WFE/EE Budget Tool** | 2008-09-01 A |  | 0% → 9% |  |
| 176 | Other | 2009-05-04 A |  | 0% → 25% |  |
| 195 | **System Architecture** |  |  | 1% → 2% |  |
| 196 | **System Hardware Architecture** |  |  | 3% → 4% |  |
| 198 | Degraded Laser Power Trade Study | 2008-08-04 A |  | 0% → 30% |  |
| 200 | **Software Architecture** |  |  | 0% → 1% |  |
| 201 | Evaluate Software Architecture Options |  |  | 2% → 10% |  |
| 204 | **Control Systems Architecture** |  |  | 0% → 2% |  |
| 205 | Evaluate Control Systems Arch Options |  |  | 2% → 10% |  |
| 207 | Evaluate Motion Control Arch Options | 2009-01-08 A |  | 0% → 5% |  |
| 236 | **Technical Risk Assessment & Mitigation** |  |  | 8% → 15% |  |
| 240 | **Risk Mitigation Efforts** |  |  | 9% → 17% |  |
| 241 | **PSF Calibration** |  |  | 20% → 40% |  |
| 242 | Support/Monitor Profiler Implementation |  |  | 20% → 40% |  |
| 246 | **AO System Design** |  |  | 3% → 7% |  |
| 249 | AO Support Structure | 2008-11-03 A |  | 0% → 5% |  |
| 250 | Rotator | 2009-03-12 A |  | 0% → 5% |  |
| 251 | Optical Relays |  |  | 10% → 15% |  |
| 308 | **Non-real-time Control** | 2009-01-19 A |  |  |  |
| 310 | **AO Sequencer** | 2009-02-02 A |  | 0% → 1% |  |
| 311 | AO Sequencer: Architecture | 2009-02-02 A |  | 0% → 5% |  |
| 359 | **Real-time Control** |  |  | 6% → 13% |  |
| 360 | **RTC Processor** |  |  | 7% → 16% |  |
| 361 | RTC Technical Management |  |  | 10% → 15% |  |
| 362 | Centroid/Wavefront Reconstruction Processing Requirements |  |  | 30% → 75% |  |
| 363 | Centroid/Wavefront Reconstruction Test Definition |  |  | 10% → 50% |  |
| 371 | Define Required Bit Resolution |  | 2008-06-17 A | 30% → 100% | 459d → none |
| 377 | Define Testing Procedures | 2008-09-29 A |  | 0% → 20% |  |
| 449 | **Laser System Control (LSC)** | 2009-04-28 A |  | 0% → 1% |  |

| ID | Task | Start | Complete |
| --- | --- | --- | --- |
| 450 | **LSC Software** | 2009-07-01 A | 0% → 2% |
| 452 | LSC Sequencer Software | 2009-07-13 A | 0% → 5% |
| 460 | **Science Operations Tools Design** | 2008-07-01 A |  |
| 461 | **Multi-Systems Command Sequencer (MCS)** | 2008-07-01 A |  |
| 462 | **MCS Infrastructure** | 2008-07-07 A |  |
| 463 | **MCS Infrastructure Architecture** | 2008-07-07 A |  |
| 464 | MCS Architecture | 2008-07-07 A |  |

## Version 7 (saved 2008-12-11, file NGAO_Design_v14_tracked_Nov08.mpp)

Last finish stays 2010-03-22. Complete tasks 6 → 10.

Changed:

| ID | Task | Start | Finish | Complete | Total float | Other |
| --- | --- | --- | --- | --- | --- | --- |
| 1 | **NGAO Design** |  |  | 7% → 8% |  |  |
| 4 | **Preliminary Design** |  |  | 7% → 9% |  |  |
| 6 | **PD Phase Management** |  |  | 21% → 24% |  |  |
| 25 | **Project Management & Meetings** |  |  | 23% → 30% |  |  |
| 26 | **Executive Committee** |  |  | 25% → 30% |  |  |
| 27 | Executive Committee Management Activities |  |  | 25% → 30% |  |  |
| 28 | Executive Committee Telecons |  |  | 25% → 30% |  |  |
| 29 | **Team Meetings** |  |  | 19% → 29% |  |  |
| 30 | Meeting Participation |  |  | 19% → 29% |  |  |
| 57 | **Tracking & Reporting** |  |  | 24% → 27% |  |  |
| 58 | **Monthly Status Reports** |  |  | 26% → 30% |  |  |
| 59 | Monthly Team Status Reports |  |  | 29% → 31% |  |  |
| 60 | Monthly Project Reports (TSIP, Directors) |  |  | 25% → 30% |  |  |
| 61 | TSIP Project Report Telecons |  |  | 25% → 30% |  |  |
| 62 | **SSC Meetings** |  |  | 13% → 26% |  |  |
| 65 | SSC Meeting (UCSC) | 2008-11-03 A | 2008-11-04 A | 0% → 100% | 359.88d → none |  |
| 81 | **Programmatic Risk Assessment & Mitigation** |  |  | 23% → 30% |  |  |
| 85 | **Risk Mitigation** |  |  | 23% → 31% |  |  |
| 86 | Laser Procurement |  |  | 30% → 40% |  |  |
| 104 | **Systems Engineering** |  |  | 10% → 11% |  |  |
| 106 | **Science Case Requirements** |  |  | 14% → 15% |  |  |
| 129 | Science Requirements Summary Matrix | 2009-05-25 A |  | 0% → 8% |  |  |
| 142 | **User Community Liaison** |  |  | 12% → 14% |  |  |
| 144 | **SSC & Keck Science Meeting** |  |  | 15% → 17% |  |  |
| 145 | Prepare & Give Presentations |  |  | 25% → 30% |  |  |
| 151 | **Requirements** |  |  | 11% → 20% |  |  |
| 159 | **Functional Requirements (FRD)** |  |  | 12% → 19% |  |  |
| 160 | FRD Release 1 |  |  | 30% → 50% |  |  |
| 163 | Software Standards (Define & Document) |  |  | 15% → 75% |  |  |
| 165 | **Systems Engineering Analysis** |  |  | 8% → 10% |  |  |
| 166 | **Performance Budgets** |  |  | 3% → 9% |  |  |
| 171 | **Wavefront & Encircled Energy** |  |  | 6% → 19% |  |  |
| 172 | **WFE/EE Budget Tool** |  |  | 9% → 26% |  |  |
| 176 | Other (NFIRAOS budget comparison) |  |  | 25% → 75% |  | was named Other |
| 189 | **Modeling & Analysis** |  |  | 26% → 23% |  |  |
| 190 | T/T Sharpening Study Report |  |  | 85% → 75% |  |  |
| 195 | **System Architecture** |  |  | 2% → 4% |  |  |
| 196 | **System Hardware Architecture** |  |  | 4% → 8% |  |  |
| 197 | Hybrid Rayleigh / Sodium Trade Study |  |  | 25% → 50% |  |  |
| 201 | Evaluate Software Architecture Options |  |  | 10% → 20% |  |  |
| 204 | **Control Systems Architecture** |  |  | 2% → 3% |  |  |
| 205 | Evaluate Control Systems Arch Options |  |  | 10% → 20% |  |  |
| 207 | Evaluate Motion Control Arch Options |  |  | 5% → 10% |  |  |
| 246 | **AO System Design** |  |  | 7% → 6% |  |  |
| 248 | **Opto-Mechanical** |  |  | 4% → 7% |  |  |
| 249 | AO Support Structure |  |  | 5% → 10% |  |  |
| 250 | Rotator |  |  | 5% → 10% |  |  |
| 251 | Optical Relays |  |  | 15% → 20% |  |  |
| 286 | **Tip/Tilt Vibration Mitigation** |  |  | 10% → 50% |  |  |
| 287 | TT Vibration Mitigation Analysis |  |  | 10% → 50% |  |  |
| 359 | **Real-time Control** |  |  | 13% → 10% |  |  |
| 360 | **RTC Processor** |  |  | 16% → 11% |  |  |
| 361 | RTC Technical Management |  |  | 15% → 20% |  |  |
| 362 | Centroid/Wavefront Reconstruction Processing Requirements |  |  | 75% → 5% |  |  |
| 363 | Centroid/Wavefront Reconstruction Test Definition | 2008-09-08 A → 2008-09-08 |  | 50% → 0% |  |  |
| 365 | Preconditioning & Scaling Processing Test Definition | 2008-12-29 A |  | 0% → 50% |  |  |
| 369 | Camera Data Transfer Issues | 2009-07-27 A |  | 0% → 5% |  |  |
| 371 | Define Required Bit Resolution |  | 2008-06-17 A → 2008-06-17 | 100% → 75% | none → 459d |  |
| 375 | Diagnostic Control & I/O Requirements | 2009-02-02 A |  | 0% → 30% |  |  |
| 402 | **Laser System Design** |  |  | 2% → 12% |  |  |
| 408 | **Laser** |  |  | 5% → 27% |  |  |
| 410 | **Laser Requirements** | 2008-05-05 A |  | 0% → 20% | 211d → 381d |  |
| 413 | Laser Requirements Development | 2008-06-30 A |  | 0% → 50% | 211d → 393.5d |  |
| 414 | Laser Requirements Drafting and Revisions | 2008-07-28 A |  | 0% → 25% | 211d → 381d |  |
| 417 | **Laser Request for Proposals (RFP)** | 2008-10-06 A | 2009-02-06 A | 0% → 100% | 211d → none |  |
| 418 | Laser Proposal Drafting | 2008-10-06 A | 2008-10-31 A | 0% → 100% | 211d → none |  |
| 419 | Laser Proposal Release | 2008-11-03 A | 2008-11-14 A | 0% → 100% | 211d → none |  |
| 420 | Laser Proposal Response Period | 2008-11-17 A | 2009-02-06 A | 0% → 100% | 211d → none |  |
| 421 | **Laser RFP Response Report** | 2009-02-09 A |  | 0% → 33% | 211d → 251d |  |
| 422 | Laser Proposal Evaluation | 2009-02-09 A | 2009-03-06 A | 0% → 100% | 211d → none |  |

## Version 8 (saved 2009-01-25, file NGAO_Design_v14_tracked_Dec08.mpp)

Last finish stays 2010-03-22. Complete tasks 10 → 13.

Changed:

| ID | Task | Start | Finish | Complete | Total float |
| --- | --- | --- | --- | --- | --- |
| 1 | **NGAO Design** |  |  | 8% → 10% |  |
| 4 | **Preliminary Design** |  |  | 9% → 10% |  |
| 6 | **PD Phase Management** |  |  | 24% → 29% |  |
| 7 | **Planning** |  |  | 9% → 11% |  |
| 8 | **Replans (PD phase)** |  |  | 20% → 35% |  |
| 10 | Replan 1 | 2008-10-27 A |  | 0% → 40% |  |
| 25 | **Project Management & Meetings** |  |  | 30% → 35% |  |
| 26 | **Executive Committee** |  |  | 30% → 35% |  |
| 27 | Executive Committee Management Activities |  |  | 30% → 35% |  |
| 28 | Executive Committee Telecons |  |  | 30% → 35% |  |
| 29 | **Team Meetings** |  |  | 29% → 34% |  |
| 30 | Meeting Participation |  |  | 29% → 34% |  |
| 57 | **Tracking & Reporting** |  |  | 27% → 28% |  |
| 58 | **Monthly Status Reports** |  |  | 30% → 31% |  |
| 59 | Monthly Team Status Reports |  |  | 31% → 34% |  |
| 71 | **Other Presentations** |  |  | 7% → 8% |  |
| 74 | Keck Science Meeting 08 | 2008-09-18 A | 2008-09-22 A | 0% → 100% | 390d → none |
| 77 | **Proposals** |  |  | 2% → 3% |  |
| 80 | Other Proposal |  |  | 40% → 60% |  |
| 81 | **Programmatic Risk Assessment & Mitigation** |  |  | 30% → 38% |  |
| 85 | **Risk Mitigation** |  |  | 31% → 38% |  |
| 86 | Laser Procurement |  |  | 40% → 50% |  |
| 87 | Science Instruments |  |  | 5% → 10% |  |
| 100 | **Project Support** |  |  | 23% → 31% |  |
| 101 | Administrative/Contract Support |  |  | 25% → 34% |  |
| 102 | Shared Infrastructure |  |  | 20% → 25% |  |
| 103 | Research Time |  |  | 25% → 35% |  |
| 104 | **Systems Engineering** |  |  | 11% → 12% |  |
| 105 | **Science Case Requirements** |  |  | 13% → 14% |  |
| 106 | **Science Case Requirements** |  |  | 15% → 16% |  |
| 122 | **Characterize PSF Stability, Knowledge & Subtraction Requirements** |  |  | 1% → 3% |  |
| 123 | Nearby AGNs |  |  | 3% → 6% |  |
| 124 | Galactic Center Astrometry | 2008-10-06 A |  | 0% → 2% |  |
| 129 | Science Requirements Summary Matrix |  |  | 8% → 16% |  |
| 151 | **Requirements** |  |  | 20% → 23% |  |
| 159 | **Functional Requirements (FRD)** |  |  | 19% → 23% |  |
| 160 | FRD Release 1 |  |  | 50% → 60% |  |
| 163 | Software Standards (Define & Document) |  |  | 75% → 90% |  |
| 165 | **Systems Engineering Analysis** |  |  | 10% → 13% |  |
| 166 | **Performance Budgets** |  |  | 9% → 12% |  |
| 171 | **Wavefront & Encircled Energy** |  |  | 19% → 25% |  |
| 172 | **WFE/EE Budget Tool** |  |  | 26% → 35% |  |
| 176 | Other (NFIRAOS budget comparison) |  | 2009-06-24 A | 75% → 100% | 193d → none |
| 189 | **Modeling & Analysis** |  |  | 23% → 27% |  |
| 190 | T/T Sharpening Study Report |  |  | 75% → 90% |  |
| 195 | **System Architecture** |  |  | 4% → 5% |  |
| 198 | Degraded Laser Power Trade Study |  |  | 30% → 70% |  |
| 200 | **Software Architecture** |  |  | 1% → 3% |  |
| 201 | Evaluate Software Architecture Options |  |  | 20% → 40% |  |
| 204 | **Control Systems Architecture** |  |  | 3% → 5% |  |
| 205 | Evaluate Control Systems Arch Options |  |  | 20% → 40% |  |
| 215 | **External Interface Control** | 2008-10-06 A |  | 0% → 1% |  |
| 216 | **Observatory Interfaces** | 2008-10-06 A |  | 0% → 3% |  |
| 217 | AO System ICD | 2009-02-02 A |  | 0% → 5% |  |
| 218 | Laser System ICD | 2008-10-06 A |  | 0% → 5% |  |
| 219 | Science Tools ICD | 2008-10-06 A |  | 0% → 1% |  |
| 220 | **Science Instrument Interfaces to NGAO** | 2008-10-06 A |  | 0% → 1% |  |
| 221 | Generic Science Instrument ICD to AO | 2008-10-06 A |  | 0% → 5% |  |
| 228 | **Internal Interface Control** | 2008-08-04 A |  | 0% → 6% |  |
| 230 | Interface N-Squared Diagram | 2008-10-06 A |  | 0% → 25% |  |
| 246 | **AO System Design** |  |  | 6% → 8% |  |
| 248 | **Opto-Mechanical** |  |  | 7% → 10% |  |
| 249 | AO Support Structure |  |  | 10% → 20% |  |
| 250 | Rotator |  |  | 10% → 20% |  |
| 251 | Optical Relays |  |  | 20% → 40% |  |
| 252 | Optical Switchyard | 2008-08-04 A |  | 0% → 5% |  |
| 310 | **AO Sequencer** |  |  | 1% → 3% |  |
| 311 | AO Sequencer: Architecture |  |  | 5% → 10% |  |
| 359 | **Real-time Control** |  |  | 10% → 12% |  |
| 360 | **RTC Processor** |  |  | 11% → 15% |  |

| ID | Task | Start | Finish | Complete | Total float |
| --- | --- | --- | --- | --- | --- |
| 362 | Centroid/Wavefront Reconstruction Processing Requirements |  |  | 5% → 20% |  |
| 365 | Preconditioning & Scaling Processing Test Definition |  |  | 50% → 60% |  |
| 369 | Camera Data Transfer Issues |  |  | 5% → 15% |  |
| 371 | Define Required Bit Resolution |  | 2008-06-17 A | 75% → 100% | 459d → none |
| 375 | Diagnostic Control & I/O Requirements |  |  | 30% → 60% |  |
| 377 | Define Testing Procedures |  |  | 20% → 30% |  |
| 402 | **Laser System Design** |  |  | 12% → 14% |  |
| 408 | **Laser** |  |  | 27% → 30% |  |
| 409 | Laser Project Management |  |  | 10% → 15% |  |
| 410 | **Laser Requirements** |  |  | 20% → 25% |  |
| 413 | Laser Requirements Development |  |  | 50% → 75% |  |
| 428 | **Laser Launch Facility (LLF)** | 2009-01-19 A |  | 0% → 2% |  |
| 431 | LLF Launch Telescope Preliminary Design Contract | 2009-03-16 A |  | 0% → 5% |  |
| 449 | **Laser System Control (LSC)** |  |  | 1% → 3% |  |
| 450 | **LSC Software** |  |  | 2% → 4% |  |
| 452 | LSC Sequencer Software |  |  | 5% → 10% |  |
| 464 | MCS Architecture |  |  | 0% → 1% |  |

## Version 9 (saved 2009-02-16, file NGAO_Design_v14_expected_Jan09.mpp)

Last finish stays 2010-03-22. Complete tasks 13 → 115.

Changed:

| ID | Task | Start | Finish | Complete | Total float |
| --- | --- | --- | --- | --- | --- |
| 1 | **NGAO Design** |  |  | 10% → 36% |  |
| 4 | **Preliminary Design** |  |  | 10% → 37% |  |
| 6 | **PD Phase Management** |  |  | 29% → 36% |  |
| 7 | **Planning** |  |  | 11% → 15% |  |
| 8 | **Replans (PD phase)** |  |  | 35% → 62% |  |
| 9 | Replan based on SDR |  | 2008-05-09 A | 85% → 100% | 486d → none |
| 10 | Replan 1 |  | 2008-11-07 A | 40% → 100% | 356d → none |
| 12 | **WMKO FY Plans** |  |  | 19% → 23% |  |
| 14 | Support WMKO FY10 Planning | 2009-02-02 A |  | 0% → 5% |  |
| 25 | **Project Management & Meetings** |  |  | 35% → 40% |  |
| 26 | **Executive Committee** |  |  | 35% → 40% |  |
| 27 | Executive Committee Management Activities |  |  | 35% → 40% |  |
| 28 | Executive Committee Telecons |  |  | 35% → 40% |  |
| 29 | **Team Meetings** |  |  | 34% → 39% |  |
| 30 | Meeting Participation |  |  | 34% → 39% | 0d → 16d |
| 57 | **Tracking & Reporting** |  |  | 28% → 35% |  |
| 58 | **Monthly Status Reports** |  |  | 31% → 40% |  |
| 59 | Monthly Team Status Reports |  |  | 34% → 39% | 0d → 16d |
| 60 | Monthly Project Reports (TSIP, Directors) |  |  | 30% → 40% |  |
| 61 | TSIP Project Report Telecons |  |  | 30% → 40% |  |
| 77 | **Proposals** | 2008-06-02 A → 2008-06-02 |  | 3% → 0% |  |
| 80 | Other Proposal | 2009-09-03 A → 2009-09-03 |  | 60% → 0% |  |
| 81 | **Programmatic Risk Assessment & Mitigation** |  |  | 38% → 64% |  |
| 82 | **Risk Assessment** | 2008-09-04 A |  | 0% → 76% |  |
| 83 | Programmatic Risk Assessment v1 | 2008-09-04 A | 2008-09-12 A | 0% → 100% | 396d → none |
| 85 | **Risk Mitigation** |  |  | 38% → 64% |  |
| 87 | Science Instruments |  | 2008-11-21 A | 10% → 100% | 346d → none |
| 88 | Funding |  | 2008-09-26 A | 5% → 100% | 386d → none |
| 100 | **Project Support** |  |  | 31% → 38% |  |
| 101 | Administrative/Contract Support |  |  | 34% → 38% |  |
| 102 | Shared Infrastructure |  |  | 25% → 35% |  |
| 103 | Research Time |  |  | 35% → 40% |  |
| 104 | **Systems Engineering** |  |  | 12% → 49% |  |
| 105 | **Science Case Requirements** |  |  | 14% → 46% |  |
| 106 | **Science Case Requirements** |  |  | 16% → 66% |  |
| 107 | **Requirements for new Science Drivers** |  | 2009-01-12 A | 32% → 100% | 310d → none |
| 108 | Astrometry Science in Sparse Fields |  | 2009-01-12 A | 50% → 100% | 310d → none |
| 109 | Resolved Stellar Populations in Crowded Fields |  | 2008-10-06 A | 50% → 100% | 380d → none |
| 110 | Debris Disks & Young Stellar Objects |  | 2008-10-06 A | 10% → 100% | 380d → none |
| 111 | QSO Host Galaxies |  | 2008-07-11 A | 13% → 100% | 441d → none |
| 112 | **Extend SCRD Discussion of Science Drivers** |  | 2008-12-22 A | 11% → 100% | 325d → none |
| 113 | Nearby AGNs |  | 2008-07-11 A | 50% → 100% | 441d → none |
| 114 | Gravitational Lensing |  | 2008-07-11 A | 45% → 100% | 441d → none |
| 115 | Backup Science | 2008-05-01 A | 2008-07-11 A | 0% → 100% | 441d → none |
| 116 | Ice Giant Planets | 2008-07-14 A | 2008-10-06 A | 0% → 100% | 380d → none |
| 117 | GR at Galactic Center |  | 2008-10-06 A | 4% → 100% | 380d → none |
| 118 | Extrasolar Planets |  | 2008-12-16 A | 14% → 100% | 329d → none |
| 119 | Asteroids | 2008-05-01 A | 2008-07-11 A | 0% → 100% | 441d → none |
| 120 | QSO Host Galaxies | 2008-07-14 A | 2008-12-22 A | 0% → 100% | 325d → none |
| 121 | Backup Science - NGS & Acquisition Camera | 2008-07-14 A | 2008-10-06 A | 0% → 100% | 380d → none |
| 122 | **Characterize PSF Stability, Knowledge & Subtraction Requirements** |  |  | 3% → 55% |  |
| 123 | Nearby AGNs |  |  | 6% → 35% |  |
| 124 | Galactic Center Astrometry |  |  | 2% → 90% |  |
| 125 | Extrasolar Planets | 2009-01-12 A |  | 0% → 10% |  |
| 126 | Minor Planet Multiplicity | 2008-10-20 A | 2008-12-08 A | 0% → 100% | 335d → none |
| 127 | QSO Host Galaxies | 2008-10-06 A | 2009-01-26 A | 0% → 100% | 300d → none |
| 128 | Characterize Sensitivity & Background Requirements |  |  | 90% → 10% |  |
| 129 | Science Requirements Summary Matrix | 2009-05-25 A → 2009-05-25 |  | 16% → 0% |  |
| 131 | **Science Observing Planning & Execution** |  |  | 2% → 50% |  |
| 132 | Key Science Driver Observing Scenarios |  | 2009-01-16 A | 3% → 100% | 306d → none |
| 134 | **Science Performance Input** |  |  | 10% → 22% |  |
| 135 | Define Science Driver Parameters for Performance Budgets |  | 2008-10-28 A | 50% → 100% | 364d → none |
| 136 | Input to User Interfaces, Planning & Observing Tools | 2008-10-06 A |  | 0% → 25% |  |
| 137 | Input to Preliminary Operations Concept Document |  |  | 20% → 15% |  |
| 138 | **Science Competitiveness** |  |  | 27% → 38% |  |
| 140 | Evaluate NGAO Potential to Compliment Other Facilities |  |  | 28% → 40% |  |
| 141 | Define NGAO Uniqueness Space |  |  | 13% → 35% |  |
| 142 | **User Community Liaison** |  |  | 14% → 39% |  |
| 143 | Enlist People to work on new NGAO Science Aspects |  |  | 7% → 50% |  |
| 144 | **SSC & Keck Science Meeting** |  |  | 17% → 35% |  |

| ID | Task | Start | Finish | Complete | Total float |
| --- | --- | --- | --- | --- | --- |
| 145 | Prepare & Give Presentations |  |  | 30% → 35% |  |
| 146 | Obtain & Document Feedback |  |  | 4% → 35% |  |
| 147 | **Science Advisory Team Meetings** | 2008-06-09 A |  | 0% → 42% |  |
| 148 | Prepare Minutes, Presentations & KAONs | 2008-06-09 A |  | 0% → 45% |  |
| 149 | Refine Science Requirements | 2008-07-21 A |  | 0% → 40% |  |
| 150 | Evaluate Science Impact of Proposed Changes | 2008-07-21 A |  | 0% → 40% |  |
| 151 | **Requirements** |  |  | 23% → 64% |  |
| 152 | **Operations Concept Document (OCD)** |  |  | 14% → 50% |  |
| 153 | OCD Outline |  | 2008-06-06 A | 90% → 100% | 466d → none |
| 154 | OCD Release 1 |  | 2009-01-30 A | 15% → 100% | 296d → none |
| 156 | **System Requirements (SRD)** | 2008-12-01 A |  | 0% → 50% |  |
| 157 | SRD Release I | 2008-12-01 A | 2008-12-12 A | 0% → 100% | 331d → none |
| 159 | **Functional Requirements (FRD)** |  |  | 23% → 61% |  |
| 160 | FRD Release 1 |  | 2008-08-29 A | 60% → 100% | 406d → none |
| 162 | Compliance Matrix | 2008-10-06 A | 2008-10-31 A | 0% → 100% | 361d → none |
| 163 | Software Standards (Define & Document) |  | 2008-11-17 A | 90% → 100% | 350d → none |
| 164 | Component Standards (Define & Document) | 2008-11-03 A | 2008-12-05 A | 0% → 100% | 336d → none |
| 165 | **Systems Engineering Analysis** |  |  | 13% → 49% |  |
| 166 | **Performance Budgets** |  |  | 12% → 59% |  |
| 168 | **Throughput & Background Budget** | 2008-11-03 A | 2008-12-12 A | 0% → 100% | 331d → none |
| 169 | Thermal Background Analysis Software with Documentation | 2008-11-03 A | 2008-11-21 A | 0% → 100% | 346d → none |
| 170 | Thermal Analysis | 2008-12-01 A | 2008-12-12 A | 0% → 100% | 331d → none |
| 171 | **Wavefront & Encircled Energy** |  |  | 25% → 48% |  |
| 172 | **WFE/EE Budget Tool** |  |  | 35% → 65% |  |
| 173 | NGS TT & TTFA Sharpening Budgets | 2008-10-06 A | 2008-11-18 A | 0% → 100% | 349.5d → none |
| 174 | Improved Bandwidth Model | 2008-12-01 A | 2009-01-02 A | 0% → 100% | 316d → none |
| 175 | Improved Atmospheric Dispersion Model | 2008-09-01 A | 2008-09-19 A | 0% → 100% | 391d → none |
| 176 | Other (NFIRAOS budget comparison) | 2009-05-04 A → 2009-05-04 | 2009-06-24 A → 2009-06-24 | 100% → 0% | none → 193d |
| 180 | **Astrometric Precision** | 2008-10-06 A |  | 0% → 78% |  |
| 181 | Develop Astrometric Budget Tool | 2008-10-06 A |  | 0% → 95% |  |
| 182 | Galactic Center Astrometric Analysis | 2009-01-05 A |  | 0% → 55% |  |
| 183 | **Observing Efficiency** | 2008-06-24 A |  | 0% → 50% |  |
| 184 | Observing Efficiency Tool | 2008-06-24 A | 2008-06-30 A | 0% → 100% | 450d → none |
| 186 | **Observing Uptime** | 2008-12-01 A |  | 0% → 50% |  |
| 187 | Observing Uptime Tool | 2008-12-01 A | 2008-12-12 A | 0% → 100% | 331d → none |
| 189 | **Modeling & Analysis** |  |  | 27% → 69% |  |
| 190 | T/T Sharpening Study Report |  | 2008-06-27 A | 90% → 100% | 451d → none |
| 191 | Performance vs T/T NGS Report | 2008-09-01 A |  | 0% → 60% |  |
| 193 | PSF Libraries | 2008-11-03 A | 2008-12-19 A | 0% → 100% | 326d → none |
| 195 | **System Architecture** |  |  | 5% → 47% |  |
| 196 | **System Hardware Architecture** |  |  | 8% → 52% |  |
| 197 | Hybrid Rayleigh / Sodium Trade Study |  |  | 50% → 90% |  |
| 198 | Degraded Laser Power Trade Study |  | 2008-08-15 A | 70% → 100% | 416d → none |
| 199 | System Architecture: Evaluate & Document Changes | 2008-06-02 A |  | 0% → 45% |  |
| 200 | **Software Architecture** |  |  | 3% → 43% |  |
| 201 | Evaluate Software Architecture Options |  | 2008-08-22 A | 40% → 100% | 391d → none |
| 202 | Determine/Document Software Arch Approach | 2008-08-25 A | 2008-09-19 A | 0% → 100% | 391d → none |
| 203 | Software Architecture: Evaluate & Document Changes | 2008-09-22 A |  | 0% → 35% |  |
| 204 | **Control Systems Architecture** |  |  | 5% → 33% |  |
| 205 | Evaluate Control Systems Arch Options |  | 2008-11-14 A | 40% → 100% | 315d → none |
| 206 | Determine/Document Control Systems Arch | 2008-11-17 A | 2009-01-05 A | 0% → 100% | 315d → none |
| 207 | Evaluate Motion Control Arch Options |  |  | 10% → 40% |  |
| 209 | Control Systems Architecture: Evaluate & Document Changes | 2009-01-08 A |  | 0% → 10% |  |
| 210 | **Operations Sequences Architecture** | 2008-05-05 A |  | 0% → 56% |  |
| 211 | Define Required System Level Sequences | 2008-05-05 A | 2008-05-16 A | 0% → 100% | 481d → none |
| 212 | Develop System Level Sequences Approach | 2008-05-19 A | 2008-06-06 A | 0% → 100% | 466d → none |
| 213 | Sequences Definition Document | 2008-06-09 A | 2008-06-27 A | 0% → 100% | 451d → none |
| 214 | Sequences: Evaluate & Document Changes | 2008-07-07 A |  | 0% → 50% |  |
| 215 | **External Interface Control** |  |  | 1% → 92% |  |
| 216 | **Observatory Interfaces** |  |  | 3% → 67% |  |
| 217 | AO System ICD | 2009-02-02 A → 2009-02-02 |  | 5% → 0% |  |
| 218 | Laser System ICD |  | 2008-10-17 A | 5% → 100% | 371d → none |
| 219 | Science Tools ICD |  | 2008-10-31 A | 1% → 100% | 361d → none |
| 220 | **Science Instrument Interfaces to NGAO** |  | 2008-11-28 A | 1% → 100% | 341d → none |
| 221 | Generic Science Instrument ICD to AO |  | 2008-10-31 A | 5% → 100% | 361d → none |
| 222 | Generic Science Instrument ICD to NGAO Science Tools | 2008-10-06 A | 2008-10-31 A | 0% → 100% | 361d → none |
| 223 | Interferometer Specific ICD | 2008-11-03 A | 2008-11-28 A | 0% → 100% | 341d → none |
| 224 | OSIRIS Specific ICD | 2008-11-03 A | 2008-11-28 A | 0% → 100% | 341d → none |
| 225 | NIR Camera Specific ICD | 2008-11-03 A | 2008-11-28 A | 0% → 100% | 341d → none |
| 226 | Visible Camera Specific ICD | 2008-11-03 A | 2008-11-28 A | 0% → 100% | 341d → none |

| ID | Task | Start | Finish | Complete | Total float |
| --- | --- | --- | --- | --- | --- |
| 227 | d-IFS Specific ICD | 2008-11-03 A | 2008-11-28 A | 0% → 100% | 341d → none |
| 228 | **Internal Interface Control** |  | 2008-12-19 A | 6% → 100% | 326d → none |
| 229 | Diagram & Document Draft Outline | 2008-08-04 A | 2008-09-26 A | 0% → 100% | 386d → none |
| 230 | Interface N-Squared Diagram |  | 2008-11-07 A | 25% → 100% | 356d → none |
| 231 | Interface Definition Document | 2008-10-27 A | 2008-12-19 A | 0% → 100% | 326d → none |
| 234 | **Documentation Control** | 2009-01-12 A | 2009-01-16 A | 0% → 100% | 306d → none |
| 235 | Document Control Guidelines & Tools Definition | 2009-01-12 A | 2009-01-16 A | 0% → 100% | 306d → none |
| 236 | **Technical Risk Assessment & Mitigation** |  |  | 15% → 75% |  |
| 237 | **Risk Assessment** | 2008-10-13 A |  | 0% → 52% |  |
| 238 | Risk Assessment v1 | 2008-10-13 A | 2008-10-30 A | 0% → 100% | 362d → none |
| 240 | **Risk Mitigation Efforts** |  |  | 17% → 77% |  |
| 241 | **PSF Calibration** |  | 2009-01-30 A | 40% → 100% | 296d → none |
| 242 | Support/Monitor Profiler Implementation |  | 2009-01-30 A | 40% → 100% | 296d → none |
| 243 | **Sky Coverage** | 2008-10-06 A |  | 0% → 60% |  |
| 244 | Prototype NIR Tip/tilt Sensor | 2008-10-06 A |  | 0% → 60% |  |
| 246 | **AO System Design** |  |  | 8% → 31% |  |
| 247 | AO Enclosure | 2008-10-01 A |  | 0% → 60% |  |
| 248 | **Opto-Mechanical** |  |  | 10% → 22% |  |
| 249 | AO Support Structure |  | 2009-01-09 A | 20% → 100% | 311d → none |
| 250 | Rotator | 2009-03-12 A → 2009-03-12 |  | 20% → 0% |  |
| 251 | Optical Relays |  |  | 40% → 30% |  |
| 252 | Optical Switchyard |  | 2008-11-07 A | 5% → 100% | 356d → none |
| 291 | **Atmospheric Dispersion Correctors** | 2008-10-17 A |  | 0% → 10% |  |
| 292 | LOWFS ADCs | 2008-10-17 A |  | 0% → 20% |  |
| 310 | **AO Sequencer** | 2009-02-02 A → 2009-02-02 |  | 3% → 0% |  |
| 311 | AO Sequencer: Architecture | 2009-02-02 A → 2009-02-02 |  | 10% → 0% |  |
| 337 | **AO Motion Control Electronics** | 2009-01-19 A |  | 0% → 10% |  |
| 338 | Motion Control HW: Spreadsheet | 2009-01-19 A |  | 0% → 10% |  |
| 359 | **Real-time Control** |  |  | 12% → 51% |  |
| 360 | **RTC Processor** |  |  | 15% → 44% |  |
| 361 | RTC Technical Management |  |  | 20% → 40% |  |
| 362 | Centroid/Wavefront Reconstruction Processing Requirements |  | 2008-10-03 A | 20% → 100% | 381d → none |
| 363 | Centroid/Wavefront Reconstruction Test Definition | 2008-09-08 A | 2008-11-11 A | 0% → 100% | 354d → none |
| 364 | Preconditioning & Scaling Processing Requirements | 2008-10-06 A | 2009-01-16 A | 0% → 100% | 306d → none |
| 365 | Preconditioning & Scaling Processing Test Definition |  |  | 60% → 90% |  |
| 369 | Camera Data Transfer Issues | 2009-07-27 A → 2009-07-27 |  | 15% → 0% |  |
| 370 | Radial versus Rectilinear Voxels Trade Study | 2008-11-03 A |  | 0% → 70% |  |
| 375 | Diagnostic Control & I/O Requirements | 2009-02-02 A → 2009-02-02 |  | 60% → 0% |  |
| 377 | Define Testing Procedures |  | 2008-11-28 A | 30% → 100% | 341d → none |
| 379 | **DMs & Tip/Tilt Stages** | 2008-10-06 A |  | 0% → 87% |  |
| 380 | **Woofer DM/TT** | 2008-10-06 A |  | 0% → 89% |  |
| 381 | Define Requirements | 2008-10-06 A | 2008-10-31 A | 0% → 100% | 361d → none |
| 382 | Evaluate Tip/Tilt Mount Options | 2008-12-01 A | 2009-01-09 A | 0% → 100% | 311d → none |
| 383 | Evaluate Combined DM & Tip/Tilt Performance | 2009-01-12 A | 2009-01-23 A | 0% → 100% | 301d → none |
| 384 | Select Tip/Tilt Mount | 2009-01-26 A | 2009-01-30 A | 0% → 100% | 296d → none |
| 386 | Obtain Quotes | 2009-01-05 A | 2009-01-30 A | 0% → 100% | 296d → none |
| 387 | **Tweeter DM/TT** | 2008-10-06 A |  | 0% → 86% |  |
| 388 | Define Requirements | 2008-10-06 A | 2008-10-31 A | 0% → 100% | 361d → none |
| 389 | Evaluate Options & Select Tip/Tilt Mount | 2008-11-03 A | 2008-11-28 A | 0% → 100% | 341d → none |
| 391 | Obtain Quotes | 2008-11-03 A | 2008-11-28 A | 0% → 100% | 341d → none |
| 392 | **LOWFS DM/TT** | 2008-10-06 A |  | 0% → 85% |  |
| 393 | Define Requirements including LOWFS Interface | 2008-10-06 A | 2008-10-31 A | 0% → 100% | 361d → none |
| 394 | Evaluate Options & Select Tip/Tilt Mount | 2008-11-03 A | 2008-11-28 A | 0% → 100% | 341d → none |
| 395 | Design Mechanical Package | 2009-01-12 A |  | 0% → 50% |  |
| 396 | Obtain Quotes | 2008-11-03 A | 2008-11-28 A | 0% → 100% | 341d → none |
| 402 | **Laser System Design** |  |  | 14% → 31% |  |
| 403 | **Laser Enclosure (LE)** | 2009-01-19 A |  | 0% → 16% |  |
| 404 | LE Requirements & Interfaces | 2009-01-19 A |  | 0% → 40% |  |
| 408 | **Laser** |  |  | 30% → 66% |  |
| 409 | Laser Project Management |  |  | 15% → 65% |  |
| 410 | **Laser Requirements** |  | 2008-10-03 A | 25% → 100% | 381d → none |
| 411 | Laser Performance Analysis | 2008-05-05 A | 2008-05-30 A | 0% → 100% | 403.5d → none |
| 412 | Laser Requirements Analysis | 2008-06-02 A | 2008-06-27 A | 0% → 100% | 403.5d → none |
| 413 | Laser Requirements Development |  | 2008-07-25 A | 75% → 100% | 393.5d → none |
| 414 | Laser Requirements Drafting and Revisions |  | 2008-10-03 A | 25% → 100% | 381d → none |
| 415 | **Laser Preliminary ICD** | 2008-07-28 A | 2008-08-22 A | 0% → 100% | 411d → none |
| 416 | Laser ICD Drafting and Revisions | 2008-07-28 A | 2008-08-22 A | 0% → 100% | 411d → none |
| 417 | **Laser Request for Proposals (RFP)** |  | 2009-02-06 A → 2009-02-06 | 100% → 93% | none → 211d |
| 420 | Laser Proposal Response Period |  | 2009-02-06 A → 2009-02-06 | 100% → 90% | none → 211d |
| 421 | **Laser RFP Response Report** | 2009-02-09 A → 2009-02-09 |  | 33% → 0% | 251d → 211d |

| ID | Task | Start | Finish | Complete | Total float |
| --- | --- | --- | --- | --- | --- |
| 422 | Laser Proposal Evaluation | 2009-02-09 A → 2009-02-09 | 2009-03-06 A → 2009-03-06 | 100% → 0% | none → 211d |
| 429 | LLF Requirements & Interfaces | 2009-01-19 A |  | 0% → 25% | 286d → 0d |
| 431 | LLF Launch Telescope Preliminary Design Contract | 2009-03-16 A → 2009-03-16 |  | 5% → 0% |  |
| 460 | **Science Operations Tools Design** |  |  | 0% → 34% |  |
| 461 | **Multi-Systems Command Sequencer (MCS)** |  |  | 0% → 97% |  |
| 462 | **MCS Infrastructure** |  |  | 0% → 99% |  |
| 463 | **MCS Infrastructure Architecture** |  | 2008-10-24 A | 0% → 100% | 366d → none |
| 464 | MCS Architecture |  | 2008-10-24 A | 1% → 100% | 366d → none |
| 465 | MCS Operations Concept Document | 2008-07-07 A | 2008-10-24 A | 0% → 100% | 366d → none |
| 466 | MCS Software Requirements | 2008-07-07 A | 2008-10-24 A | 0% → 100% | 366d → none |
| 467 | MCS Module Definitions | 2008-07-07 A | 2008-10-24 A | 0% → 100% | 366d → none |
| 468 | **Coordination Sequence Support Library** | 2008-07-07 A |  | 0% → 99% |  |
| 469 | Functional Requirements | 2008-07-07 A | 2008-10-24 A | 0% → 100% | 366d → none |
| 471 | **Command Interface** | 2008-07-07 A |  | 0% → 99% |  |
| 472 | Functional Requirements | 2008-07-07 A | 2008-10-24 A | 0% → 100% | 366d → none |
| 474 | **System Health** | 2008-07-07 A |  | 0% → 99% |  |
| 475 | Functional Requirements | 2008-07-07 A | 2008-10-24 A | 0% → 100% | 366d → none |
| 477 | **Setup Sequences: Configuration & Calibration** | 2008-07-01 A |  | 0% → 99% |  |
| 478 | **Setup Sequences Common Structure** | 2008-07-01 A | 2008-10-31 A | 0% → 100% | 361d → none |
| 479 | Setup Sequences Operations Concept Document | 2008-07-01 A | 2008-10-31 A | 0% → 100% | 361d → none |
| 480 | Setup Sequences Software Requirements | 2008-07-01 A | 2008-10-31 A | 0% → 100% | 361d → none |
| 481 | Setup Sequences Module Definitions | 2008-07-01 A | 2008-10-31 A | 0% → 100% | 361d → none |
| 482 | **Configuration Sequences** | 2008-07-01 A |  | 0% → 99% |  |
| 483 | Functional Requirements | 2008-07-01 A | 2008-10-31 A | 0% → 100% | 361d → none |
| 485 | **Calibration Sequences** | 2008-07-01 A |  | 0% → 99% |  |
| 486 | Functional Requirements | 2008-07-01 A | 2008-10-31 A | 0% → 100% | 361d → none |
| 488 | **Observing Sequences** | 2008-10-01 A |  | 0% → 95% |  |
| 489 | **Observing Sequences Common Structure** | 2008-10-01 A |  | 0% → 95% |  |
| 490 | Observing Sequences Operations Concept Document | 2008-10-01 A |  | 0% → 95% |  |
| 491 | Observing Sequences Software Requirements | 2008-10-01 A |  | 0% → 95% |  |
| 492 | Observing Sequences Module Definitions | 2008-10-01 A |  | 0% → 95% |  |
| 493 | **Acquisition Sequences** | 2008-10-01 A |  | 0% → 95% |  |
| 494 | Functional Requirements | 2008-10-01 A |  | 0% → 95% |  |
| 495 | Interface Definitions | 2008-10-01 A |  | 0% → 95% |  |
| 496 | **Observing Sequences** | 2008-10-01 A |  | 0% → 94% |  |
| 497 | Functional Requirements | 2008-10-01 A |  | 0% → 95% |  |
| 499 | **Quality Monitoring Sequences** | 2008-10-01 A |  | 0% → 94% |  |
| 500 | Functional Requirements | 2008-10-01 A |  | 0% → 95% |  |
| 502 | **Optimization Sequences** | 2008-10-01 A |  | 0% → 94% |  |
| 503 | Functional Requirements | 2008-10-01 A |  | 0% → 95% |  |
| 505 | **Alarm Handler & Troubleshooting Sequences** | 2008-10-01 A |  | 0% → 94% |  |
| 506 | **Alarm Handler & Troubleshooting Common Structure** | 2008-10-01 A |  | 0% → 95% |  |
| 507 | Alarm & Troubleshooting Operations Concept Document | 2008-10-01 A |  | 0% → 95% |  |
| 508 | Alarm & Troubleshooting Software Requirements | 2008-10-01 A |  | 0% → 95% |  |
| 509 | Alarm & Troubleshooting Module Definitions | 2008-10-01 A |  | 0% → 95% |  |
| 516 | **User Interfaces** | 2008-07-01 A |  | 0% → 46% |  |
| 517 | **User Interface (UI) Infrastructure** | 2008-07-01 A |  | 0% → 88% |  |
| 518 | **UI Infrastructure Architecture** | 2008-07-01 A | 2008-10-31 A | 0% → 100% | 361d → none |
| 519 | UI Architecture | 2008-07-01 A | 2008-10-31 A | 0% → 100% | 361d → none |
| 520 | UI Operations Concept Document | 2008-07-01 A | 2008-10-31 A | 0% → 100% | 361d → none |
| 521 | UI Software Requirements | 2008-07-01 A | 2008-10-31 A | 0% → 100% | 361d → none |
| 522 | UI Module Definitions | 2008-07-01 A | 2008-10-31 A | 0% → 100% | 361d → none |
| 523 | **UI Command Interface to MCS** | 2008-07-01 A | 2008-10-31 A | 0% → 100% | 361d → none |
| 524 | Functional Requirements | 2008-07-01 A | 2008-10-31 A | 0% → 100% | 361d → none |
| 525 | Interface Definitions | 2008-07-01 A | 2008-10-31 A | 0% → 100% | 361d → none |
| 526 | **UI Command Interface to Pre- & Post-Observing Tools** | 2008-07-01 A |  | 0% → 50% |  |
| 527 | Functional Requirements | 2008-07-01 A | 2008-10-31 A | 0% → 100% | 361d → none |
| 529 | **Setup User Interfaces** | 2008-10-01 A |  | 0% → 46% |  |
| 530 | **Setup UI Common Structure** | 2008-10-01 A |  | 0% → 65% |  |
| 531 | Setup UI Operations Concept Document | 2008-10-01 A |  | 0% → 65% |  |
| 532 | Setup UI Software Requirements | 2008-10-01 A |  | 0% → 65% |  |
| 533 | Setup UI Module Definitions | 2008-10-01 A |  | 0% → 65% |  |
| 534 | **Setup UI Configurations** | 2008-10-01 A |  | 0% → 33% |  |
| 535 | Functional Requirements | 2008-10-01 A |  | 0% → 65% |  |
| 537 | **Setup UI Calibrations** | 2008-10-01 A |  | 0% → 33% |  |
| 538 | Functional Requirements | 2008-10-01 A |  | 0% → 65% |  |
| 540 | **Observations User Interfaces** | 2008-10-01 A |  | 0% → 33% |  |
| 541 | **Observations UI Common Structure** | 2008-10-01 A |  | 0% → 44% |  |
| 542 | Observations UI Operations Concept Document | 2008-10-01 A |  | 0% → 33% | 211d → 0d |
| 543 | Observations UI Software Requirements | 2008-10-01 A |  | 0% → 50% |  |

| ID | Task | Start | Finish | Complete | Total float |
| --- | --- | --- | --- | --- | --- |
| 544 | Observations UI Module Definitions | 2008-10-01 A |  | 0% → 50% |  |
| 545 | **Acquisition & AO Control UI** | 2008-10-01 A |  | 0% → 50% |  |
| 546 | Functional Requirements | 2008-10-01 A |  | 0% → 50% |  |
| 547 | Interface Definitions | 2008-10-01 A |  | 0% → 50% |  |
| 548 | **Observing Sequences UI** | 2008-10-01 A |  | 0% → 25% |  |
| 549 | Functional Requirements | 2008-10-01 A |  | 0% → 50% |  |
| 551 | **Status & Graph UI** | 2008-10-01 A |  | 0% → 25% |  |
| 552 | Functional Requirements | 2008-10-01 A |  | 0% → 50% |  |
| 554 | **Advanced Monitoring UI** | 2008-10-01 A |  | 0% → 25% |  |
| 555 | Functional Requirements | 2008-10-01 A |  | 0% → 50% |  |
| 557 | **Optimization & Troubleshooting UI** | 2008-10-01 A |  | 0% → 25% |  |
| 558 | Functional Requirements | 2008-10-01 A |  | 0% → 50% |  |
| 560 | **Pre- & Post-Observing Science Support Tools** | 2009-01-01 A |  | 0% → 4% |  |
| 561 | **User Documentation** | 2009-01-01 A |  | 0% → 10% |  |
| 562 | User Documentation Operations Concept | 2009-01-01 A |  | 0% → 10% |  |
| 563 | User Documentation Functional Requirements | 2009-01-01 A |  | 0% → 10% |  |
| 564 | **Science Observations Planning Tools** | 2009-01-07 A |  | 0% → 6% |  |
| 565 | **NGS Star Finder** | 2009-01-07 A |  | 0% → 5% |  |
| 566 | Operations Concept | 2009-01-07 A |  | 0% → 10% |  |
| 567 | Functional Requirements & Use Case Definitions | 2009-01-07 A |  | 0% → 10% |  |
| 570 | **Performance Prediction Tool** | 2009-01-07 A |  | 0% → 10% |  |
| 571 | Operations Concept | 2009-01-07 A |  | 0% → 10% |  |
| 572 | Functional Requirements & Use Case Definitions | 2009-01-07 A |  | 0% → 10% |  |
| 573 | Interface Definitions | 2009-01-07 A |  | 0% → 10% |  |
| 574 | Module Definitions | 2009-01-07 A |  | 0% → 10% |  |
| 575 | **Observation Planning & Efficiency Tool** | 2009-01-07 A |  | 0% → 10% |  |
| 576 | Operations Concept | 2009-01-07 A |  | 0% → 10% |  |
| 577 | Functional Requirements & Use Case Definitions | 2009-01-07 A |  | 0% → 10% |  |
| 578 | Interface Definitions | 2009-01-07 A |  | 0% → 10% |  |
| 579 | Module Definitions | 2009-01-07 A |  | 0% → 10% |  |
| 611 | **Telescope & Summit Engineering Design** | 2008-12-08 A |  | 0% → 19% |  |
| 626 | OSIRIS Modifications | 2009-01-12 A | 2009-01-30 A | 0% → 100% | 296d → none |
| 627 | **Interferometer Modifications** | 2008-12-08 A | 2009-01-30 A | 0% → 100% | 296d → none |
| 628 | Optical Design of Post Field Selector Optics | 2008-12-08 A | 2009-01-30 A | 0% → 100% | 296d → none |
| 629 | Evaluation of Optical Design Impact on Interferometer | 2008-12-08 A | 2009-01-30 A | 0% → 100% | 296d → none |
| 648 | **Operations Transition** | 2009-01-09 A |  | 0% → 3% |  |
| 652 | **Operations Handover** | 2009-01-09 A |  | 0% → 4% |  |
| 654 | Documentation Transition Plan | 2009-01-09 A |  | 0% → 5% |  |

## Version 10 (saved 2009-02-20, file NGAO_Design_v14_tracked_Jan09.mpp)

Last finish stays 2010-03-22. Complete tasks 115 → 17.

Changed:

| ID | Task | Start | Finish | Complete | Total float |
| --- | --- | --- | --- | --- | --- |
| 1 | **NGAO Design** |  |  | 36% → 13% |  |
| 4 | **Preliminary Design** |  |  | 37% → 14% |  |
| 6 | **PD Phase Management** |  |  | 36% → 34% |  |
| 7 | **Planning** |  |  | 15% → 12% |  |
| 8 | **Replans (PD phase)** |  |  | 62% → 35% |  |
| 9 | Replan based on SDR |  | 2008-05-09 A → 2008-05-09 | 100% → 85% | none → 486d |
| 10 | Replan 1 |  | 2008-11-07 A → 2008-11-07 | 100% → 40% | none → 356d |
| 77 | **Proposals** | 2008-06-02 A |  | 0% → 5% |  |
| 80 | Other Proposal | 2009-09-03 A | 2009-09-30 A | 0% → 100% | 123d → none |
| 81 | **Programmatic Risk Assessment & Mitigation** |  |  | 64% → 45% |  |
| 82 | **Risk Assessment** | 2008-09-04 A → 2008-09-04 |  | 76% → 0% |  |
| 83 | Programmatic Risk Assessment v1 | 2008-09-04 A → 2008-09-04 | 2008-09-12 A → 2008-09-12 | 100% → 0% | none → 396d |
| 85 | **Risk Mitigation** |  |  | 64% → 45% |  |
| 86 | Laser Procurement |  |  | 50% → 60% |  |
| 87 | Science Instruments |  | 2008-11-21 A → 2008-11-21 | 100% → 10% | none → 346d |
| 88 | Funding |  | 2008-09-26 A → 2008-09-26 | 100% → 5% | none → 386d |
| 104 | **Systems Engineering** |  |  | 49% → 18% |  |
| 105 | **Science Case Requirements** |  |  | 46% → 19% |  |
| 106 | **Science Case Requirements** |  |  | 66% → 16% |  |
| 107 | **Requirements for new Science Drivers** |  | 2009-01-12 A → 2009-01-12 | 100% → 33% | none → 310d |
| 108 | Astrometry Science in Sparse Fields |  | 2009-01-12 A → 2009-01-12 | 100% → 50% | none → 310d |
| 109 | Resolved Stellar Populations in Crowded Fields |  | 2008-10-06 A → 2008-10-06 | 100% → 55% | none → 380d |
| 110 | Debris Disks & Young Stellar Objects |  | 2008-10-06 A → 2008-10-06 | 100% → 10% | none → 380d |
| 111 | QSO Host Galaxies |  | 2008-07-11 A → 2008-07-11 | 100% → 13% | none → 441d |
| 112 | **Extend SCRD Discussion of Science Drivers** |  | 2008-12-22 A → 2008-12-22 | 100% → 11% | none → 325d |
| 113 | Nearby AGNs |  | 2008-07-11 A → 2008-07-11 | 100% → 50% | none → 441d |
| 114 | Gravitational Lensing |  | 2008-07-11 A → 2008-07-11 | 100% → 45% | none → 441d |
| 115 | Backup Science | 2008-05-01 A → 2008-05-01 | 2008-07-11 A → 2008-07-11 | 100% → 0% | none → 441d |
| 116 | Ice Giant Planets | 2008-07-14 A → 2008-07-14 | 2008-10-06 A → 2008-10-06 | 100% → 0% | none → 380d |
| 117 | GR at Galactic Center |  | 2008-10-06 A → 2008-10-06 | 100% → 4% | none → 380d |
| 118 | Extrasolar Planets |  | 2008-12-16 A → 2008-12-16 | 100% → 14% | none → 329d |
| 119 | Asteroids | 2008-05-01 A → 2008-05-01 | 2008-07-11 A → 2008-07-11 | 100% → 0% | none → 441d |
| 120 | QSO Host Galaxies | 2008-07-14 A → 2008-07-14 | 2008-12-22 A → 2008-12-22 | 100% → 0% | none → 325d |
| 121 | Backup Science - NGS & Acquisition Camera | 2008-07-14 A → 2008-07-14 | 2008-10-06 A → 2008-10-06 | 100% → 0% | none → 380d |
| 122 | **Characterize PSF Stability, Knowledge & Subtraction Requirements** |  |  | 55% → 4% |  |
| 123 | Nearby AGNs |  |  | 35% → 9% |  |
| 124 | Galactic Center Astrometry |  |  | 90% → 2% |  |
| 125 | Extrasolar Planets | 2009-01-12 A → 2009-01-12 |  | 10% → 0% |  |
| 126 | Minor Planet Multiplicity | 2008-10-20 A → 2008-10-20 | 2008-12-08 A → 2008-12-08 | 100% → 0% | none → 335d |
| 127 | QSO Host Galaxies | 2008-10-06 A → 2008-10-06 | 2009-01-26 A → 2009-01-26 | 100% → 0% | none → 300d |
| 128 | Characterize Sensitivity & Background Requirements |  |  | 10% → 90% |  |
| 129 | Science Requirements Summary Matrix | 2009-05-25 A |  | 0% → 16% |  |
| 131 | **Science Observing Planning & Execution** |  |  | 50% → 5% |  |
| 132 | Key Science Driver Observing Scenarios |  | 2009-01-16 A → 2009-01-16 | 100% → 10% | none → 306d |
| 134 | **Science Performance Input** |  |  | 22% → 15% |  |
| 135 | Define Science Driver Parameters for Performance Budgets |  | 2008-10-28 A → 2008-10-28 | 100% → 50% | none → 364d |
| 136 | Input to User Interfaces, Planning & Observing Tools |  |  | 25% → 5% |  |
| 137 | Input to Preliminary Operations Concept Document |  |  | 15% → 25% |  |
| 138 | **Science Competitiveness** |  |  | 38% → 34% |  |
| 140 | Evaluate NGAO Potential to Compliment Other Facilities |  |  | 40% → 48% |  |
| 141 | Define NGAO Uniqueness Space |  |  | 35% → 13% |  |
| 142 | **User Community Liaison** |  |  | 39% → 14% |  |
| 143 | Enlist People to work on new NGAO Science Aspects |  |  | 50% → 7% |  |
| 144 | **SSC & Keck Science Meeting** |  |  | 35% → 17% |  |
| 145 | Prepare & Give Presentations |  |  | 35% → 30% |  |
| 146 | Obtain & Document Feedback |  |  | 35% → 4% |  |
| 147 | **Science Advisory Team Meetings** |  |  | 42% → 19% |  |
| 148 | Prepare Minutes, Presentations & KAONs | 2008-06-09 A → 2008-06-09 |  | 45% → 0% |  |
| 150 | Evaluate Science Impact of Proposed Changes |  |  | 40% → 20% |  |
| 151 | **Requirements** |  |  | 64% → 27% |  |
| 152 | **Operations Concept Document (OCD)** |  |  | 50% → 19% |  |
| 154 | OCD Release 1 |  | 2009-01-30 A → 2009-01-30 | 100% → 25% | none → 296d |
| 156 | **System Requirements (SRD)** | 2008-12-01 A → 2008-12-01 |  | 50% → 0% |  |
| 157 | SRD Release I | 2008-12-01 A → 2008-12-01 | 2008-12-12 A → 2008-12-12 | 100% → 0% | none → 331d |
| 159 | **Functional Requirements (FRD)** |  |  | 61% → 27% |  |
| 160 | FRD Release 1 |  | 2008-08-29 A → 2008-08-29 | 100% → 70% | none → 406d |
| 162 | Compliance Matrix | 2008-10-06 A → 2008-10-06 | 2008-10-31 A → 2008-10-31 | 100% → 0% | none → 361d |
| 163 | Software Standards (Define & Document) |  | 2008-11-17 A → 2008-11-17 | 100% → 90% | none → 350d |
| 164 | Component Standards (Define & Document) | 2008-11-03 A → 2008-11-03 | 2008-12-05 A → 2008-12-05 | 100% → 0% | none → 336d |
| 165 | **Systems Engineering Analysis** |  |  | 49% → 16% |  |

| ID | Task | Start | Finish | Complete | Total float |
| --- | --- | --- | --- | --- | --- |
| 166 | **Performance Budgets** |  |  | 59% → 17% |  |
| 168 | **Throughput & Background Budget** |  | 2008-12-12 A → 2008-12-12 | 100% → 35% | none → 331d |
| 169 | Thermal Background Analysis Software with Documentation |  | 2008-11-21 A → 2008-11-21 | 100% → 25% | none → 346d |
| 170 | Thermal Analysis |  | 2008-12-12 A → 2008-12-12 | 100% → 50% | none → 331d |
| 171 | **Wavefront & Encircled Energy** |  |  | 48% → 29% |  |
| 172 | **WFE/EE Budget Tool** |  |  | 65% → 38% |  |
| 173 | NGS TT & TTFA Sharpening Budgets |  | 2008-11-18 A → 2008-11-18 | 100% → 10% | none → 349.5d |
| 174 | Improved Bandwidth Model | 2008-12-01 A → 2008-12-01 | 2009-01-02 A → 2009-01-02 | 100% → 0% | none → 316d |
| 175 | Improved Atmospheric Dispersion Model | 2008-09-01 A → 2008-09-01 | 2008-09-19 A → 2008-09-19 | 100% → 0% | none → 391d |
| 176 | Other (NFIRAOS budget comparison) | 2009-05-04 A | 2009-06-24 A | 0% → 100% | 193d → none |
| 177 | **WFE/EE Performance Analysis** | 2009-06-01 A |  | 0% → 5% |  |
| 178 | Key Science Cases Analysis | 2009-06-01 A |  | 0% → 10% |  |
| 180 | **Astrometric Precision** | 2008-10-06 A → 2008-10-06 |  | 78% → 0% |  |
| 181 | Develop Astrometric Budget Tool | 2008-10-06 A → 2008-10-06 |  | 95% → 0% |  |
| 182 | Galactic Center Astrometric Analysis | 2009-01-05 A → 2009-01-05 |  | 55% → 0% |  |
| 183 | **Observing Efficiency** | 2008-06-24 A → 2008-06-24 |  | 50% → 0% |  |
| 184 | Observing Efficiency Tool | 2008-06-24 A → 2008-06-24 | 2008-06-30 A → 2008-06-30 | 100% → 0% | none → 450d |
| 186 | **Observing Uptime** | 2008-12-01 A → 2008-12-01 |  | 50% → 0% |  |
| 187 | Observing Uptime Tool | 2008-12-01 A → 2008-12-01 | 2008-12-12 A → 2008-12-12 | 100% → 0% | none → 331d |
| 189 | **Modeling & Analysis** |  |  | 69% → 30% |  |
| 191 | Performance vs T/T NGS Report | 2008-09-01 A → 2008-09-01 |  | 60% → 0% |  |
| 193 | PSF Libraries | 2008-11-03 A → 2008-11-03 | 2008-12-19 A → 2008-12-19 | 100% → 0% | none → 326d |
| 195 | **System Architecture** |  |  | 47% → 12% |  |
| 196 | **System Hardware Architecture** |  |  | 52% → 29% |  |
| 197 | Hybrid Rayleigh / Sodium Trade Study |  |  | 90% → 50% |  |
| 198 | Degraded Laser Power Trade Study |  | 2008-08-15 A → 2008-08-15 | 100% → 70% | none → 416d |
| 199 | System Architecture: Evaluate & Document Changes |  |  | 45% → 25% |  |
| 200 | **Software Architecture** |  |  | 43% → 3% |  |
| 201 | Evaluate Software Architecture Options |  | 2008-08-22 A → 2008-08-22 | 100% → 50% | none → 391d |
| 202 | Determine/Document Software Arch Approach | 2008-08-25 A → 2008-08-25 | 2008-09-19 A → 2008-09-19 | 100% → 0% | none → 391d |
| 203 | Software Architecture: Evaluate & Document Changes | 2008-09-22 A → 2008-09-22 |  | 35% → 0% |  |
| 204 | **Control Systems Architecture** |  |  | 33% → 9% |  |
| 205 | Evaluate Control Systems Arch Options |  | 2008-11-14 A → 2008-11-14 | 100% → 50% | none → 315d |
| 206 | Determine/Document Control Systems Arch | 2008-11-17 A → 2008-11-17 | 2009-01-05 A → 2009-01-05 | 100% → 0% | none → 315d |
| 207 | Evaluate Motion Control Arch Options |  |  | 40% → 30% |  |
| 209 | Control Systems Architecture: Evaluate & Document Changes | 2009-01-08 A → 2009-01-08 |  | 10% → 0% |  |
| 210 | **Operations Sequences Architecture** | 2008-05-05 A → 2008-05-05 |  | 56% → 0% |  |
| 211 | Define Required System Level Sequences | 2008-05-05 A → 2008-05-05 | 2008-05-16 A → 2008-05-16 | 100% → 0% | none → 481d |
| 212 | Develop System Level Sequences Approach | 2008-05-19 A → 2008-05-19 | 2008-06-06 A → 2008-06-06 | 100% → 0% | none → 466d |
| 213 | Sequences Definition Document | 2008-06-09 A → 2008-06-09 | 2008-06-27 A → 2008-06-27 | 100% → 0% | none → 451d |
| 214 | Sequences: Evaluate & Document Changes | 2008-07-07 A → 2008-07-07 |  | 50% → 0% |  |
| 215 | **External Interface Control** |  |  | 92% → 5% |  |
| 216 | **Observatory Interfaces** |  |  | 67% → 16% |  |
| 217 | AO System ICD | 2009-02-02 A |  | 0% → 25% |  |
| 218 | Laser System ICD |  | 2008-10-17 A → 2008-10-17 | 100% → 25% | none → 371d |
| 219 | Science Tools ICD |  | 2008-10-31 A → 2008-10-31 | 100% → 5% | none → 361d |
| 220 | **Science Instrument Interfaces to NGAO** |  | 2008-11-28 A → 2008-11-28 | 100% → 1% | none → 341d |
| 221 | Generic Science Instrument ICD to AO |  | 2008-10-31 A → 2008-10-31 | 100% → 5% | none → 361d |
| 222 | Generic Science Instrument ICD to NGAO Science Tools | 2008-10-06 A → 2008-10-06 | 2008-10-31 A → 2008-10-31 | 100% → 0% | none → 361d |
| 223 | Interferometer Specific ICD | 2008-11-03 A → 2008-11-03 | 2008-11-28 A → 2008-11-28 | 100% → 0% | none → 341d |
| 224 | OSIRIS Specific ICD | 2008-11-03 A → 2008-11-03 | 2008-11-28 A → 2008-11-28 | 100% → 0% | none → 341d |
| 225 | NIR Camera Specific ICD | 2008-11-03 A → 2008-11-03 | 2008-11-28 A → 2008-11-28 | 100% → 0% | none → 341d |
| 226 | Visible Camera Specific ICD | 2008-11-03 A → 2008-11-03 | 2008-11-28 A → 2008-11-28 | 100% → 0% | none → 341d |
| 227 | d-IFS Specific ICD | 2008-11-03 A → 2008-11-03 | 2008-11-28 A → 2008-11-28 | 100% → 0% | none → 341d |
| 228 | **Internal Interface Control** |  | 2008-12-19 A → 2008-12-19 | 100% → 25% | none → 326d |
| 229 | Diagram & Document Draft Outline |  | 2008-09-26 A → 2008-09-26 | 100% → 25% | none → 386d |
| 230 | Interface N-Squared Diagram |  | 2008-11-07 A → 2008-11-07 | 100% → 25% | none → 356d |
| 231 | Interface Definition Document |  | 2008-12-19 A → 2008-12-19 | 100% → 25% | none → 326d |
| 232 | **Configuration Control** | 2009-10-05 A |  | 0% → 10% |  |
| 233 | Change Control Guidelines & Tools Definition | 2009-10-05 A |  | 0% → 10% |  |
| 234 | **Documentation Control** | 2009-01-12 A → 2009-01-12 | 2009-01-16 A → 2009-01-16 | 100% → 0% | none → 306d |
| 235 | Document Control Guidelines & Tools Definition | 2009-01-12 A → 2009-01-12 | 2009-01-16 A → 2009-01-16 | 100% → 0% | none → 306d |
| 236 | **Technical Risk Assessment & Mitigation** |  |  | 75% → 23% |  |
| 237 | **Risk Assessment** | 2008-10-13 A → 2008-10-13 |  | 52% → 0% |  |
| 238 | Risk Assessment v1 | 2008-10-13 A → 2008-10-13 | 2008-10-30 A → 2008-10-30 | 100% → 0% | none → 362d |
| 240 | **Risk Mitigation Efforts** |  |  | 77% → 26% |  |
| 241 | **PSF Calibration** |  | 2009-01-30 A → 2009-01-30 | 100% → 60% | none → 296d |
| 242 | Support/Monitor Profiler Implementation |  | 2009-01-30 A → 2009-01-30 | 100% → 60% | none → 296d |
| 243 | **Sky Coverage** | 2008-10-06 A → 2008-10-06 |  | 60% → 0% |  |
| 244 | Prototype NIR Tip/tilt Sensor | 2008-10-06 A → 2008-10-06 |  | 60% → 0% |  |

| ID | Task | Start | Finish | Complete | Total float |
| --- | --- | --- | --- | --- | --- |
| 246 | **AO System Design** |  |  | 31% → 15% |  |
| 247 | AO Enclosure | 2008-10-01 A → 2008-10-01 |  | 60% → 0% |  |
| 248 | **Opto-Mechanical** |  |  | 22% → 14% |  |
| 249 | AO Support Structure |  | 2009-01-09 A → 2009-01-09 | 100% → 40% | none → 311d |
| 250 | Rotator | 2009-03-12 A |  | 0% → 20% |  |
| 251 | Optical Relays |  |  | 30% → 50% |  |
| 252 | Optical Switchyard |  | 2008-11-07 A → 2008-11-07 | 100% → 20% | none → 356d |
| 291 | **Atmospheric Dispersion Correctors** |  |  | 10% → 28% |  |
| 292 | LOWFS ADCs |  |  | 20% → 40% |  |
| 293 | NIR Science ADC | 2008-12-24 A |  | 0% → 15% |  |
| 294 | Visible Science & NGS WFS ADC | 2009-02-23 A |  | 0% → 15% |  |
| 310 | **AO Sequencer** | 2009-02-02 A |  | 0% → 3% |  |
| 311 | AO Sequencer: Architecture | 2009-02-02 A |  | 0% → 10% |  |
| 337 | **AO Motion Control Electronics** | 2009-01-19 A → 2009-01-19 |  | 10% → 0% |  |
| 338 | Motion Control HW: Spreadsheet | 2009-01-19 A → 2009-01-19 |  | 10% → 0% |  |
| 359 | **Real-time Control** |  |  | 51% → 25% |  |
| 360 | **RTC Processor** |  |  | 44% → 27% |  |
| 361 | RTC Technical Management |  |  | 40% → 30% |  |
| 362 | Centroid/Wavefront Reconstruction Processing Requirements |  | 2008-10-03 A → 2008-10-03 | 100% → 30% | none → 381d |
| 363 | Centroid/Wavefront Reconstruction Test Definition | 2008-09-08 A → 2008-09-08 | 2008-11-11 A → 2008-11-11 | 100% → 0% | none → 354d |
| 365 | Preconditioning & Scaling Processing Test Definition | 2008-12-29 A → 2008-12-29 |  | 90% → 0% |  |
| 369 | Camera Data Transfer Issues | 2009-07-27 A |  | 0% → 35% |  |
| 370 | Radial versus Rectilinear Voxels Trade Study | 2008-11-03 A → 2008-11-03 |  | 70% → 0% |  |
| 375 | Diagnostic Control & I/O Requirements | 2009-02-02 A |  | 0% → 65% |  |
| 377 | Define Testing Procedures |  | 2008-11-28 A → 2008-11-28 | 100% → 35% | none → 341d |
| 378 | Documentation | 2009-06-08 A |  | 0% → 20% |  |
| 379 | **DMs & Tip/Tilt Stages** |  |  | 87% → 19% |  |
| 380 | **Woofer DM/TT** |  |  | 89% → 11% |  |
| 381 | Define Requirements |  | 2008-10-31 A → 2008-10-31 | 100% → 25% | none → 361d |
| 382 | Evaluate Tip/Tilt Mount Options |  | 2009-01-09 A → 2009-01-09 | 100% → 3% | none → 311d |
| 383 | Evaluate Combined DM & Tip/Tilt Performance |  | 2009-01-23 A → 2009-01-23 | 100% → 10% | none → 301d |
| 384 | Select Tip/Tilt Mount |  | 2009-01-30 A → 2009-01-30 | 100% → 2% | none → 296d |
| 386 | Obtain Quotes |  | 2009-01-30 A → 2009-01-30 | 100% → 20% | none → 296d |
| 387 | **Tweeter DM/TT** |  |  | 86% → 28% |  |
| 388 | Define Requirements |  | 2008-10-31 A → 2008-10-31 | 100% → 50% | none → 361d |
| 389 | Evaluate Options & Select Tip/Tilt Mount |  | 2008-11-28 A → 2008-11-28 | 100% → 8% | none → 341d |
| 391 | Obtain Quotes |  | 2008-11-28 A → 2008-11-28 | 100% → 40% | none → 341d |
| 392 | **LOWFS DM/TT** |  |  | 85% → 20% |  |
| 393 | Define Requirements including LOWFS Interface |  | 2008-10-31 A → 2008-10-31 | 100% → 30% | none → 0d |
| 394 | Evaluate Options & Select Tip/Tilt Mount |  | 2008-11-28 A → 2008-11-28 | 100% → 16% | none → 0d |
| 395 | Design Mechanical Package | 2009-01-12 A → 2009-01-12 |  | 50% → 0% |  |
| 396 | Obtain Quotes |  | 2008-11-28 A → 2008-11-28 | 100% → 40% | none → 341d |
| 402 | **Laser System Design** |  |  | 31% → 27% |  |
| 403 | **Laser Enclosure (LE)** | 2009-01-19 A → 2009-01-19 |  | 16% → 0% |  |
| 404 | LE Requirements & Interfaces | 2009-01-19 A → 2009-01-19 |  | 40% → 0% |  |
| 408 | **Laser** |  |  | 66% → 55% |  |
| 409 | Laser Project Management |  |  | 65% → 50% |  |
| 410 | **Laser Requirements** |  | 2008-10-03 A → 2008-10-03 | 100% → 61% | none → 381d |
| 411 | Laser Performance Analysis | 2008-05-05 A → 2008-05-05 | 2008-05-30 A → 2008-05-30 | 100% → 0% | none → 441d |
| 412 | Laser Requirements Analysis |  | 2008-06-27 A → 2008-06-27 | 100% → 75% | none → 426d |
| 413 | Laser Requirements Development |  | 2008-07-25 A → 2008-07-25 | 100% → 75% | none → 411d |
| 414 | Laser Requirements Drafting and Revisions |  | 2008-10-03 A → 2008-10-03 | 100% → 75% | none → 381d |
| 415 | **Laser Preliminary ICD** | 2008-07-28 A → 2008-07-28 | 2008-08-22 A → 2008-08-22 | 100% → 0% | none → 411d |
| 416 | Laser ICD Drafting and Revisions | 2008-07-28 A → 2008-07-28 | 2008-08-22 A → 2008-08-22 | 100% → 0% | none → 411d |
| 417 | **Laser Request for Proposals (RFP)** |  | 2009-02-06 A | 93% → 100% | 211d → none |
| 420 | Laser Proposal Response Period |  | 2009-02-06 A | 90% → 100% | 211d → none |
| 421 | **Laser RFP Response Report** | 2009-02-09 A |  | 0% → 50% | 211d → 251d |
| 422 | Laser Proposal Evaluation | 2009-02-09 A | 2009-03-06 A | 0% → 100% | 211d → none |
| 423 | Laser Response Discussions | 2009-03-09 A |  | 0% → 25% |  |
| 424 | Laser Report Drafting and Revisions | 2009-03-09 A |  | 0% → 25% | 211d → 216d |
| 425 | **Laser Contract** | 2009-04-06 A |  | 0% → 13% |  |
| 426 | Laser Contract Drafting and Revisions | 2009-04-06 A |  | 0% → 25% |  |
| 428 | **Laser Launch Facility (LLF)** |  |  | 2% → 10% |  |
| 429 | LLF Requirements & Interfaces |  |  | 25% → 2% | 0d → 286d |
| 431 | LLF Launch Telescope Preliminary Design Contract | 2009-03-16 A |  | 0% → 25% |  |
| 460 | **Science Operations Tools Design** |  |  | 34% → 0% |  |
| 461 | **Multi-Systems Command Sequencer (MCS)** |  |  | 97% → 0% |  |
| 462 | **MCS Infrastructure** |  |  | 99% → 0% |  |
| 463 | **MCS Infrastructure Architecture** |  | 2008-10-24 A → 2008-10-24 | 100% → 0% | none → 366d |
| 464 | MCS Architecture |  | 2008-10-24 A → 2008-10-24 | 100% → 1% | none → 366d |

| ID | Task | Start | Finish | Complete | Total float |
| --- | --- | --- | --- | --- | --- |
| 465 | MCS Operations Concept Document | 2008-07-07 A → 2008-07-07 | 2008-10-24 A → 2008-10-24 | 100% → 0% | none → 366d |
| 466 | MCS Software Requirements | 2008-07-07 A → 2008-07-07 | 2008-10-24 A → 2008-10-24 | 100% → 0% | none → 366d |
| 467 | MCS Module Definitions | 2008-07-07 A → 2008-07-07 | 2008-10-24 A → 2008-10-24 | 100% → 0% | none → 366d |
| 468 | **Coordination Sequence Support Library** | 2008-07-07 A → 2008-07-07 |  | 99% → 0% |  |
| 469 | Functional Requirements | 2008-07-07 A → 2008-07-07 | 2008-10-24 A → 2008-10-24 | 100% → 0% | none → 366d |
| 471 | **Command Interface** | 2008-07-07 A → 2008-07-07 |  | 99% → 0% |  |
| 472 | Functional Requirements | 2008-07-07 A → 2008-07-07 | 2008-10-24 A → 2008-10-24 | 100% → 0% | none → 366d |
| 474 | **System Health** | 2008-07-07 A → 2008-07-07 |  | 99% → 0% |  |
| 475 | Functional Requirements | 2008-07-07 A → 2008-07-07 | 2008-10-24 A → 2008-10-24 | 100% → 0% | none → 366d |
| 477 | **Setup Sequences: Configuration & Calibration** | 2008-07-01 A → 2008-07-01 |  | 99% → 0% |  |
| 478 | **Setup Sequences Common Structure** | 2008-07-01 A → 2008-07-01 | 2008-10-31 A → 2008-10-31 | 100% → 0% | none → 361d |
| 479 | Setup Sequences Operations Concept Document | 2008-07-01 A → 2008-07-01 | 2008-10-31 A → 2008-10-31 | 100% → 0% | none → 361d |
| 480 | Setup Sequences Software Requirements | 2008-07-01 A → 2008-07-01 | 2008-10-31 A → 2008-10-31 | 100% → 0% | none → 361d |
| 481 | Setup Sequences Module Definitions | 2008-07-01 A → 2008-07-01 | 2008-10-31 A → 2008-10-31 | 100% → 0% | none → 361d |
| 482 | **Configuration Sequences** | 2008-07-01 A → 2008-07-01 |  | 99% → 0% |  |
| 483 | Functional Requirements | 2008-07-01 A → 2008-07-01 | 2008-10-31 A → 2008-10-31 | 100% → 0% | none → 361d |
| 485 | **Calibration Sequences** | 2008-07-01 A → 2008-07-01 |  | 99% → 0% |  |
| 486 | Functional Requirements | 2008-07-01 A → 2008-07-01 | 2008-10-31 A → 2008-10-31 | 100% → 0% | none → 361d |
| 488 | **Observing Sequences** | 2008-10-01 A → 2008-10-01 |  | 95% → 0% |  |
| 489 | **Observing Sequences Common Structure** | 2008-10-01 A → 2008-10-01 |  | 95% → 0% |  |
| 490 | Observing Sequences Operations Concept Document | 2008-10-01 A → 2008-10-01 |  | 95% → 0% |  |
| 491 | Observing Sequences Software Requirements | 2008-10-01 A → 2008-10-01 |  | 95% → 0% |  |
| 492 | Observing Sequences Module Definitions | 2008-10-01 A → 2008-10-01 |  | 95% → 0% |  |
| 493 | **Acquisition Sequences** | 2008-10-01 A → 2008-10-01 |  | 95% → 0% |  |
| 494 | Functional Requirements | 2008-10-01 A → 2008-10-01 |  | 95% → 0% |  |
| 495 | Interface Definitions | 2008-10-01 A → 2008-10-01 |  | 95% → 0% |  |
| 496 | **Observing Sequences** | 2008-10-01 A → 2008-10-01 |  | 94% → 0% |  |
| 497 | Functional Requirements | 2008-10-01 A → 2008-10-01 |  | 95% → 0% |  |
| 499 | **Quality Monitoring Sequences** | 2008-10-01 A → 2008-10-01 |  | 94% → 0% |  |
| 500 | Functional Requirements | 2008-10-01 A → 2008-10-01 |  | 95% → 0% |  |
| 502 | **Optimization Sequences** | 2008-10-01 A → 2008-10-01 |  | 94% → 0% |  |
| 503 | Functional Requirements | 2008-10-01 A → 2008-10-01 |  | 95% → 0% |  |
| 505 | **Alarm Handler & Troubleshooting Sequences** | 2008-10-01 A → 2008-10-01 |  | 94% → 0% |  |
| 506 | **Alarm Handler & Troubleshooting Common Structure** | 2008-10-01 A → 2008-10-01 |  | 95% → 0% |  |
| 507 | Alarm & Troubleshooting Operations Concept Document | 2008-10-01 A → 2008-10-01 |  | 95% → 0% |  |
| 508 | Alarm & Troubleshooting Software Requirements | 2008-10-01 A → 2008-10-01 |  | 95% → 0% |  |
| 509 | Alarm & Troubleshooting Module Definitions | 2008-10-01 A → 2008-10-01 |  | 95% → 0% |  |
| 516 | **User Interfaces** | 2008-07-01 A → 2008-07-01 |  | 46% → 0% |  |
| 517 | **User Interface (UI) Infrastructure** | 2008-07-01 A → 2008-07-01 |  | 88% → 0% |  |
| 518 | **UI Infrastructure Architecture** | 2008-07-01 A → 2008-07-01 | 2008-10-31 A → 2008-10-31 | 100% → 0% | none → 361d |
| 519 | UI Architecture | 2008-07-01 A → 2008-07-01 | 2008-10-31 A → 2008-10-31 | 100% → 0% | none → 361d |
| 520 | UI Operations Concept Document | 2008-07-01 A → 2008-07-01 | 2008-10-31 A → 2008-10-31 | 100% → 0% | none → 361d |
| 521 | UI Software Requirements | 2008-07-01 A → 2008-07-01 | 2008-10-31 A → 2008-10-31 | 100% → 0% | none → 361d |
| 522 | UI Module Definitions | 2008-07-01 A → 2008-07-01 | 2008-10-31 A → 2008-10-31 | 100% → 0% | none → 361d |
| 523 | **UI Command Interface to MCS** | 2008-07-01 A → 2008-07-01 | 2008-10-31 A → 2008-10-31 | 100% → 0% | none → 361d |
| 524 | Functional Requirements | 2008-07-01 A → 2008-07-01 | 2008-10-31 A → 2008-10-31 | 100% → 0% | none → 361d |
| 525 | Interface Definitions | 2008-07-01 A → 2008-07-01 | 2008-10-31 A → 2008-10-31 | 100% → 0% | none → 361d |
| 526 | **UI Command Interface to Pre- & Post-Observing Tools** | 2008-07-01 A → 2008-07-01 |  | 50% → 0% |  |
| 527 | Functional Requirements | 2008-07-01 A → 2008-07-01 | 2008-10-31 A → 2008-10-31 | 100% → 0% | none → 361d |
| 529 | **Setup User Interfaces** | 2008-10-01 A → 2008-10-01 |  | 46% → 0% |  |
| 530 | **Setup UI Common Structure** | 2008-10-01 A → 2008-10-01 |  | 65% → 0% |  |
| 531 | Setup UI Operations Concept Document | 2008-10-01 A → 2008-10-01 |  | 65% → 0% |  |
| 532 | Setup UI Software Requirements | 2008-10-01 A → 2008-10-01 |  | 65% → 0% |  |
| 533 | Setup UI Module Definitions | 2008-10-01 A → 2008-10-01 |  | 65% → 0% |  |
| 534 | **Setup UI Configurations** | 2008-10-01 A → 2008-10-01 |  | 33% → 0% |  |
| 535 | Functional Requirements | 2008-10-01 A → 2008-10-01 |  | 65% → 0% |  |
| 537 | **Setup UI Calibrations** | 2008-10-01 A → 2008-10-01 |  | 33% → 0% |  |
| 538 | Functional Requirements | 2008-10-01 A → 2008-10-01 |  | 65% → 0% |  |
| 540 | **Observations User Interfaces** | 2008-10-01 A → 2008-10-01 |  | 33% → 0% |  |
| 541 | **Observations UI Common Structure** | 2008-10-01 A → 2008-10-01 |  | 44% → 0% |  |
| 542 | Observations UI Operations Concept Document | 2008-10-01 A → 2008-10-01 |  | 33% → 0% | 0d → 211d |
| 543 | Observations UI Software Requirements | 2008-10-01 A → 2008-10-01 |  | 50% → 0% |  |
| 544 | Observations UI Module Definitions | 2008-10-01 A → 2008-10-01 |  | 50% → 0% |  |
| 545 | **Acquisition & AO Control UI** | 2008-10-01 A → 2008-10-01 |  | 50% → 0% |  |
| 546 | Functional Requirements | 2008-10-01 A → 2008-10-01 |  | 50% → 0% |  |
| 547 | Interface Definitions | 2008-10-01 A → 2008-10-01 |  | 50% → 0% |  |
| 548 | **Observing Sequences UI** | 2008-10-01 A → 2008-10-01 |  | 25% → 0% |  |
| 549 | Functional Requirements | 2008-10-01 A → 2008-10-01 |  | 50% → 0% |  |
| 551 | **Status & Graph UI** | 2008-10-01 A → 2008-10-01 |  | 25% → 0% |  |
| 552 | Functional Requirements | 2008-10-01 A → 2008-10-01 |  | 50% → 0% |  |

| ID | Task | Start | Finish | Complete | Total float |
| --- | --- | --- | --- | --- | --- |
| 554 | **Advanced Monitoring UI** | 2008-10-01 A → 2008-10-01 |  | 25% → 0% |  |
| 555 | Functional Requirements | 2008-10-01 A → 2008-10-01 |  | 50% → 0% |  |
| 557 | **Optimization & Troubleshooting UI** | 2008-10-01 A → 2008-10-01 |  | 25% → 0% |  |
| 558 | Functional Requirements | 2008-10-01 A → 2008-10-01 |  | 50% → 0% |  |
| 560 | **Pre- & Post-Observing Science Support Tools** | 2009-01-01 A → 2009-01-01 |  | 4% → 0% |  |
| 561 | **User Documentation** | 2009-01-01 A → 2009-01-01 |  | 10% → 0% |  |
| 562 | User Documentation Operations Concept | 2009-01-01 A → 2009-01-01 |  | 10% → 0% |  |
| 563 | User Documentation Functional Requirements | 2009-01-01 A → 2009-01-01 |  | 10% → 0% |  |
| 564 | **Science Observations Planning Tools** | 2009-01-07 A → 2009-01-07 |  | 6% → 0% |  |
| 565 | **NGS Star Finder** | 2009-01-07 A → 2009-01-07 |  | 5% → 0% |  |
| 566 | Operations Concept | 2009-01-07 A → 2009-01-07 |  | 10% → 0% |  |
| 567 | Functional Requirements & Use Case Definitions | 2009-01-07 A → 2009-01-07 |  | 10% → 0% |  |
| 570 | **Performance Prediction Tool** | 2009-01-07 A → 2009-01-07 |  | 10% → 0% |  |
| 571 | Operations Concept | 2009-01-07 A → 2009-01-07 |  | 10% → 0% |  |
| 572 | Functional Requirements & Use Case Definitions | 2009-01-07 A → 2009-01-07 |  | 10% → 0% |  |
| 573 | Interface Definitions | 2009-01-07 A → 2009-01-07 |  | 10% → 0% |  |
| 574 | Module Definitions | 2009-01-07 A → 2009-01-07 |  | 10% → 0% |  |
| 575 | **Observation Planning & Efficiency Tool** | 2009-01-07 A → 2009-01-07 |  | 10% → 0% |  |
| 576 | Operations Concept | 2009-01-07 A → 2009-01-07 |  | 10% → 0% |  |
| 577 | Functional Requirements & Use Case Definitions | 2009-01-07 A → 2009-01-07 |  | 10% → 0% |  |
| 578 | Interface Definitions | 2009-01-07 A → 2009-01-07 |  | 10% → 0% |  |
| 579 | Module Definitions | 2009-01-07 A → 2009-01-07 |  | 10% → 0% |  |
| 611 | **Telescope & Summit Engineering Design** | 2008-12-08 A → 2008-12-08 |  | 19% → 0% |  |
| 626 | OSIRIS Modifications | 2009-01-12 A → 2009-01-12 | 2009-01-30 A → 2009-01-30 | 100% → 0% | none → 296d |
| 627 | **Interferometer Modifications** | 2008-12-08 A → 2008-12-08 | 2009-01-30 A → 2009-01-30 | 100% → 0% | none → 296d |
| 628 | Optical Design of Post Field Selector Optics | 2008-12-08 A → 2008-12-08 | 2009-01-30 A → 2009-01-30 | 100% → 0% | none → 296d |
| 629 | Evaluation of Optical Design Impact on Interferometer | 2008-12-08 A → 2008-12-08 | 2009-01-30 A → 2009-01-30 | 100% → 0% | none → 296d |
| 648 | **Operations Transition** | 2009-01-09 A → 2009-01-09 |  | 3% → 0% |  |
| 652 | **Operations Handover** | 2009-01-09 A → 2009-01-09 |  | 4% → 0% |  |
| 654 | Documentation Transition Plan | 2009-01-09 A → 2009-01-09 |  | 5% → 0% |  |

## Version 11 (saved 2009-03-17, file NGAO_Design_v14_tracked_Feb09.mpp)

Last finish stays 2010-03-22. Complete tasks 17 → 19.

Changed:

| ID | Task | Start | Finish | Complete | Total float |
| --- | --- | --- | --- | --- | --- |
| 1 | **NGAO Design** |  |  | 13% → 15% |  |
| 4 | **Preliminary Design** |  |  | 14% → 15% |  |
| 6 | **PD Phase Management** |  |  | 34% → 38% |  |
| 7 | **Planning** |  |  | 12% → 17% |  |
| 12 | **WMKO FY Plans** |  |  | 23% → 35% |  |
| 14 | Support WMKO FY10 Planning |  |  | 5% → 20% |  |
| 25 | **Project Management & Meetings** |  |  | 40% → 45% |  |
| 26 | **Executive Committee** |  |  | 40% → 45% |  |
| 27 | Executive Committee Management Activities |  |  | 40% → 45% |  |
| 28 | Executive Committee Telecons |  |  | 40% → 45% |  |
| 29 | **Team Meetings** |  |  | 39% → 44% |  |
| 30 | Meeting Participation |  |  | 39% → 44% |  |
| 57 | **Tracking & Reporting** |  |  | 35% → 40% |  |
| 58 | **Monthly Status Reports** |  |  | 40% → 45% |  |
| 59 | Monthly Team Status Reports |  |  | 39% → 44% |  |
| 60 | Monthly Project Reports (TSIP, Directors) |  |  | 40% → 45% |  |
| 61 | TSIP Project Report Telecons |  |  | 40% → 45% |  |
| 62 | **SSC Meetings** |  |  | 26% → 39% |  |
| 66 | SSC Meeting (Keck) | 2009-02-19 A | 2009-02-20 A | 0% → 100% | 281.88d → none |
| 81 | **Programmatic Risk Assessment & Mitigation** |  |  | 45% → 49% |  |
| 85 | **Risk Mitigation** |  |  | 45% → 49% |  |
| 86 | Laser Procurement |  |  | 60% → 65% |  |
| 87 | Science Instruments |  |  | 10% → 15% |  |
| 100 | **Project Support** |  |  | 38% → 43% |  |
| 101 | Administrative/Contract Support |  |  | 38% → 43% |  |
| 102 | Shared Infrastructure |  |  | 35% → 40% |  |
| 103 | Research Time |  |  | 40% → 45% |  |
| 195 | **System Architecture** |  |  | 12% → 14% |  |
| 196 | **System Hardware Architecture** |  |  | 29% → 30% |  |
| 198 | Degraded Laser Power Trade Study |  |  | 70% → 75% |  |
| 200 | **Software Architecture** |  |  | 3% → 5% |  |
| 201 | Evaluate Software Architecture Options |  |  | 50% → 75% |  |
| 204 | **Control Systems Architecture** |  |  | 9% → 14% |  |
| 205 | Evaluate Control Systems Arch Options |  |  | 50% → 75% |  |
| 207 | Evaluate Motion Control Arch Options |  |  | 30% → 50% |  |
| 215 | **External Interface Control** |  |  | 5% → 6% |  |
| 216 | **Observatory Interfaces** |  |  | 16% → 22% |  |
| 217 | AO System ICD |  |  | 25% → 35% |  |
| 218 | Laser System ICD |  |  | 25% → 35% |  |
| 246 | **AO System Design** |  |  | 15% → 21% |  |
| 248 | **Opto-Mechanical** |  |  | 14% → 18% |  |
| 249 | AO Support Structure |  |  | 40% → 60% |  |
| 251 | Optical Relays |  |  | 50% → 60% |  |
| 252 | Optical Switchyard |  |  | 20% → 40% |  |
| 308 | **Non-real-time Control** |  |  | 0% → 1% |  |
| 310 | **AO Sequencer** |  |  | 3% → 6% |  |
| 311 | AO Sequencer: Architecture |  |  | 10% → 25% |  |
| 359 | **Real-time Control** |  |  | 25% → 36% |  |
| 360 | **RTC Processor** |  |  | 27% → 38% |  |
| 361 | RTC Technical Management |  |  | 30% → 40% |  |
| 362 | Centroid/Wavefront Reconstruction Processing Requirements |  |  | 30% → 35% |  |
| 363 | Centroid/Wavefront Reconstruction Test Definition | 2008-09-08 A |  | 0% → 10% |  |
| 365 | Preconditioning & Scaling Processing Test Definition | 2008-12-29 A |  | 0% → 20% |  |
| 366 | Low Order WFS Processing Requirements | 2009-02-09 A |  | 0% → 5% |  |
| 367 | Low Order WFS Processing Test Definition | 2009-05-18 A |  | 0% → 5% |  |
| 370 | Radial versus Rectilinear Voxels Trade Study | 2008-11-03 A |  | 0% → 60% |  |
| 372 | Characterize Single Event Upset | 2009-08-24 A | 2009-10-02 A | 0% → 100% | 121d → none |
| 374 | Voxel Communication Parameters | 2009-11-30 A |  | 0% → 50% |  |
| 379 | **DMs & Tip/Tilt Stages** |  |  | 19% → 22% |  |
| 380 | **Woofer DM/TT** |  |  | 11% → 19% |  |
| 382 | Evaluate Tip/Tilt Mount Options |  |  | 3% → 18% | 311d → 0d |
| 383 | Evaluate Combined DM & Tip/Tilt Performance |  |  | 10% → 25% |  |
| 384 | Select Tip/Tilt Mount |  |  | 2% → 5% |  |
| 386 | Obtain Quotes |  |  | 20% → 25% |  |
| 402 | **Laser System Design** |  |  | 27% → 30% |  |
| 403 | **Laser Enclosure (LE)** | 2009-01-19 A |  | 0% → 20% |  |
| 404 | LE Requirements & Interfaces | 2009-01-19 A |  | 0% → 50% |  |
| 429 | LLF Requirements & Interfaces |  |  | 2% → 6% |  |
| 435 | **Laser Safety Systems** | 2009-08-03 A |  | 0% → 11% |  |
| 436 | **Personnel & Equipment Safety System** | 2009-08-03 A |  | 0% → 17% |  |

| ID | Task | Start | Complete |
| --- | --- | --- | --- |
| 439 | Safety Communication Protocols & Methods | 2009-08-17 A | 0% → 40% |
| 441 | Safety Electronics, Shutter & Interlocks | 2009-08-17 A | 0% → 50% |
| 449 | **Laser System Control (LSC)** |  | 3% → 8% |
| 450 | **LSC Software** |  | 4% → 9% |
| 452 | LSC Sequencer Software |  | 10% → 25% |
| 455 | **LSC Hardware** | 2009-04-28 A | 0% → 6% |
| 456 | LSC Hardware Requirements & Interfaces | 2009-04-28 A | 0% → 20% |
| 630 | **Telescope Integration & Test** | 2009-10-05 A | 0% → 5% |
| 631 | **Old AO/Laser Removal** | 2009-10-05 A | 0% → 35% |
| 633 | Laser Removal Plan | 2009-10-05 A | 0% → 70% |

## Version 12 (saved 2009-04-21, file NGAO_Design_v14_tracked_Mar09.mpp)

Last finish stays 2010-03-22. Complete tasks 19 → 24.

Changed:

| ID | Task | Start | Finish | Complete | Total float |
| --- | --- | --- | --- | --- | --- |
| 1 | **NGAO Design** |  |  | 15% → 19% |  |
| 4 | **Preliminary Design** |  |  | 15% → 20% |  |
| 6 | **PD Phase Management** |  |  | 38% → 43% |  |
| 7 | **Planning** |  |  | 17% → 26% |  |
| 12 | **WMKO FY Plans** |  |  | 35% → 60% |  |
| 14 | Support WMKO FY10 Planning |  |  | 20% → 50% |  |
| 25 | **Project Management & Meetings** |  |  | 45% → 48% |  |
| 26 | **Executive Committee** |  |  | 45% → 50% |  |
| 27 | Executive Committee Management Activities |  |  | 45% → 50% |  |
| 28 | Executive Committee Telecons |  |  | 45% → 50% |  |
| 57 | **Tracking & Reporting** |  |  | 40% → 44% |  |
| 58 | **Monthly Status Reports** |  |  | 45% → 49% |  |
| 59 | Monthly Team Status Reports |  |  | 44% → 48% |  |
| 60 | Monthly Project Reports (TSIP, Directors) |  |  | 45% → 50% |  |
| 61 | TSIP Project Report Telecons |  |  | 45% → 50% |  |
| 81 | **Programmatic Risk Assessment & Mitigation** |  |  | 49% → 56% |  |
| 85 | **Risk Mitigation** |  |  | 49% → 57% |  |
| 86 | Laser Procurement |  |  | 65% → 75% |  |
| 100 | **Project Support** |  |  | 43% → 47% |  |
| 101 | Administrative/Contract Support |  |  | 43% → 51% |  |
| 103 | Research Time |  |  | 45% → 50% |  |
| 104 | **Systems Engineering** |  |  | 18% → 30% |  |
| 105 | **Science Case Requirements** |  |  | 19% → 33% |  |
| 131 | **Science Observing Planning & Execution** |  |  | 5% → 15% |  |
| 132 | Key Science Driver Observing Scenarios |  |  | 10% → 30% |  |
| 134 | **Science Performance Input** |  |  | 15% → 23% |  |
| 135 | Define Science Driver Parameters for Performance Budgets |  | 2008-10-28 A | 50% → 100% | 364d → none |
| 137 | Input to Preliminary Operations Concept Document |  |  | 25% → 40% |  |
| 142 | **User Community Liaison** |  |  | 14% → 52% |  |
| 144 | **SSC & Keck Science Meeting** |  |  | 17% → 70% |  |
| 145 | Prepare & Give Presentations |  |  | 30% → 70% |  |
| 146 | Obtain & Document Feedback |  |  | 4% → 70% |  |
| 147 | **Science Advisory Team Meetings** |  |  | 19% → 45% |  |
| 149 | Refine Science Requirements |  |  | 40% → 60% |  |
| 150 | Evaluate Science Impact of Proposed Changes |  |  | 20% → 80% |  |
| 151 | **Requirements** |  |  | 27% → 31% |  |
| 152 | **Operations Concept Document (OCD)** |  |  | 19% → 30% |  |
| 154 | OCD Release 1 |  |  | 25% → 50% |  |
| 165 | **Systems Engineering Analysis** |  |  | 16% → 27% |  |
| 166 | **Performance Budgets** |  |  | 17% → 33% |  |
| 168 | **Throughput & Background Budget** |  |  | 35% → 80% |  |
| 169 | Thermal Background Analysis Software with Documentation |  | 2008-11-21 A | 25% → 100% | 346d → none |
| 171 | **Wavefront & Encircled Energy** |  |  | 29% → 55% |  |
| 172 | **WFE/EE Budget Tool** |  |  | 38% → 53% |  |
| 173 | NGS TT & TTFA Sharpening Budgets |  |  | 10% → 50% |  |
| 175 | Improved Atmospheric Dispersion Model | 2008-09-01 A |  | 0% → 25% |  |
| 177 | **WFE/EE Performance Analysis** |  |  | 5% → 63% |  |
| 178 | Key Science Cases Analysis |  | 2009-06-26 A | 10% → 100% | 191d → none |
| 179 | Additional Science Case Analysis | 2009-08-03 A |  | 0% → 25% |  |
| 189 | **Modeling & Analysis** |  |  | 30% → 39% |  |
| 191 | Performance vs T/T NGS Report | 2008-09-01 A |  | 0% → 38% |  |
| 195 | **System Architecture** |  |  | 14% → 21% |  |
| 196 | **System Hardware Architecture** |  |  | 30% → 51% |  |
| 198 | Degraded Laser Power Trade Study |  | 2008-08-15 A | 75% → 100% | 416d → none |
| 199 | System Architecture: Evaluate & Document Changes |  |  | 25% → 50% |  |
| 210 | **Operations Sequences Architecture** | 2008-05-05 A |  | 0% → 1% |  |
| 211 | Define Required System Level Sequences | 2008-05-05 A |  | 0% → 25% |  |
| 215 | **External Interface Control** |  |  | 6% → 5% |  |
| 216 | **Observatory Interfaces** |  |  | 22% → 16% |  |
| 217 | AO System ICD |  |  | 35% → 25% |  |
| 218 | Laser System ICD |  |  | 35% → 25% |  |
| 228 | **Internal Interface Control** |  |  | 25% → 50% |  |
| 229 | Diagram & Document Draft Outline |  |  | 25% → 50% |  |
| 230 | Interface N-Squared Diagram |  |  | 25% → 50% |  |
| 231 | Interface Definition Document |  |  | 25% → 50% |  |
| 236 | **Technical Risk Assessment & Mitigation** |  |  | 23% → 25% |  |
| 240 | **Risk Mitigation Efforts** |  |  | 26% → 28% |  |
| 241 | **PSF Calibration** |  |  | 60% → 65% |  |
| 242 | Support/Monitor Profiler Implementation |  |  | 60% → 65% |  |
| 246 | **AO System Design** |  |  | 21% → 25% |  |

| ID | Task | Start | Finish | Complete | Total float |
| --- | --- | --- | --- | --- | --- |
| 248 | **Opto-Mechanical** |  |  | 18% → 30% |  |
| 251 | Optical Relays |  |  | 60% → 70% |  |
| 253 | **LGS Wavefront Sensor Assembly** |  |  | 2% → 28% |  |
| 254 | Review concept design for LGS WFS assembly (includes OSM) |  | 2008-06-27 A | 20% → 100% | 269d → none |
| 255 | Develop to preliminary design level the opto-mechanical design for the LGS wavefront sensor unit. | 2008-06-30 A |  | 0% → 30% | 269d → 293.31d |
| 256 | Identify the issues with uplink TTM, asterism generation and OSM concepts to ensure it conforms to the dithering requirements. This is important when the LGSs have to move with the source | 2008-10-06 A |  | 0% → 38% | 269d → 285.28d |
| 257 | Develop to preliminary design level the opto-mechanical design for the LGS OSM. (overlaps with TT(FA) OSMs; hence costed there) | 2008-11-03 A |  | 0% → 15% | 269d → 283.78d |
| 258 | Package and model the assembly. | 2008-11-17 A |  | 0% → 10% | 269d → 273.45d |
| 260 | Identify the motion control needs and specify solutions. | 2008-12-25 A |  | 0% → 20% | 269d → 269.45d |
| 261 | Identify design risks and mitigation of the identified risks. | 2009-01-22 A |  | 0% → 10% |  |
| 263 | LGS WFS Assembly Documentation | 2009-02-11 A |  | 0% → 5% |  |
| 264 | **NGS WFS/TWFS Assembly** | 2009-04-16 A |  | 0% → 13% |  |
| 265 | Review concept design for NGS WFS and TWFS; jointly called NGS WFS assembly. | 2009-04-16 A |  | 0% → 50% | 128.5d → 134.45d |
| 266 | Develop to preliminary design level the opto-mechanical design for the NGS wavefront sensor assembly. | 2009-04-30 A |  | 0% → 10% | 128.5d → 131.65d |
| 267 | Check compliance of design with the design of the field steering mirror assembly. | 2009-06-09 A |  | 0% → 10% | 128.5d → 130.25d |
| 269 | Identify the motion control needs and specify solutions. | 2009-08-21 A |  | 0% → 25% |  |
| 270 | Identify design risks and mitigation of the identified risks. | 2009-09-01 A |  | 0% → 10% |  |
| 272 | NGS WFS Assembly Documentation | 2009-10-23 A |  | 0% → 5% |  |
| 273 | **Low Order Wavefront Sensor Assembly** |  |  | 6% → 17% |  |
| 274 | Review concept design for LOWFS assembly. |  |  | 50% → 75% | 148d → 211.6d |
| 276 | Develop to preliminary design level the opto-mechanical design for the tip-tilt and the TTFA-TWFS wavefront sensor units | 2009-01-12 A |  | 0% → 15% | 147d → 150d |
| 277 | Develop to preliminary design level the opto-mechanical design for the LOWFS OSM | 2009-02-13 A |  | 0% → 15% | 147d → 148d |
| 278 | Make sure that the design doesn't preclude the inclusion of a PSF monitor later | 2009-03-04 A |  | 0% → 10% | 147d → 147.67d |
| 279 | Package and model the assembly. | 2009-03-09 A |  | 0% → 10% |  |
| 281 | Identify the motion control needs and specify solutions. | 2009-04-10 A |  | 0% → 15% |  |
| 286 | **Tip/Tilt Vibration Mitigation** |  |  | 50% → 60% |  |
| 287 | TT Vibration Mitigation Analysis |  |  | 50% → 60% |  |
| 359 | **Real-time Control** |  |  | 36% → 39% |  |
| 360 | **RTC Processor** |  |  | 38% → 41% |  |
| 361 | RTC Technical Management |  |  | 40% → 45% |  |
| 362 | Centroid/Wavefront Reconstruction Processing Requirements |  |  | 35% → 40% |  |
| 374 | Voxel Communication Parameters |  |  | 50% → 70% |  |
| 379 | **DMs & Tip/Tilt Stages** |  |  | 22% → 29% |  |
| 380 | **Woofer DM/TT** |  |  | 19% → 27% |  |
| 381 | Define Requirements |  |  | 25% → 30% |  |
| 382 | Evaluate Tip/Tilt Mount Options |  |  | 18% → 23% |  |
| 386 | Obtain Quotes |  |  | 25% → 50% |  |
| 387 | **Tweeter DM/TT** |  |  | 28% → 37% |  |
| 389 | Evaluate Options & Select Tip/Tilt Mount |  |  | 8% → 30% | 341d → 0d |
| 391 | Obtain Quotes |  |  | 40% → 50% |  |
| 392 | **LOWFS DM/TT** |  |  | 20% → 26% |  |
| 394 | Evaluate Options & Select Tip/Tilt Mount |  |  | 16% → 30% |  |
| 396 | Obtain Quotes |  |  | 40% → 50% |  |
| 611 | **Telescope & Summit Engineering Design** | 2008-12-08 A |  | 0% → 1% |  |
| 620 | **Infrastructure modifications for Laser System** | 2009-05-04 A |  | 0% → 3% |  |
| 621 | Infrastructure Requirements & Interfaces | 2009-05-04 A |  | 0% → 2% |  |
| 622 | Infrastructure Mechanical Modifications | 2009-06-29 A |  | 0% → 10% |  |
| 625 | Infrastructure Implementation & Test Plans | 2009-08-31 A |  | 0% → 1% |  |
| 630 | **Telescope Integration & Test** |  |  | 5% → 6% |  |
| 642 | **Laser System Install + I&T** | 2009-11-02 A |  | 0% → 5% |  |
| 643 | Laser System Installation & Integration Plan | 2009-11-02 A |  | 0% → 10% |  |

## Version 13 (saved 2009-05-21, file NGAO_Design_v14_tracked_Apr09.mpp)

Last finish stays 2010-03-22. Complete tasks 24 → 25.

Changed:

| ID | Task | Start | Finish | Complete | Total float |
| --- | --- | --- | --- | --- | --- |
| 1 | **NGAO Design** |  |  | 19% → 20% |  |
| 4 | **Preliminary Design** |  |  | 20% → 21% |  |
| 6 | **PD Phase Management** |  |  | 43% → 47% |  |
| 7 | **Planning** |  |  | 26% → 31% |  |
| 8 | **Replans (PD phase)** |  |  | 35% → 44% |  |
| 9 | Replan based on SDR |  |  | 85% → 90% |  |
| 10 | Replan 1 |  |  | 40% → 60% |  |
| 12 | **WMKO FY Plans** |  |  | 60% → 72% |  |
| 14 | Support WMKO FY10 Planning |  |  | 50% → 65% |  |
| 25 | **Project Management & Meetings** |  |  | 48% → 54% |  |
| 26 | **Executive Committee** |  |  | 50% → 55% |  |
| 27 | Executive Committee Management Activities |  |  | 50% → 55% |  |
| 28 | Executive Committee Telecons |  |  | 50% → 55% |  |
| 29 | **Team Meetings** |  |  | 44% → 53% |  |
| 30 | Meeting Participation |  |  | 44% → 53% |  |
| 57 | **Tracking & Reporting** |  |  | 44% → 47% |  |
| 58 | **Monthly Status Reports** |  |  | 49% → 53% |  |
| 59 | Monthly Team Status Reports |  |  | 48% → 53% |  |
| 60 | Monthly Project Reports (TSIP, Directors) |  |  | 50% → 55% |  |
| 62 | **SSC Meetings** |  |  | 39% → 52% |  |
| 67 | SSC Meeting (CIT) | 2009-04-29 A | 2009-04-30 A | 0% → 100% | 232.88d → none |
| 81 | **Programmatic Risk Assessment & Mitigation** |  |  | 56% → 63% |  |
| 85 | **Risk Mitigation** |  |  | 57% → 64% |  |
| 86 | Laser Procurement |  |  | 75% → 85% |  |
| 100 | **Project Support** |  |  | 47% → 51% |  |
| 102 | Shared Infrastructure |  |  | 40% → 45% |  |
| 103 | Research Time |  |  | 50% → 55% |  |
| 104 | **Systems Engineering** |  |  | 30% → 28% |  |
| 105 | **Science Case Requirements** |  |  | 33% → 31% |  |
| 106 | **Science Case Requirements** |  |  | 16% → 17% |  |
| 107 | **Requirements for new Science Drivers** |  |  | 33% → 36% |  |
| 110 | Debris Disks & Young Stellar Objects |  |  | 10% → 20% |  |
| 118 | Extrasolar Planets |  |  | 14% → 20% |  |
| 131 | **Science Observing Planning & Execution** |  |  | 15% → 20% |  |
| 132 | Key Science Driver Observing Scenarios |  |  | 30% → 40% |  |
| 134 | **Science Performance Input** |  |  | 23% → 28% |  |
| 137 | Input to Preliminary Operations Concept Document |  |  | 40% → 50% |  |
| 142 | **User Community Liaison** |  |  | 52% → 36% |  |
| 144 | **SSC & Keck Science Meeting** |  |  | 70% → 48% |  |
| 146 | Obtain & Document Feedback |  |  | 70% → 25% |  |
| 147 | **Science Advisory Team Meetings** |  |  | 45% → 46% |  |
| 148 | Prepare Minutes, Presentations & KAONs | 2008-06-09 A |  | 0% → 1% |  |
| 151 | **Requirements** |  |  | 31% → 33% |  |
| 152 | **Operations Concept Document (OCD)** |  |  | 30% → 36% |  |
| 154 | OCD Release 1 |  |  | 50% → 65% |  |
| 236 | **Technical Risk Assessment & Mitigation** |  |  | 25% → 27% |  |
| 240 | **Risk Mitigation Efforts** |  |  | 28% → 30% |  |
| 241 | **PSF Calibration** |  |  | 65% → 70% |  |
| 242 | Support/Monitor Profiler Implementation |  |  | 65% → 70% |  |
| 245 | Preliminary Design Manual | 2009-08-03 A |  | 0% → 8% |  |
| 246 | **AO System Design** |  |  | 25% → 27% |  |
| 248 | **Opto-Mechanical** |  |  | 30% → 32% |  |
| 252 | Optical Switchyard |  |  | 40% → 60% |  |
| 359 | **Real-time Control** |  |  | 39% → 43% |  |
| 360 | **RTC Processor** |  |  | 41% → 44% |  |
| 361 | RTC Technical Management |  |  | 45% → 50% |  |
| 362 | Centroid/Wavefront Reconstruction Processing Requirements |  |  | 40% → 50% |  |
| 368 | Layer Combining & DM Processing Requirements | 2009-06-01 A |  | 0% → 10% |  |
| 369 | Camera Data Transfer Issues |  |  | 35% → 40% |  |
| 370 | Radial versus Rectilinear Voxels Trade Study |  |  | 60% → 70% |  |
| 374 | Voxel Communication Parameters |  |  | 70% → 80% |  |
| 379 | **DMs & Tip/Tilt Stages** |  |  | 29% → 34% |  |
| 387 | **Tweeter DM/TT** |  |  | 37% → 47% |  |
| 388 | Define Requirements |  |  | 50% → 60% |  |
| 389 | Evaluate Options & Select Tip/Tilt Mount |  |  | 30% → 44% |  |
| 391 | Obtain Quotes |  |  | 50% → 60% |  |
| 392 | **LOWFS DM/TT** |  |  | 26% → 30% |  |
| 393 | Define Requirements including LOWFS Interface |  |  | 30% → 37% |  |
| 394 | Evaluate Options & Select Tip/Tilt Mount |  |  | 30% → 37% |  |
| 396 | Obtain Quotes |  |  | 50% → 55% |  |

| ID | Task | Start | Complete |
| --- | --- | --- | --- |
| 402 | **Laser System Design** |  | 30% → 39% |
| 428 | **Laser Launch Facility (LLF)** |  | 10% → 12% |
| 430 | LLF Optical Design | 2009-04-01 A | 0% → 10% |
| 435 | **Laser Safety Systems** |  | 11% → 50% |
| 436 | **Personnel & Equipment Safety System** |  | 17% → 50% |
| 437 | Safety Requirements & Interfaces | 2009-08-03 A | 0% → 50% |
| 438 | Safety Algorithms, Diagrams & Dataflow | 2009-08-17 A | 0% → 50% |
| 439 | Safety Communication Protocols & Methods |  | 40% → 50% |
| 440 | Safety Performance Estimate | 2009-08-17 A | 0% → 50% |
| 442 | Safety Test Plans | 2009-08-17 A | 0% → 50% |
| 443 | **Laser Traffic Control System (LTCS) Modifications** | 2009-10-05 A | 0% → 50% |
| 444 | LTCS Requirements & Interfaces | 2009-10-05 A | 0% → 50% |
| 445 | LTCS Algorithms, Diagrams & Dataflow | 2009-10-05 A | 0% → 50% |
| 446 | LTCS Communication Protocols & Methods | 2009-10-05 A | 0% → 50% |
| 447 | LTCS Performance Estimate | 2009-10-05 A | 0% → 50% |
| 448 | LTCS Test Plans | 2009-10-05 A | 0% → 50% |
